# Mobile Project Update v1

Schedule from MS Project, 2017-02-08 to 2018-12-31, status date 2018-06-18, costs in $, A marks actual dates.

## Calendars

- Standard: Mon-Fri 08:00-12:00, 13:00-17:00; Sat-Sun off.

## Resources

| Resource | Rate |
| --- | --- |
| Grey Heller | 1 |
| Modo | 1 |
| Debbie Henry/Cassandra Heavrin | 1 |
| Nhi Nguyen | 1 |
| Deanna Kreitz/Rainer Schuhsler | 1 |
| Dominic Johnson | 1 |
| Riod T | 1 |
| Rolana Starr/Cassandra Heavrin/Lety Gallegos | 1 |
| Alina Longoria | 1 |
| Briget Jans/Lety Gallegos | 1 |
| Shane Mills | 1 |
| Andy Stratz/Chris Durham | 1 |
| Admissions? | 1 |
| Rachel Honora | 1 |
| Mardel Maxwell/Rolana Starr | 1 |
| Limitations w/ various systems of record | 1 |
| Shibboleth /SAML vulnerability | 1 |
| LDAP | 1 |
| Riod Triantoro | 1 |
| Charita Hampton | 1 |
| Ali Dorton | 1 |
| CRITICAL TASK | 1 |
| These meetings are also listed under the Modo section of the plan | 1 |
| Kenny Mauk | 1 |
| Diane Trippel | 1 |
| Trippel | 1 |
| Deana Kreitz | 1 |
| Marketing | 1 |
| UIT | 1 |
| Keith Martin | 1 |
| Bob Marberry | 1 |
| Teri Longacre/Melissa Pierson | 1 |
| Cassandra Heavrin | 1 |
| Keidra Gaston/Vuong Pham | 1 |
| Rainer Schuhsler | 1 |
| Bob Marberry/Edu Balingasa | 1 |
| Deana Kreitz/Bob Marberry | 1 |
| Robert Birkline | 1 |
| Edu | 1 |
| Edu Ballingasa | 1 |
| Deron Frederickson | 1 |
| Keith Kowalka | 1 |
| Eric Holeman | 1 |
| Rosie Ashley | 1 |
| J Fisher | 1 |
| Rob Spragg | 1 |
| Leroy Mays | 1 |
| Need to get developer key | 1 |
| fix bugs | 1 |
| Rosies | 1 |
| Lawrence Daniel | 1 |
| Mark Rosanes | 1 |
| Kelly Boysen | 1 |
| Dan Olivaris | 1 |
| Al.i | 1 |
| Deborah Davis | 1 |

## Schedule

| ID | WBS | Task | Type | Duration | Start | Finish | Predecessors | Complete | Remaining | Actual start | Actual finish | Baseline start | Baseline finish | Baseline duration | Baseline 1 start | Baseline 1 finish | Total slack | Constraint | Resources | Work | Actual work | Cost | Actual cost | Text13 |
| --- | --- | --- | --- | --- | --- | --- | --- | --- | --- | --- | --- | --- | --- | --- | --- | --- | --- | --- | --- | --- | --- | --- | --- | --- |
| 1 | 1 | **UH Mobile Project** |  | 393.8d? | 2017-02-08 A | 2018-08-14 |  | 32% | 266.66d? |  |  | 2017-02-08 | 2018-09-03 | 408d? | 2017-02-08 | 2018-08-14 | 99.2d |  |  | 8950h | 3920.99h | 8,950 | 3,920.99 | 0.83 |
| 2 | 1.1 | **Establish Steering and Governance Structure** |  | 0d | 2017-04-03 A | 2017-04-03 A |  | 100% |  |  |  | 2017-04-03 | 2017-04-03 | 0d | 2017-04-03 | 2017-04-03 |  |  |  |  |  |  |  |  |
| 3 | 1.1.1 | Setup process to status these groups | milestone | 0d | 2017-04-03 A | 2017-04-03 A |  | 100% |  |  |  | 2017-04-03 | 2017-04-03 | 0d | 2017-04-03 | 2017-04-03 |  | finish no earlier than 2017-06-14 |  |  |  |  |  |  |
| 4 | 1.2 | **Acquire New Development platform (Modo and GH)** |  | 136d | 2017-06-08 A | 2017-12-14 A |  | 100% |  |  |  | 2017-06-08 | 2017-12-14 | 136d | 2017-06-08 | 2017-12-14 |  |  |  |  |  |  |  |  |
| 5 | 1.2.1 | **Modo** |  | 135d | 2017-06-09 A | 2017-12-14 A |  | 100% |  |  |  | 2017-06-09 | 2017-12-14 | 135d | 2017-06-09 | 2017-12-14 |  |  |  |  |  |  |  |  |
| 6 | 1.2.1.1 | Contract Package |  | 135d | 2017-06-09 A | 2017-12-14 A |  | 100% |  |  |  | 2017-06-09 | 2017-12-14 | 135d | 2017-06-09 | 2017-12-14 |  | finish no earlier than 2017-12-14 |  |  |  |  |  |  |
| 7 | 1.2.2 | **Grey Heller** |  | 88d | 2017-06-08 A | 2017-10-09 A |  | 100% |  |  |  | 2017-06-08 | 2017-10-09 | 88d | 2017-06-08 | 2017-10-09 |  |  |  |  |  |  |  |  |
| 8 | 1.2.2.1 | Sole Source for UHS |  | 88d | 2017-06-08 A | 2017-10-09 A |  | 100% |  |  |  | 2017-06-08 | 2017-10-09 | 88d | 2017-06-08 | 2017-10-09 |  | finish no earlier than 2017-10-09 |  |  |  |  |  |  |
| 9 | 1.3 | **Create Dedicated Mobile App Team** |  | 261d | 2017-02-08 | 2018-02-08 |  | 100% |  | 2017-05-30 | 2017-08-08 | 2017-02-08 | 2018-02-08 | 261d | 2017-02-08 | 2018-02-08 |  |  |  |  |  |  |  |  |
| 10 | 1.3.1 | Create Job Description |  | 23d | 2017-06-14 A | 2017-07-14 A |  | 100% |  |  |  | 2017-06-14 | 2017-07-14 | 23d | 2017-06-14 | 2017-07-14 |  | finish no earlier than 2017-07-14 |  |  |  |  |  |  |
| 11 | 1.3.2 | Post Job |  | 20d | 2017-07-12 A | 2017-08-08 A |  | 100% |  |  |  | 2017-07-12 | 2017-08-08 | 20d | 2017-07-12 | 2017-08-08 |  | finish no earlier than 2017-08-08 |  |  |  |  |  |  |
| 12 | 1.3.3 | Identify workspace |  | 4d | 2017-05-30 A | 2017-06-02 A |  | 100% |  |  |  | 2017-05-30 | 2017-06-02 | 4d | 2017-05-30 | 2017-06-02 |  | finish no earlier than 2017-06-02 |  |  |  |  |  |  |
| 13 | 1.3.4 | Create Team |  | 1d | 2017-07-24 A | 2017-07-24 A | 12 | 100% |  |  |  | 2017-07-24 | 2017-07-24 | 1d | 2017-07-24 | 2017-07-24 |  | finish no earlier than 2017-07-24 |  |  |  |  |  |  |
| 14 | 1.4 | **Engage Students** |  | 101d | 2017-10-05 A | 2018-02-22 A |  | 100% |  |  |  | 2017-10-05 | 2018-02-22 | 101d | 2017-10-05 | 2018-02-22 |  |  |  |  |  |  |  |  |
| 15 | 1.4.1 | Create Survey Questions |  | 3d | 2017-10-05 A | 2017-10-09 A |  | 100% |  |  |  | 2017-10-05 | 2017-10-09 | 3d | 2017-10-05 | 2017-10-09 |  | finish no earlier than 2017-10-09 |  |  |  |  |  |  |
| 16 | 1.4.2 | Create Accessuh Banner and Website Page |  | 2d | 2017-10-09 A | 2017-10-10 A |  | 100% |  |  |  | 2017-10-09 | 2017-10-10 | 2d | 2017-10-09 | 2017-10-10 |  | finish no earlier than 2017-10-10 |  |  |  |  |  |  |
| 17 | 1.4.3 | First focus group |  | 24d | 2017-10-09 A | 2017-11-09 A |  | 100% |  |  |  | 2017-10-09 | 2017-11-09 | 24d | 2017-10-09 | 2017-11-09 |  | finish no earlier than 2017-11-09 |  |  |  |  |  |  |
| 18 | 1.4.4 | Second Focus Group |  | 3d | 2017-12-06 A | 2017-12-08 A |  | 100% |  |  |  | 2017-12-06 | 2017-12-08 | 3d | 2017-12-06 | 2017-12-08 |  | finish no earlier than 2017-12-08 |  |  |  |  |  |  |
| 19 | 1.4.5 | Third Focus Group |  | 3d | 2018-02-20 A | 2018-02-22 A |  | 100% |  |  |  | 2018-02-20 | 2018-02-22 | 3d | 2018-02-20 | 2018-02-22 |  |  |  |  |  |  |  |  |
| 20 | 1.4.6 | Student Survey |  | 4d | 2017-12-08 A | 2017-12-13 A |  | 100% |  |  |  | 2017-12-08 | 2017-12-13 | 4d | 2017-12-08 | 2017-12-13 |  | finish no earlier than 2017-12-13 |  |  |  |  |  |  |
| 21 | 1.4.7 | Focus Group Final Report | manual | 49d | 2017-12-14 A | 2018-02-20 A |  | 100% |  |  |  | 2017-12-14 | 2018-02-20 | 49d | 2017-12-14 | 2018-02-20 |  |  |  |  |  |  |  |  |
| 22 | 1.5 | **Engage Stakeholders and Colleagues** |  | 72d? | 2017-12-14 A | 2018-03-23 A |  | 100% |  |  |  | 2017-12-14 | 2018-03-23 | 72d? | 2017-12-14 | 2018-03-23 |  |  |  | 32h | 32h | 32 | 32 |  |
| 23 | 1.5.1 | Strategy Meetings |  | 19d | 2017-12-14 A | 2018-01-09 A |  | 100% |  |  |  | 2017-12-14 | 2018-01-09 | 19d | 2017-12-14 | 2018-01-09 |  | finish no earlier than 2018-01-09 |  |  |  |  |  |  |
| 24 | 1.5.2 | Marketing Meeting |  | 1d | 2018-02-06 A | 2018-02-06 A |  | 100% |  |  |  | 2018-02-06 | 2018-02-06 | 1d | 2018-02-06 | 2018-02-06 |  | start no earlier than 2018-02-06 |  |  |  |  |  |  |
| 25 | 1.5.3 | Auxiliary Services Meeting |  | 1d | 2018-02-26 A | 2018-02-26 A |  | 100% |  |  |  | 2018-02-26 | 2018-02-26 | 1d | 2018-02-26 | 2018-02-26 |  | start no earlier than 2018-02-26 |  |  |  |  |  |  |
| 26 | 1.5.4 | Enrollment Services Meeting |  | 1d | 2018-02-06 A | 2018-02-06 A |  | 100% |  |  |  | 2018-02-06 | 2018-02-06 | 1d | 2018-02-06 | 2018-02-06 |  | start no earlier than 2018-02-06 |  |  |  |  |  |  |
| 27 | 1.5.5 | TouchNet Meeting |  | 1d | 2018-03-23 A | 2018-03-23 A |  | 100% |  |  |  | 2018-03-23 | 2018-03-23 | 1d | 2018-03-23 | 2018-03-23 |  | finish no earlier than 2018-03-23 | These meetings are also listed under the Modo section of the plan | 8h | 8h | 8 | 8 |  |
| 28 | 1.5.6 | Housing Meeting |  | 10d? | 2018-03-12 A | 2018-03-23 A |  | 100% |  |  |  | 2018-03-12 | 2018-03-23 | 10d? | 2018-03-12 | 2018-03-23 |  | finish no earlier than 2018-03-23 |  |  |  |  |  |  |
| 29 | 1.5.7 | EAB Guide Meeting |  | 10d? | 2018-03-12 A | 2018-03-23 A |  | 100% |  |  |  | 2018-03-12 | 2018-03-23 | 10d? | 2018-03-12 | 2018-03-23 |  | finish no earlier than 2018-03-23 |  |  |  |  |  |  |
| 30 | 1.5.8 | Credentials / Authentication / Security [Placeholder] |  | 1d? | 2018-02-20 A | 2018-02-20 A |  | 100% |  |  |  | 2018-02-20 | 2018-02-20 | 1d? | 2018-02-20 | 2018-02-20 |  |  | Limitations w/ various systems of record; Shibboleth /SAML vulnerability; LDAP | 24h | 24h | 24 | 24 |  |
| 31 | 1.5.9 | Production Schedule [Placeholder] |  | 1d? | 2018-02-20 A | 2018-02-20 A |  | 100% |  |  |  | 2018-02-20 | 2018-02-20 | 1d? | 2018-02-20 | 2018-02-20 |  |  |  |  |  |  |  |  |

| ID | WBS | Task | Type | Duration | Start | Finish | Predecessors | Baseline start | Baseline finish | Baseline duration | Baseline 1 start | Baseline 1 finish | Total slack | Free slack | Constraint | Resources | Work | Cost | Text11 | Text13 | Project Plan Phase |
| --- | --- | --- | --- | --- | --- | --- | --- | --- | --- | --- | --- | --- | --- | --- | --- | --- | --- | --- | --- | --- | --- |
| 32 | 1.6 | **Grey Heller Implementation** |  | 125.8d? | 2018-02-20 | 2018-08-14 |  | 2018-02-20 | 2018-07-27 | 114d? | 2018-02-20 | 2018-08-14 |  |  |  |  | 2768h | 2,768 | GH | 0.81 |  |
| 33 | 1.6.1 | **Current Students** |  | 123d? | 2018-02-20 | 2018-08-09 |  | 2018-02-20 | 2018-07-27 | 114d? | 2018-02-20 | 2018-08-14 |  |  |  |  | 2768h | 2,768 | GH | 0.81 |  |
| 34 | 1.6.1.1 | **Phase 0 - Grades, Schedule, Add, Drop, Swap** |  | 107.7d? | 2018-02-20 | 2018-07-19 |  | 2018-02-20 | 2018-07-09 | 100d? | 2018-02-20 | 2018-07-19 |  |  |  |  | 984h | 984 | GH |  | P0 |
| 35 | 1.6.1.1.1 | Install |  | 64d? | 2018-02-20 | 2018-05-18 |  | 2018-02-20 | 2018-05-18 | 64d? | 2018-02-20 | 2018-05-18 | 161d | 21d | finish no earlier than 2018-05-18 | Charita Hampton | 512h | 512 | GH |  | P0 |
| 36 | 1.6.1.1.2 | Class Search | milestone | 0d | 2018-06-18 | 2018-06-18 | 35 | 2018-05-21 | 2018-05-25 | 5d | 2018-06-19 | 2018-06-25 | 140d |  | start no earlier than 2018-06-18 |  |  |  | GH |  | P0 |
| 37 | 1.6.1.1.3 | Academic Records: View My Grades | milestone | 0d | 2018-06-18 | 2018-06-18 |  | 2018-05-21 | 2018-05-25 | 5d | 2018-06-19 | 2018-06-25 | 140d |  | start no earlier than 2018-06-18 |  |  |  | GH |  | P0 |
| 38 | 1.6.1.1.4 | Academic Records: My Class Schedule |  | 1d? | 2018-06-19 | 2018-06-19 |  | 2018-05-21 | 2018-05-25 | 5d | 2018-06-19 | 2018-06-25 | 139d |  | start no earlier than 2018-06-18 |  |  |  | GH |  | P0 |
| 39 | 1.6.1.1.5 | Academic Records: Enrollment: Add Classes |  | 1d? | 2018-06-19 | 2018-06-19 |  | 2018-05-21 | 2018-05-25 | 5d | 2018-06-19 | 2018-06-25 | 139d |  | start no earlier than 2018-06-18 |  |  |  | GH |  | P0 |
| 40 | 1.6.1.1.6 | Academic Records: Enrollment: Drop Classes |  | 1d? | 2018-06-19 | 2018-06-19 |  | 2018-05-21 | 2018-05-25 | 5d | 2018-06-19 | 2018-06-25 | 139d |  | start no earlier than 2018-06-18 |  |  |  | GH |  | P0 |
| 41 | 1.6.1.1.7 | Navigation | manual | 1d? | 2018-02-20 | 2018-02-20 |  |  |  |  | 2018-02-20 | 2018-02-26 |  |  | start no earlier than 2018-06-18 |  |  |  | GH |  |  |
| 42 | 1.6.1.1.8 | Tiling | manual | 1d? | 2018-02-20 | 2018-02-20 |  |  |  |  | 2018-02-20 | 2018-02-26 |  |  | start no earlier than 2018-06-18 |  |  |  | GH |  |  |
| 43 | 1.6.1.1.9 | Branding | manual | 1d? | 2018-02-20 | 2018-02-20 |  |  |  |  | 2018-02-20 | 2018-02-20 |  |  | start no earlier than 2018-06-18 |  |  |  | GH |  |  |
| 44 | 1.6.1.1.10 | Student Center: Shopping Cart |  | 1d? | 2018-06-19 | 2018-06-19 |  | 2018-05-21 | 2018-05-25 | 5d | 2018-06-19 | 2018-06-25 | 139d |  | start no earlier than 2018-06-18 |  |  |  | GH |  | P0 |
| 45 | 1.6.1.1.11 | Student Center: Enroll - Swap a Class |  | 1d? | 2018-06-19 | 2018-06-19 |  | 2018-05-21 | 2018-05-25 | 5d | 2018-06-19 | 2018-06-25 | 139d |  | start no earlier than 2018-06-18 |  |  |  | GH |  | P0 |
| 46 | 1.6.1.1.12 | Firewall Configuration for Modo Integration |  | 1d | 2018-02-20 | 2018-02-20 |  | 2018-02-20 | 2018-02-20 | 1d | 2018-02-20 | 2018-02-20 | 224d |  | finish no earlier than 2018-02-20 | Charita Hampton | 8h | 8 | GH |  | P0 |
| 47 | 1.6.1.1.13 | **Testing** |  | 100.7d? | 2018-03-01 | 2018-07-19 |  | 2018-03-01 | 2018-07-09 | 93d? | 2018-03-01 | 2018-07-19 |  |  |  |  | 464h | 464 | GH | 0.99 |  |
| 48 | 1.6.1.1.13.1 | Set up test accounts |  | 8d | 2018-03-01 | 2018-03-12 |  | 2018-03-01 | 2018-03-12 | 8d | 2018-03-01 | 2018-03-12 | 210d |  | finish no earlier than 2018-03-12 | Charita Hampton | 64h | 64 | GH |  |  |
| 49 | 1.6.1.1.13.2 | Identify testers |  | 44d? | 2018-03-01 | 2018-05-01 |  | 2018-03-01 | 2018-05-01 | 44d? | 2018-03-01 | 2018-05-01 | 174d |  | finish no earlier than 2018-05-01 | Charita Hampton | 352h | 352 | GH |  |  |
| 50 | 1.6.1.1.13.3 | Perform Dev Test |  | 6d? | 2018-06-08 | 2018-06-21 |  | 2018-05-21 | 2018-05-25 | 5d? | 2018-06-08 | 2018-06-21 | 131.3d | 0.3d | start no earlier than 2018-06-08 | Nhi Nguyen | 48h | 48 | GH | 1.2 |  |
| 51 | 1.6.1.1.13.4 | Perform UI/UX Test |  | 1d? | 2018-06-22 | 2018-06-22 | 50 | 2018-05-28 | 2018-06-15 | 15d? | 2018-06-21 | 2018-06-28 | 131d | 9d | finish no earlier than 2018-06-22 |  |  |  | GH | 0.33 |  |
| 52 | 1.6.1.1.13.5 | Perform BO Functional Test |  | 1d? | 2018-07-06 | 2018-07-06 | 51 | 2018-06-18 | 2018-07-02 | 11d? | 2018-06-28 | 2018-07-12 | 122d | 0d | finish no earlier than 2018-07-06 |  |  |  | GH | 0.91 |  |
| 53 | 1.6.1.1.13.6 | Perform Usability Test |  | 1d? | 2018-07-09 | 2018-07-09 | 52 | 2018-07-03 | 2018-07-09 | 5d? | 2018-07-12 | 2018-07-19 | 122d | 0d | finish no earlier than 2018-07-09 |  |  |  | GH |  |  |
| 54 | 1.6.1.1.14 | **Migrations** |  | 1d? | 2018-07-10 | 2018-07-10 |  | 2018-05-28 | 2018-05-28 | 1d? | 2018-07-10 | 2018-07-12 |  |  |  |  |  |  | GH | 1.5 |  |
| 55 | 1.6.1.1.14.1 | Move to TEST | manual | 1d? | 2018-07-10 | 2018-07-10 | 53 | 2018-05-28 | 2018-05-28 | 1d? | 2018-07-10 | 2018-07-10 |  |  |  |  |  |  | GH |  |  |
| 56 | 1.6.1.1.14.2 | Move to Production |  | 1d? | 2018-07-11 | 2018-07-11 | 55 | 2018-05-28 | 2018-05-28 | 1d? | 2018-07-11 | 2018-07-11 | 122d | 0d | start no earlier than 2018-05-28 |  |  |  | GH |  |  |
| 57 | 1.6.1.1.14.3 | MS: Phase 0 Completed | manual | 1d? | 2018-07-12 | 2018-07-12 | 56 |  |  |  | 2018-07-12 | 2018-07-12 |  |  |  |  |  |  | GH |  |  |

| ID | WBS | Task | Type | Duration | Start | Finish | Predecessors | Baseline start | Baseline finish | Baseline duration | Baseline 1 start | Baseline 1 finish | Total slack | Free slack | Constraint | Resources | Work | Cost | Project Plan Phase | Text11 | Text13 |
| --- | --- | --- | --- | --- | --- | --- | --- | --- | --- | --- | --- | --- | --- | --- | --- | --- | --- | --- | --- | --- | --- |
| 58 | 1.6.1.2 | **Phase 1 - Personal Information** |  | 97d? | 2018-03-01 | 2018-07-13 |  | 2018-03-01 | 2018-07-09 | 93d? | 2018-03-01 | 2018-07-17 |  |  |  |  | 472h | 472 | P1 | GH | 0.93 |
| 59 | 1.6.1.2.1 | Personal Info: Emergency Contacts |  | 1d? | 2018-06-19 | 2018-06-19 |  | 2018-05-18 | 2018-05-18 | 1d | 2018-06-19 | 2018-06-19 | 139d |  | start no earlier than 2018-06-18 |  |  |  | P1 | GH |  |
| 60 | 1.6.1.2.2 | Personal Info: Personal Information Acknowledgement Pop-Up |  | 1d? | 2018-06-19 | 2018-06-19 |  | 2018-05-18 | 2018-05-18 | 1d? | 2018-06-19 | 2018-06-19 | 139d |  | start no earlier than 2018-06-18 |  |  |  | P1 | GH |  |
| 61 | 1.6.1.2.3 | Personal Info: Campus Emergency Notification |  | 1d? | 2018-06-19 | 2018-06-19 |  | 2018-05-18 | 2018-05-18 | 1d? | 2018-06-19 | 2018-06-19 | 139d |  | start no earlier than 2018-06-18 |  |  |  | P1 | GH |  |
| 62 | 1.6.1.2.4 | Personal Info: To Do List |  | 1d? | 2018-06-19 | 2018-06-19 |  | 2018-05-18 | 2018-05-18 | 1d? | 2018-06-19 | 2018-06-19 | 139d |  | start no earlier than 2018-06-18 |  |  |  | P1 | GH |  |
| 63 | 1.6.1.2.5 | Personal Info: Setup Security Questions |  | 1d? | 2018-06-19 | 2018-06-19 |  | 2018-05-18 | 2018-05-18 | 1d? | 2018-06-19 | 2018-06-19 | 139d |  | start no earlier than 2018-06-18 |  |  |  | P1 | GH |  |
| 64 | 1.6.1.2.6 | Personal Info: Contact Details |  | 1d? | 2018-06-19 | 2018-06-19 |  | 2018-05-18 | 2018-05-18 | 1d? | 2018-06-19 | 2018-06-19 | 139d |  | start no earlier than 2018-06-18 |  |  |  | P1 | GH |  |
| 65 | 1.6.1.2.7 | Personal Info: My Holds |  | 1d? | 2018-06-19 | 2018-06-19 |  | 2018-05-18 | 2018-05-18 | 1d? | 2018-06-19 | 2018-06-19 | 139d |  | start no earlier than 2018-06-18 |  |  |  | P1 | GH |  |
| 66 | 1.6.1.2.8 | Personal Info: My Personalizations (Campus Preferences) | manual | 1d? | 2018-03-01 | 2018-03-01 |  |  |  |  | 2018-03-01 | 2018-03-01 |  |  | start no earlier than 2018-06-18 |  |  |  |  | GH |  |
| 67 | 1.6.1.2.9 | Personal Info: Addresses |  | 1d? | 2018-06-19 | 2018-06-19 |  | 2018-05-18 | 2018-05-18 | 1d? | 2018-06-19 | 2018-06-19 | 139d |  | start no earlier than 2018-06-18 |  |  |  | P1 | GH |  |
| 68 | 1.6.1.2.10 | Personal Info: Password Reset |  | 1d? | 2018-06-19 | 2018-06-19 |  | 2018-05-18 | 2018-05-18 | 1d? | 2018-06-19 | 2018-06-19 | 139d |  | start no earlier than 2018-06-18 |  |  |  | P1 | GH |  |
| 69 | 1.6.1.2.11 | Personal Info: Privacy Settings |  | 1d? | 2018-06-19 | 2018-06-19 |  | 2018-05-18 | 2018-05-18 | 1d? | 2018-06-19 | 2018-06-19 | 139d |  | start no earlier than 2018-06-18 |  |  |  | P1 | GH |  |
| 70 | 1.6.1.2.12 | Personal Info: Personal Details |  | 1d? | 2018-06-19 | 2018-06-19 |  | 2018-05-18 | 2018-05-18 | 1d? | 2018-06-19 | 2018-06-19 | 139d |  | start no earlier than 2018-06-18 |  |  |  | P1 | GH |  |
| 71 | 1.6.1.2.13 | Personal Info: Ethnicity |  | 1d? | 2018-06-19 | 2018-06-19 |  | 2018-05-18 | 2018-05-18 | 1d? | 2018-06-19 | 2018-06-19 | 139d |  | start no earlier than 2018-06-18 |  |  |  | P1 | GH |  |
| 72 | 1.6.1.2.14 | **Testing** |  | 97d? | 2018-03-01 | 2018-07-13 |  | 2018-03-01 | 2018-07-09 | 93d? | 2018-03-01 | 2018-07-17 | 121d |  |  |  | 472h | 472 |  | GH | 0.97 |
| 73 | 1.6.1.2.14.1 | Set up test accounts |  | 8d? | 2018-03-01 | 2018-03-12 |  | 2018-03-01 | 2018-03-12 | 8d? | 2018-03-01 | 2018-03-12 | 210d |  | finish no earlier than 2018-03-12 | Charita Hampton | 64h | 64 |  | GH |  |
| 74 | 1.6.1.2.14.2 | Identify testers |  | 44d? | 2018-03-01 | 2018-05-01 |  | 2018-03-01 | 2018-05-01 | 44d? | 2018-03-01 | 2018-05-01 | 174d |  | finish no earlier than 2018-05-01 | Charita Hampton | 352h | 352 |  | GH |  |
| 75 | 1.6.1.2.14.3 | Perform Dev Test |  | 7d? | 2018-06-06 | 2018-06-18 |  | 2018-05-21 | 2018-05-25 | 5d? | 2018-06-08 | 2018-06-20 | 119d | 0d | finish no earlier than 2018-06-18 | Nhi Nguyen | 56h | 56 |  | GH | 1.4 |
| 76 | 1.6.1.2.14.4 | Perform UI/UX Test |  | 4d? | 2018-06-19 | 2018-06-22 | 75 | 2018-05-28 | 2018-06-15 | 15d? | 2018-06-20 | 2018-06-26 | 119d | 0d | finish no earlier than 2018-06-22 |  |  |  |  | GH | 0.27 |
| 77 | 1.6.1.2.14.5 | Perform Functional Test |  | 10d? | 2018-06-25 | 2018-07-06 | 76 | 2018-06-18 | 2018-07-02 | 11d? | 2018-06-26 | 2018-07-10 | 119d | 0d | finish no earlier than 2018-07-06 |  |  |  |  | GH | 0.91 |
| 78 | 1.6.1.2.14.6 | Perform Usability Test |  | 5d? | 2018-07-09 | 2018-07-13 | 77 | 2018-07-03 | 2018-07-09 | 5d? | 2018-07-10 | 2018-07-17 | 119d | 0d | finish no earlier than 2018-07-09 |  |  |  |  | GH |  |
| 79 | 1.6.1.2.15 | **Migrations** |  | 2d? | 2018-07-10 | 2018-07-12 |  | 2018-06-11 | 2018-07-02 | 16d? | 2018-07-10 | 2018-07-12 | 0d |  |  |  |  |  |  | GH | 0.22 |
| 80 | 1.6.1.2.15.1 | Move to TEST | manual | 1d | 2018-07-10 | 2018-07-10 | 78 | 2018-06-11 | 2018-06-11 | 1d | 2018-07-10 | 2018-07-10 |  |  |  |  |  |  |  | GH |  |
| 81 | 1.6.1.2.15.2 | Move to Production |  | 1d? | 2018-07-11 | 2018-07-11 | 80 | 2018-07-02 | 2018-07-02 | 1d? | 2018-07-11 | 2018-07-11 | 123d | 0d | start no earlier than 2018-07-02 |  |  |  |  | GH |  |
| 82 | 1.6.1.2.15.3 | MS: Phase 1 Completed | milestone, manual | 0d | 2018-07-12 | 2018-07-12 | 81 |  |  |  | 2018-07-12 | 2018-07-12 |  |  |  |  |  |  |  | GH |  |

| ID | WBS | Task | Type | Duration | Start | Finish | Predecessors | Baseline start | Baseline finish | Baseline duration | Baseline 1 start | Baseline 1 finish | Total slack | Free slack | Constraint | Resources | Work | Cost | Project Plan Phase | Text11 | Text13 |
| --- | --- | --- | --- | --- | --- | --- | --- | --- | --- | --- | --- | --- | --- | --- | --- | --- | --- | --- | --- | --- | --- |
| 83 | 1.6.1.3 | **Phase 2 - Financial Aid** |  | 116d? | 2018-03-01 | 2018-08-09 |  | 2018-03-01 | 2018-07-27 | 107d? | 2018-03-01 | 2018-08-14 | 78d |  |  |  | 472h | 472 | P2 | GH | 1.04 |
| 84 | 1.6.1.3.1 | Financial Aid: To Do List |  | 1d | 2018-06-19 | 2018-06-19 |  | 2018-05-18 | 2018-05-18 | 1d | 2018-06-19 | 2018-06-19 | 139d |  | start no earlier than 2018-06-18 |  |  |  | P2 | GH |  |
| 85 | 1.6.1.3.2 | Financial Aid: Accept/Decline Awards |  | 1d? | 2018-06-19 | 2018-06-19 |  | 2018-05-18 | 2018-05-18 | 1d? | 2018-06-19 | 2018-06-19 | 139d |  | start no earlier than 2018-06-18 |  |  |  | P2 | GH |  |
| 86 | 1.6.1.3.3 | Financial Aid: View Financial Aid |  | 1d? | 2018-06-19 | 2018-06-19 |  | 2018-05-18 | 2018-05-18 | 1d? | 2018-06-19 | 2018-06-19 | 139d |  | start no earlier than 2018-06-18 |  |  |  | P2 | GH |  |
| 87 | 1.6.1.3.4 | Financial Aid: Intended Enrollment Form |  | 1d? | 2018-06-19 | 2018-06-19 |  | 2018-05-18 | 2018-05-18 | 1d? | 2018-06-19 | 2018-06-19 | 139d |  | start no earlier than 2018-06-18 |  |  |  | P2 | GH |  |
| 88 | 1.6.1.3.5 | Financial Aid: Apply for UH Scholarships |  | 1d? | 2018-06-19 | 2018-06-19 |  | 2018-05-18 | 2018-05-18 | 1d? | 2018-06-19 | 2018-06-19 | 139d |  | start no earlier than 2018-06-18 |  |  |  | P2 | GH |  |
| 89 | 1.6.1.3.6 | **Testing** |  | 116d? | 2018-03-01 | 2018-08-09 |  | 2018-03-01 | 2018-07-27 | 107d? | 2018-03-01 | 2018-08-14 | 102d |  |  |  | 472h | 472 |  | GH | 1.03 |
| 90 | 1.6.1.3.6.1 | Set up test accounts |  | 8d? | 2018-03-01 | 2018-03-12 |  | 2018-03-01 | 2018-03-12 | 8d? | 2018-03-01 | 2018-03-12 | 210d |  | finish no earlier than 2018-03-12 | Charita Hampton | 64h | 64 |  | GH |  |
| 91 | 1.6.1.3.6.2 | Identify testers |  | 44d? | 2018-03-01 | 2018-05-01 |  | 2018-03-01 | 2018-05-01 | 44d? | 2018-03-01 | 2018-05-01 | 174d |  | finish no earlier than 2018-05-01 | Charita Hampton | 352h | 352 |  | GH |  |
| 92 | 1.6.1.3.6.3 | Perform Dev Test |  | 7d? | 2018-06-05 | 2018-06-18 |  | 2018-05-21 | 2018-05-25 | 5d? | 2018-06-08 | 2018-06-21 | 102d | 0d | finish no earlier than 2018-06-18 | Alina Longoria | 56h | 56 |  | GH | 1.4 |
| 93 | 1.6.1.3.6.4 | Perform UI/UX Test |  | 4d? | 2018-06-19 | 2018-06-22 | 92 | 2018-05-28 | 2018-06-08 | 10d? | 2018-06-21 | 2018-06-27 | 102d | 0d | finish no earlier than 2018-06-22 |  |  |  |  | GH | 0.4 |
| 94 | 1.6.1.3.6.5 | Perform Functional Test |  | 10d? | 2018-06-25 | 2018-07-06 | 93 | 2018-06-11 | 2018-06-25 | 11d? | 2018-06-27 | 2018-07-11 | 102d | 0d | finish no earlier than 2018-07-06 |  |  |  |  | GH | 0.91 |
| 95 | 1.6.1.3.6.6 | Perform Usability Test |  | 24d? | 2018-07-09 | 2018-08-09 | 94 | 2018-06-26 | 2018-07-27 | 24d? | 2018-07-11 | 2018-08-14 | 102d |  | finish no earlier than 2018-06-01 |  |  |  |  | GH |  |
| 96 | 1.6.1.3.7 | **Migrations** |  | 10d? | 2018-06-19 | 2018-07-02 |  | 2018-06-11 | 2018-07-02 | 16d? | 2018-06-19 | 2018-07-02 | 0d |  |  |  |  |  |  | GH | 0.67 |
| 97 | 1.6.1.3.7.1 | Move to TEST | manual | 1d | 2018-06-19 | 2018-06-19 |  | 2018-06-11 | 2018-06-11 | 1d | 2018-06-19 | 2018-06-19 |  |  |  |  |  |  |  | GH |  |
| 98 | 1.6.1.3.7.2 | Move to Production |  | 1d? | 2018-07-02 | 2018-07-02 |  | 2018-07-02 | 2018-07-02 | 1d? | 2018-07-02 | 2018-07-02 | 130d |  | start no earlier than 2018-07-02 |  |  |  |  | GH |  |
| 99 | 1.6.1.3.7.3 | MS: Phase 2 Completed | manual | 1d? | 2018-06-19 | 2018-06-19 |  |  |  |  | 2018-06-19 | 2018-06-19 |  |  | start no earlier than 2018-06-18 |  |  |  |  | GH |  |
| 100 | 1.6.1.4 | **Phase 3 - Academic Records, Enrollment** |  | 99d? | 2018-03-01 | 2018-07-17 |  | 2018-03-01 | 2018-07-10 | 94d? | 2018-03-01 | 2018-07-18 | 0d |  |  |  | 424h | 424 | P3 | GH | 0.94 |
| 101 | 1.6.1.4.1 | Academic Records: Enrollment Dates |  | 1d | 2018-06-19 | 2018-06-19 |  | 2018-05-18 | 2018-05-18 | 1d | 2018-06-19 | 2018-06-19 | 139d |  | start no earlier than 2018-06-18 |  |  |  | P3 | GH |  |
| 102 | 1.6.1.4.2 | Academic Records: View AAEC Approval Status |  | 1d? | 2018-06-19 | 2018-06-19 |  | 2018-05-18 | 2018-05-18 | 1d? | 2018-06-19 | 2018-06-19 | 139d |  | start no earlier than 2018-06-18 |  |  |  | P3 | GH |  |
| 103 | 1.6.1.4.3 | Academic Records: Forward Form to Faculty |  | 1d? | 2018-06-19 | 2018-06-19 |  | 2018-05-18 | 2018-05-18 | 1d? | 2018-06-19 | 2018-06-19 | 139d |  | start no earlier than 2018-06-18 |  |  |  | P3 | GH |  |
| 104 | 1.6.1.4.4 | Academic Records: Browse Catalog |  | 1d? | 2018-06-19 | 2018-06-19 |  | 2018-05-18 | 2018-05-18 | 1d? | 2018-06-19 | 2018-06-19 | 139d |  | start no earlier than 2018-06-18 |  |  |  | P3 | GH |  |
| 105 | 1.6.1.4.5 | Academic Records: View Unofficial Transcript |  | 1d? | 2018-06-19 | 2018-06-19 |  | 2018-05-18 | 2018-05-18 | 1d? | 2018-06-19 | 2018-06-19 | 139d |  | start no earlier than 2018-06-18 |  |  |  | P3 | GH |  |
| 106 | 1.6.1.4.6 | Academic Records: UH_Official_Transcript |  | 1d? | 2018-06-19 | 2018-06-19 |  | 2018-05-18 | 2018-05-18 | 1d? | 2018-06-19 | 2018-06-19 | 139d |  | start no earlier than 2018-06-18 |  |  |  | P3 | GH |  |
| 107 | 1.6.1.4.7 | Academic Records: Request Enrollment Verification |  | 1d? | 2018-06-19 | 2018-06-19 |  | 2018-05-18 | 2018-05-18 | 1d? | 2018-06-19 | 2018-06-19 | 139d |  | start no earlier than 2018-06-18 |  |  |  | P3 | GH |  |
| 108 | 1.6.1.4.8 | Advising: Apply for Graduation | manual | 1d? | 2018-03-01 | 2018-03-01 |  |  |  |  | 2018-03-01 | 2018-03-01 |  |  | start no earlier than 2018-06-18 |  |  |  |  | GH |  |
| 109 | 1.6.1.4.9 | Academic Records: Request Term Withdrawal |  | 1d? | 2018-06-19 | 2018-06-19 |  | 2018-05-18 | 2018-05-18 | 1d? | 2018-06-19 | 2018-06-19 | 139d |  | start no earlier than 2018-06-18 |  |  |  | P3 | GH |  |
| 110 | 1.6.1.4.10 | Academic Records: View Faculty Approval Status |  | 1d? | 2018-06-19 | 2018-06-19 |  | 2018-05-18 | 2018-05-18 | 1d? | 2018-06-19 | 2018-06-19 | 139d |  | start no earlier than 2018-06-18 |  |  |  | P3 | GH |  |
| 111 | 1.6.1.4.11 | Academic Records: View My Weekly Schedule |  | 1d? | 2018-06-19 | 2018-06-19 |  | 2018-05-18 | 2018-05-18 | 1d? | 2018-06-19 | 2018-06-19 | 139d |  | start no earlier than 2018-06-18 |  |  |  | P3 | GH |  |
| 112 | 1.6.1.4.12 | Academic Records: View Transfer Credit Report |  | 1d? | 2018-06-19 | 2018-06-19 |  | 2018-05-18 | 2018-05-18 | 1d? | 2018-06-19 | 2018-06-19 | 139d |  | start no earlier than 2018-06-18 |  |  |  | P3 | GH |  |
| 113 | 1.6.1.4.13 | Academic Records: Class Search |  | 1d? | 2018-06-19 | 2018-06-19 |  | 2018-05-18 | 2018-05-18 | 1d? | 2018-06-19 | 2018-06-19 | 139d |  | start no earlier than 2018-06-18 |  |  |  | P3 | GH |  |
| 114 | 1.6.1.4.14 | Student Center: Schedule Planner |  | 1d? | 2018-06-19 | 2018-06-19 |  | 2018-05-18 | 2018-05-18 | 1d? | 2018-06-19 | 2018-06-19 | 139d |  | start no earlier than 2018-06-18 |  |  |  | P3 | GH |  |
| 115 | 1.6.1.4.15 | Student Center: My Planner |  | 1d? | 2018-06-19 | 2018-06-19 |  | 2018-05-18 | 2018-05-18 | 1d? | 2018-06-19 | 2018-06-19 | 139d |  | start no earlier than 2018-06-18 |  |  |  | P3 | GH |  |

Notes:
- 108: Why is this in SF twice

| ID | WBS | Task | Type | Duration | Start | Finish | Predecessors | Baseline start | Baseline finish | Baseline duration | Baseline 1 start | Baseline 1 finish | Total slack | Free slack | Constraint | Resources | Work | Cost | Text11 | Text13 | Project Plan Phase |
| --- | --- | --- | --- | --- | --- | --- | --- | --- | --- | --- | --- | --- | --- | --- | --- | --- | --- | --- | --- | --- | --- |
| 116 | 1.6.1.4.16 | **Testing** |  | 99d? | 2018-03-01 | 2018-07-17 |  | 2018-03-01 | 2018-07-10 | 94d? | 2018-03-01 | 2018-07-18 | 119d |  |  |  | 424h | 424 | GH | 0.96 |  |
| 117 | 1.6.1.4.16.1 | Set up test accounts |  | 8d? | 2018-03-01 | 2018-03-12 |  | 2018-03-01 | 2018-03-12 | 8d? | 2018-03-01 | 2018-03-12 | 210d |  | finish no earlier than 2018-03-12 | Charita Hampton | 64h | 64 | GH |  |  |
| 118 | 1.6.1.4.16.2 | Identify testers |  | 44d? | 2018-03-01 | 2018-05-01 |  | 2018-03-01 | 2018-05-01 | 44d? | 2018-03-01 | 2018-05-01 | 174d |  | finish no earlier than 2018-05-01 | Charita Hampton | 352h | 352 | GH |  |  |
| 119 | 1.6.1.4.16.3 | Perform Dev Test |  | 1d? | 2018-06-08 | 2018-06-08 |  | 2018-05-21 | 2018-06-08 | 15d? | 2018-06-08 | 2018-06-19 | 125d | 6d | start no earlier than 2018-06-08 | Nhi Nguyen | 8h | 8 | GH | 0.07 |  |
| 120 | 1.6.1.4.16.4 | Perform UI/UX Test |  | 10d? | 2018-06-19 | 2018-07-02 | 119 | 2018-06-11 | 2018-06-22 | 10d? | 2018-06-19 | 2018-07-03 | 119d | 0d | start no earlier than 2018-06-18 |  |  |  | GH |  |  |
| 121 | 1.6.1.4.16.5 | Perform Functional Test |  | 11d? | 2018-07-03 | 2018-07-17 | 120 | 2018-06-25 | 2018-07-09 | 11d? | 2018-07-03 | 2018-07-18 | 119d |  |  |  |  |  | GH |  |  |
| 122 | 1.6.1.4.16.6 | Perform Usability Test |  | 7d? | 2018-07-02 | 2018-07-10 |  | 2018-07-02 | 2018-07-10 | 7d? | 2018-07-02 | 2018-07-10 | 122d | 0d | finish no earlier than 2018-07-10 |  |  |  | GH |  |  |
| 123 | 1.6.1.4.17 | **Migrations** |  | 2d? | 2018-07-11 | 2018-07-13 |  | 2018-06-11 | 2018-07-02 | 16d? | 2018-07-11 | 2018-07-13 | 0d |  |  |  |  |  | GH | 0.22 |  |
| 124 | 1.6.1.4.17.1 | Move to TEST | manual | 1d | 2018-07-11 | 2018-07-11 | 122 | 2018-06-11 | 2018-06-11 | 1d | 2018-07-11 | 2018-07-11 |  |  |  |  |  |  | GH |  |  |
| 125 | 1.6.1.4.17.2 | Move to Production |  | 1d? | 2018-07-12 | 2018-07-12 | 124 | 2018-07-02 | 2018-07-02 | 1d? | 2018-07-12 | 2018-07-12 | 122d | 0d | start no earlier than 2018-07-02 |  |  |  | GH |  |  |
| 126 | 1.6.1.4.17.3 | MS: Phase 3 Completed | milestone, manual | 0d | 2018-07-13 | 2018-07-13 | 125 |  |  |  | 2018-07-13 | 2018-07-13 |  |  |  |  |  |  | GH |  |  |
| 127 | 1.6.1.5 | **Phase 4 - Student Financials** |  | 96d? | 2018-03-01 | 2018-07-13 |  | 2018-03-01 | 2018-07-10 | 94d? | 2018-03-01 | 2018-07-13 | 0d |  |  |  | 416h | 416 | GH | 0.92 | P4 |
| 128 | 1.6.1.5.1 | Student Financials: Account Summary |  | 1d | 2018-06-19 | 2018-06-19 |  | 2018-05-18 | 2018-05-18 | 1d | 2018-06-19 | 2018-06-19 | 139d |  | start no earlier than 2018-06-18 |  |  |  | GH |  | P4 |
| 129 | 1.6.1.5.2 | Student Financials: Pending Financial Aid |  | 1d? | 2018-06-19 | 2018-06-19 |  | 2018-05-18 | 2018-05-18 | 1d? | 2018-06-19 | 2018-06-19 | 139d |  | start no earlier than 2018-06-18 |  |  |  | GH |  | P4 |
| 130 | 1.6.1.5.3 | Student Financials: BOA-Velocity Payment Page for Credit Cards linked from above |  | 1d? | 2018-06-19 | 2018-06-19 |  | 2018-05-18 | 2018-05-18 | 1d? | 2018-06-19 | 2018-06-19 | 139d |  | start no earlier than 2018-06-18 |  |  |  | GH |  | P4 |
| 131 | 1.6.1.5.4 | Student Financials: Charges Due |  | 1d? | 2018-06-19 | 2018-06-19 |  | 2018-05-18 | 2018-05-18 | 1d? | 2018-06-19 | 2018-06-19 | 139d |  | start no earlier than 2018-06-18 |  |  |  | GH |  | P4 |
| 132 | 1.6.1.5.5 | Student Financials: Account Balance |  | 1d? | 2018-06-19 | 2018-06-19 |  | 2018-05-18 | 2018-05-18 | 1d? | 2018-06-19 | 2018-06-19 | 139d |  | start no earlier than 2018-06-18 |  |  |  | GH |  | P4 |
| 133 | 1.6.1.5.6 | Student Financials: Payment Plans |  | 1d? | 2018-06-19 | 2018-06-19 |  | 2018-05-18 | 2018-05-18 | 1d? | 2018-06-19 | 2018-06-19 | 139d |  | start no earlier than 2018-06-18 |  |  |  | GH |  | P4 |
| 134 | 1.6.1.5.7 | Student Financials: Optional Fees |  | 1d? | 2018-06-19 | 2018-06-19 |  | 2018-05-18 | 2018-05-18 | 1d? | 2018-06-19 | 2018-06-19 | 139d |  | start no earlier than 2018-06-18 |  |  |  | GH |  | P4 |
| 135 | 1.6.1.5.8 | Student Financials: Make a Payment |  | 1d? | 2018-06-19 | 2018-06-19 |  | 2018-05-18 | 2018-05-18 | 1d? | 2018-06-19 | 2018-06-19 | 139d |  | start no earlier than 2018-06-18 |  |  |  | GH |  | P4 |
| 136 | 1.6.1.5.9 | Student Financials: Self Service 1098T |  | 1d? | 2018-06-19 | 2018-06-19 |  | 2018-05-18 | 2018-05-18 | 1d? | 2018-06-19 | 2018-06-19 | 139d |  | start no earlier than 2018-06-18 |  |  |  | GH |  | P4 |
| 137 | 1.6.1.5.10 | Student Financials: Payment History |  | 1d? | 2018-06-19 | 2018-06-19 |  | 2018-05-18 | 2018-05-18 | 1d? | 2018-06-19 | 2018-06-19 | 139d |  | start no earlier than 2018-06-18 |  |  |  | GH |  | P4 |
| 138 | 1.6.1.5.11 | Student Financials: UH in 4 Fixed Rate Tuition Plan |  | 1d? | 2018-06-19 | 2018-06-19 |  | 2018-05-18 | 2018-05-18 | 1d? | 2018-06-19 | 2018-06-19 | 139d |  | start no earlier than 2018-06-18 |  |  |  | GH |  | P4 |
| 139 | 1.6.1.5.12 | Student Financials: Self Service Refund Request |  | 1d? | 2018-06-19 | 2018-06-19 |  | 2018-05-18 | 2018-05-18 | 1d? | 2018-06-19 | 2018-06-19 | 139d |  | start no earlier than 2018-06-18 |  |  |  | GH |  | P4 |
| 140 | 1.6.1.5.13 | Student Communications Center: Communications to Student (if available) |  | 1d? | 2018-06-19 | 2018-06-19 |  | 2018-05-18 | 2018-05-18 | 1d? | 2018-06-19 | 2018-06-19 | 139d |  | start no earlier than 2018-06-18 |  |  |  | GH |  | P4 |
| 141 | 1.6.1.5.14 | Advising: UH in 4 Graduation Plan | manual | 1d? | 2018-03-01 | 2018-03-01 |  |  |  |  | 2018-03-01 | 2018-03-01 |  |  | start no earlier than 2018-06-18 |  |  |  | GH |  |  |
| 142 | 1.6.1.5.15 | Advising: List of Advisors Link | manual | 1d? | 2018-03-01 | 2018-03-01 |  |  |  |  | 2018-03-01 | 2018-03-01 |  |  | start no earlier than 2018-06-18 |  |  |  | GH |  |  |
| 143 | 1.6.1.5.16 | Advising: View My Appointments | manual | 1d? | 2018-03-01 | 2018-03-01 |  |  |  |  | 2018-03-01 | 2018-03-01 |  |  | start no earlier than 2018-06-18 |  |  |  | GH |  |  |
| 144 | 1.6.1.5.17 | Advising: Appointment with Advisor | manual | 1d? | 2018-03-01 | 2018-03-01 |  |  |  |  | 2018-03-01 | 2018-03-01 |  |  | start no earlier than 2018-06-18 |  |  |  | GH |  |  |
| 145 | 1.6.1.5.18 | Advising: Appointment with ISSSO | manual | 1d? | 2018-03-01 | 2018-03-01 |  |  |  |  | 2018-03-01 | 2018-03-01 |  |  | start no earlier than 2018-06-18 |  |  |  | GH |  |  |
| 146 | 1.6.1.5.19 | Advising: Graduation Status | manual | 1d? | 2018-03-01 | 2018-03-01 |  |  |  |  | 2018-03-01 | 2018-03-01 |  |  | start no earlier than 2018-06-18 |  |  |  |  |  |  |
| 147 | 1.6.1.5.20 | JumpForward: JumpForward Website | manual | 1d? | 2018-03-01 | 2018-03-01 |  |  |  |  | 2018-03-01 | 2018-03-01 |  |  | start no earlier than 2018-06-18 |  |  |  |  |  |  |
| 148 | 1.6.1.5.21 | Advising: Apply for Graduation | manual | 1d? | 2018-03-01 | 2018-03-01 |  |  |  |  | 2018-03-01 | 2018-03-01 |  |  | start no earlier than 2018-06-18 |  |  |  |  |  |  |
| 149 | 1.6.1.5.22 | UHS Acknowledgement Center: Student Acknowledgements (if available) |  | 1d? | 2018-06-19 | 2018-06-19 |  | 2018-05-18 | 2018-05-18 | 1d? | 2018-06-19 | 2018-06-19 | 139d |  | start no earlier than 2018-06-18 |  |  |  | GH |  | P4 |

Notes:
- 142: Need to ask why this element has not been moved to phase 4

| ID | WBS | Task | Type | Duration | Start | Finish | Predecessors | Complete | Remaining | Actual start | Baseline start | Baseline finish | Baseline duration | Baseline 1 start | Baseline 1 finish | Total slack | Free slack | Constraint | Resources | Work | Actual work | Cost | Actual cost | Text11 | Text13 | Audience |
| --- | --- | --- | --- | --- | --- | --- | --- | --- | --- | --- | --- | --- | --- | --- | --- | --- | --- | --- | --- | --- | --- | --- | --- | --- | --- | --- |
| 150 | 1.6.1.5.23 | **Testing** |  | 94d? | 2018-03-01 | 2018-07-10 |  |  |  |  | 2018-03-01 | 2018-07-10 | 94d? | 2018-03-01 | 2018-07-13 | 124d |  |  |  | 416h |  | 416 |  | GH | 0.93 |  |
| 151 | 1.6.1.5.23.1 | Set up test accounts |  | 8d? | 2018-03-01 | 2018-03-12 |  |  |  |  | 2018-03-01 | 2018-03-12 | 8d? | 2018-03-01 | 2018-03-12 | 210d |  | finish no earlier than 2018-03-12 | Charita Hampton | 64h |  | 64 |  | GH |  |  |
| 152 | 1.6.1.5.23.2 | Identify testers |  | 44d? | 2018-03-01 | 2018-05-01 |  |  |  |  | 2018-03-01 | 2018-05-01 | 44d? | 2018-03-01 | 2018-05-01 | 174d |  | finish no earlier than 2018-05-01 | Charita Hampton | 352h |  | 352 |  | GH |  |  |
| 153 | 1.6.1.5.23.3 | Perform Dev Test |  | 7d? | 2018-06-08 | 2018-06-18 |  |  |  |  | 2018-05-21 | 2018-06-08 | 15d? | 2018-06-08 | 2018-06-22 | 123d | 0d | finish no earlier than 2018-06-18 |  |  |  |  |  | GH | 0.47 |  |
| 154 | 1.6.1.5.23.4 | Perform UI/UX Test |  | 4d? | 2018-06-19 | 2018-06-22 | 153 |  |  |  | 2018-06-11 | 2018-06-22 | 10d? | 2018-06-22 | 2018-06-28 | 123d | 0d | finish no earlier than 2018-06-22 |  |  |  |  |  | GH | 0.4 |  |
| 155 | 1.6.1.5.23.5 | Perform Functional Test |  | 10d? | 2018-06-25 | 2018-07-06 | 154 |  |  |  | 2018-06-25 | 2018-07-09 | 11d? | 2018-06-28 | 2018-07-12 | 123d | 1d | finish no earlier than 2018-07-06 |  |  |  |  |  | GH | 0.91 |  |
| 156 | 1.6.1.5.23.6 | Perform Usability Test |  | 1d? | 2018-07-10 | 2018-07-10 | 155 |  |  |  | 2018-07-10 | 2018-07-10 | 1d? | 2018-07-12 | 2018-07-13 | 122d | 0d | finish no earlier than 2018-07-10 |  |  |  |  |  | GH |  |  |
| 157 | 1.6.1.5.24 | **Migrations** |  | 2d? | 2018-07-11 | 2018-07-13 |  |  |  |  | 2018-06-11 | 2018-07-02 | 16d? | 2018-07-11 | 2018-07-13 | 0d |  |  |  |  |  |  |  | GH | 0.22 |  |
| 158 | 1.6.1.5.24.1 | Move to TEST | manual | 1d | 2018-07-11 | 2018-07-11 | 156 |  |  |  | 2018-06-11 | 2018-06-11 | 1d | 2018-07-11 | 2018-07-11 |  |  |  |  |  |  |  |  | GH |  |  |
| 159 | 1.6.1.5.24.2 | Move to Production |  | 1d? | 2018-07-12 | 2018-07-12 | 158 |  |  |  | 2018-07-02 | 2018-07-02 | 1d? | 2018-07-12 | 2018-07-12 | 122d | 0d | start no earlier than 2018-07-02 |  |  |  |  |  | GH |  |  |
| 160 | 1.6.1.5.24.3 | MS: Phase 4 Completed | milestone, manual | 0d | 2018-07-13 | 2018-07-13 | 159 |  |  |  |  |  |  | 2018-07-13 | 2018-07-13 |  |  |  |  |  |  |  |  | GH |  |  |
| 161 | 1.7 | **Modo Labs Tasks** |  | 119d? | 2018-02-20 A | 2018-08-03 |  | 28% | 86.14d? |  | 2018-02-20 | 2018-08-03 | 119d? | 2018-02-20 | 2018-08-03 | 106d |  |  |  | 6150h | 3888.99h | 6,150 | 3,888.99 |  | 0.85 |  |
| 162 | 1.7.1 | **Create Initial Test Apps** |  | 109d | 2018-02-20 A | 2018-07-20 |  | 14% | 93.43d |  | 2018-02-20 | 2018-06-01 | 74d | 2018-02-20 | 2018-07-20 | 0d |  |  |  | 192h |  | 192 |  |  |  |  |
| 163 | 1.7.1.1 | Send Modo Labs Invites to iTunes, Apple Developer, and Google Play |  | 1d | 2018-02-20 A | 2018-02-20 A |  | 100% |  |  | 2018-02-20 | 2018-02-20 | 1d | 2018-02-20 | 2018-02-20 |  |  |  |  |  |  |  |  |  |  |  |
| 164 | 1.7.1.2 | Retrieve user UDIDs for iOS test apps |  | 1d | 2018-02-20 A | 2018-02-20 A |  | 100% |  |  | 2018-02-20 | 2018-02-20 | 1d | 2018-02-20 | 2018-02-20 |  |  |  |  |  |  |  |  |  |  |  |
| 165 | 1.7.1.3 | Modo Labs will confirm access and retrieve certificates for app creation |  | 1d | 2018-02-20 A | 2018-02-20 A |  | 100% |  |  | 2018-02-20 | 2018-02-20 | 1d | 2018-02-20 | 2018-02-20 |  |  |  |  |  |  |  |  |  |  |  |
| 166 | 1.7.1.4 | Test apps will be distributed |  | 1d | 2018-02-20 A | 2018-02-20 A |  | 100% |  |  | 2018-02-20 | 2018-02-20 | 1d | 2018-02-20 | 2018-02-20 |  |  |  |  |  |  |  |  |  |  |  |
| 167 | 1.7.1.5 | Clean-up Test platform | manual | 24d | 2018-06-19 | 2018-07-20 |  |  |  |  | 2018-05-01 | 2018-06-01 | 24d | 2018-06-19 | 2018-07-20 |  |  |  | Ali Dorton | 192h |  | 192 |  |  |  |  |
| 168 | 1.7.2 | **Blackboard Integration** |  | 65d | 2018-04-02 | 2018-06-29 |  | 54% | 29.86d | 2018-05-14 | 2018-04-02 | 2018-06-29 | 65d | 2018-04-02 | 2018-06-29 |  |  |  |  | 96h | 48h | 96 | 48 |  |  | Student |
| 169 | 1.7.2.1 | Setup Building Block in BB | manual | 14d | 2018-05-14 A | 2018-05-31 A |  | 100% |  |  | 2018-05-14 | 2018-05-31 | 14d | 2018-05-14 | 2018-05-31 |  |  |  |  |  |  |  |  |  |  |  |
| 170 | 1.7.2.2 | Configure Modo | manual | 12d | 2018-05-31 A | 2018-06-26 |  | 50% | 6d |  | 2018-05-31 | 2018-06-15 | 12d | 2018-05-31 | 2018-06-26 |  |  |  | Robert Birkline | 96h | 48h | 96 | 48 |  |  |  |
| 171 | 1.7.2.3 | Test | manual | 11d | 2018-06-19 | 2018-07-03 |  |  |  |  | 2018-06-15 | 2018-06-29 | 11d | 2018-06-19 | 2018-07-03 |  |  |  |  |  |  |  |  |  |  |  |
| 172 | 1.7.3 | **Authentication** |  | 73d | 2018-02-20 A | 2018-05-31 |  | 85% | 11.06d |  | 2018-02-20 | 2018-05-31 | 73d | 2018-02-20 | 2018-05-31 |  |  |  |  | 528h | 448h | 528 | 448 |  |  |  |
| 173 | 1.7.3.1 | SSO | manual | 1d | 2018-02-20 A | 2018-02-20 A |  | 100% |  |  | 2018-02-20 | 2018-02-20 | 1d | 2018-02-20 | 2018-02-20 |  |  |  | Keith Martin | 8h | 8h | 8 | 8 |  |  |  |
| 174 | 1.7.3.2 | Shibboleth for other services | manual | 55d | 2018-04-02 A | 2018-06-15 A |  | 100% |  |  | 2018-04-02 | 2018-06-15 | 55d | 2018-04-02 | 2018-06-15 |  |  |  | Keith Martin | 440h | 440h | 440 | 440 |  |  |  |
| 175 | 1.7.3.3 | Create authentication page |  | 10d | 2018-05-28 | 2018-06-08 |  |  |  |  | 2018-05-28 | 2018-06-08 | 10d | 2018-05-28 | 2018-06-08 | 146d |  | finish no earlier than 2018-06-08 | Bob Marberry | 80h |  | 80 |  |  |  |  |

Notes:
- 170: waiting on Ips for netscaler

| ID | WBS | Task | Type | Duration | Start | Finish | Complete | Remaining | Baseline start | Baseline finish | Baseline duration | Baseline 1 start | Baseline 1 finish | Total slack | Free slack | Constraint | Deadline | Resources | Work | Actual work | Cost | Actual cost | Text13 |
| --- | --- | --- | --- | --- | --- | --- | --- | --- | --- | --- | --- | --- | --- | --- | --- | --- | --- | --- | --- | --- | --- | --- | --- |
| 176 | 1.7.4 | **Communicate** |  | 14d | 2018-06-19 | 2018-07-06 |  |  | 2018-05-28 | 2018-06-22 | 20d | 2018-06-19 | 2018-07-06 | 0d |  |  |  |  | 352h |  | 352 |  |  |
| 177 | 1.7.4.1 | **Establish policy (Modo)** |  | 10d | 2018-06-19 | 2018-07-02 |  |  | 2018-05-28 | 2018-06-15 | 15d | 2018-06-19 | 2018-07-02 | 0d |  |  |  |  | 120h |  | 120 |  |  |
| 178 | 1.7.4.1.1 | Draft | manual | 10d | 2018-06-19 | 2018-07-02 |  |  | 2018-05-28 | 2018-06-08 | 10d | 2018-06-19 | 2018-07-02 |  |  |  |  | Ali Dorton | 80h |  | 80 |  |  |
| 179 | 1.7.4.1.2 | Final | manual | 5d | 2018-06-19 | 2018-06-25 |  |  | 2018-06-11 | 2018-06-15 | 5d | 2018-06-19 | 2018-06-25 |  |  |  |  | Deana Kreitz | 40h |  | 40 |  |  |
| 180 | 1.7.4.2 | Create message channels | manual | 14d | 2018-06-19 | 2018-07-06 |  |  | 2018-06-05 | 2018-06-22 | 14d | 2018-06-19 | 2018-07-06 |  |  |  |  | Diane Trippel; Deana Kreitz | 224h |  | 224 |  |  |
| 181 | 1.7.4.3 | Confirm test notifications can be received on test app |  | 1d | 2018-06-19 | 2018-06-19 |  |  | 2018-06-11 | 2018-06-11 | 1d | 2018-06-19 | 2018-06-19 | 139d |  | start no earlier than 2018-06-18 |  | Ali Dorton | 8h |  | 8 |  |  |
| 182 | 1.7.5 | **Analytics** |  | 10d | 2018-07-09 | 2018-07-20 |  |  | 2018-07-09 | 2018-07-20 | 10d | 2018-07-09 | 2018-07-20 | 0d |  |  |  |  | 80h |  | 80 |  |  |
| 183 | 1.7.5.1 | Configure | manual | 10d | 2018-07-09 | 2018-07-20 |  |  | 2018-07-09 | 2018-07-20 | 10d | 2018-07-09 | 2018-07-20 |  |  |  |  | Deana Kreitz | 80h |  | 80 |  |  |
| 184 | 1.7.6 | **Marketing and Communications** |  | 115d | 2018-02-20 A | 2018-07-30 | 16% | 96.48d | 2018-02-20 | 2018-07-06 | 99d | 2018-02-20 | 2018-07-30 | 108d |  |  |  |  | 1600h | 347.23h | 1,600 | 347.23 | 0.89 |
| 185 | 1.7.6.1 | Create new name (UH Go) |  | 29d | 2018-02-20 A | 2018-07-19 | 21% | 23d | 2018-02-20 | 2018-03-30 | 29d | 2018-02-20 | 2018-07-19 | -79d | 0d | finish no earlier than 2018-03-30 | 2018-03-20 |  |  |  |  |  |  |
| 186 | 1.7.6.2 | Communication Plan | manual | 30d | 2018-06-19 | 2018-07-30 |  |  | 2018-05-28 | 2018-07-06 | 30d | 2018-06-19 | 2018-07-30 |  |  |  |  | Keidra Gaston/Vuong Pham | 240h |  | 240 |  |  |
| 187 | 1.7.6.3 | Marketing Plan | manual | 30d | 2018-06-19 | 2018-07-30 |  |  | 2018-05-28 | 2018-07-06 | 30d | 2018-06-19 | 2018-07-30 |  |  |  |  | Keidra Gaston/Vuong Pham | 240h |  | 240 |  |  |
| 188 | 1.7.6.4 | **UH Go IA** |  | 29d | 2018-05-01 | 2018-06-08 |  |  | 2018-05-01 | 2018-06-08 | 29d | 2018-05-01 | 2018-06-08 |  |  |  |  |  | 64h |  | 64 |  |  |
| 189 | 1.7.6.4.1 | Wireframes | manual | 1d | 2018-05-01 | 2018-05-01 |  |  | 2018-05-01 | 2018-05-01 | 1d | 2018-05-01 | 2018-05-01 |  |  | start no earlier than 2018-06-18 |  | Bob Marberry | 8h |  | 8 |  |  |
| 190 | 1.7.6.4.2 | Documentation | manual | 1d | 2018-05-01 | 2018-05-01 |  |  | 2018-05-01 | 2018-05-01 | 1d | 2018-05-01 | 2018-05-01 |  |  | start no earlier than 2018-06-18 |  | Bob Marberry | 8h |  | 8 |  |  |
| 191 | 1.7.6.4.3 | Create Navigation |  | 6d | 2018-06-19 | 2018-06-26 |  |  | 2018-05-01 | 2018-05-08 | 6d | 2018-06-19 | 2018-06-26 | 132d | 23d | start no earlier than 2018-06-18 |  | Bob Marberry | 48h |  | 48 |  |  |
| 192 | 1.7.6.5 | **Themes** |  | 30d | 2018-06-18 A | 2018-07-27 | 27% | 21.89d | 2018-05-01 | 2018-06-29 | 44d | 2018-06-19 | 2018-07-27 | 0d |  |  |  | Bob Marberry | 1056h | 347.23h | 1,056 | 347.23 | 0.84 |
| 193 | 1.7.6.5.1 | App Theme (parent that everything in app inherits) | manual | 29d | 2018-06-19 | 2018-07-27 |  |  | 2018-05-01 | 2018-06-08 | 29d | 2018-06-19 | 2018-07-27 |  |  |  |  | Rainer Schuhsler | 232h |  | 232 |  |  |
| 194 | 1.7.6.5.2 | Modules and Screens | manual | 29d | 2018-06-19 | 2018-07-27 |  |  | 2018-05-01 | 2018-06-08 | 29d | 2018-06-19 | 2018-07-27 |  |  |  |  | Edu Ballingasa | 232h |  | 232 |  |  |
| 195 | 1.7.6.5.3 | Style Guideline for Content Owners | manual | 1d | 2018-06-18 | 2018-06-18 |  |  | 2018-05-01 | 2018-05-01 | 1d | 2018-06-19 | 2018-06-19 |  |  | start no earlier than 2018-06-18 |  | Bob Marberry/Edu Balingasa | 8h |  | 8 |  |  |
| 196 | 1.7.6.5.4 | **App Design** |  | 14d | 2018-06-18 A | 2018-07-05 | 82% | 2.51d | 2018-05-29 | 2018-06-29 | 24d | 2018-06-19 | 2018-07-06 | 0d |  |  |  | Deana Kreitz | 344h | 282.32h | 344 | 282.32 | 0.81 |
| 197 | 1.7.6.5.4.1 | Logo for UH Go! | manual | 1d | 2018-06-29 | 2018-06-29 |  |  | 2018-06-29 | 2018-06-29 | 1d | 2018-06-29 | 2018-06-29 |  |  |  |  | Deana Kreitz | 8h |  | 8 |  |  |
| 198 | 1.7.6.5.4.2 | Home Page: University of Houston Persona | manual | 14d | 2018-06-18 A | 2018-07-05 | 85% | 2.1d | 2018-05-29 | 2018-06-15 | 14d | 2018-06-19 | 2018-07-06 |  |  |  |  | Edu Ballingasa | 112h | 95.2h | 112 | 95.2 |  |
| 199 | 1.7.6.5.4.3 | Student Persona | manual | 14d | 2018-06-18 A | 2018-07-05 | 85% | 2.1d | 2018-05-29 | 2018-06-15 | 14d | 2018-06-19 | 2018-07-06 |  |  |  |  | Edu Ballingasa | 112h | 95.2h | 112 | 95.2 |  |

Notes:
- 180: I don't. From the sound of it, it sounds like it should pertain to the variety of channels we can message through in the app = alerts, banners, push notifications, etc.

| ID | WBS | Task | Type | Duration | Start | Finish | Predecessors | Complete | Remaining | Baseline start | Baseline finish | Baseline duration | Baseline 1 start | Baseline 1 finish | Total slack | Free slack | Constraint | Resources | Work | Actual work | Cost | Actual cost | Text13 | Text12 | Audience |
| --- | --- | --- | --- | --- | --- | --- | --- | --- | --- | --- | --- | --- | --- | --- | --- | --- | --- | --- | --- | --- | --- | --- | --- | --- | --- |
| 200 | 1.7.7 | **Development** |  | 114d? | 2018-02-20 A | 2018-07-27 |  | 30% | 80.09d? | 2018-02-20 | 2018-07-27 | 114d? | 2018-02-20 | 2018-07-27 | 111d |  |  |  | 3182h | 2925.76h | 3,182 | 2,925.76 | 0.81 |  |  |
| 201 | 1.7.7.1 | **Content & Services** |  | 114d? | 2018-02-20 A | 2018-07-27 |  | 30% | 80.09d? | 2018-02-20 | 2018-07-27 | 114d? | 2018-02-20 | 2018-07-27 | 111d |  |  |  | 3182h | 2925.76h | 3,182 | 2,925.76 | 0.81 |  |  |
| 202 | 1.7.7.1.1 | **myUH (GreyHeller)** |  | 1d | 2018-02-20 A | 2018-02-20 A |  | 100% |  | 2018-02-20 | 2018-02-20 | 1d | 2018-02-20 | 2018-02-20 |  |  |  |  | 24h | 24h | 24 | 24 |  |  |  |
| 203 | 1.7.7.1.1.1 | Authentication via Shibboleth (SSO) |  | 1d | 2018-02-20 A | 2018-02-20 A |  | 100% |  | 2018-02-20 | 2018-02-20 | 1d | 2018-02-20 | 2018-02-20 |  |  |  | Keith Martin | 8h | 8h | 8 | 8 |  |  |  |
| 204 | 1.7.7.1.1.2 | Create IA |  | 1d | 2018-02-20 A | 2018-02-20 A |  | 100% |  | 2018-02-20 | 2018-02-20 | 1d | 2018-02-20 | 2018-02-20 |  |  |  | Charita Hampton | 8h | 8h | 8 | 8 |  |  |  |
| 205 | 1.7.7.1.1.3 | Build screens/navigation |  | 1d | 2018-02-20 A | 2018-02-20 A |  | 100% |  | 2018-02-20 | 2018-02-20 | 1d | 2018-02-20 | 2018-02-20 |  |  |  | Ali Dorton | 8h | 8h | 8 | 8 |  |  |  |
| 206 | 1.7.7.1.2 | **Housing** |  | 40d? | 2018-06-04 A | 2018-07-27 |  | 42% | 23.03d? | 2018-06-04 | 2018-07-27 | 40d? | 2018-06-04 | 2018-07-27 | 111d |  |  |  | 200h | 200h | 200 | 200 | 0.66 | Diane (Housing) |  |
| 207 | 1.7.7.1.2.1 | Housing Stakeholder Meeting |  | 20d? | 2018-06-04 A | 2018-06-29 A |  | 100% |  | 2018-06-04 | 2018-06-29 | 20d? | 2018-06-04 | 2018-06-29 |  |  | start no earlier than 2018-06-04 | Keith Kowalka | 160h | 160h | 160 | 160 |  | Diane (Housing) |  |
| 208 | 1.7.7.1.2.2 | **Move-in Guide** |  | 1d | 2018-06-19 | 2018-06-19 |  |  |  | 2018-06-04 | 2018-06-06 | 3d | 2018-06-19 | 2018-06-19 | 0d |  |  |  |  |  |  |  |  | Diane (Housing) | Students>Residents |
| 209 | 1.7.7.1.2.2.1 | create screen so that we can add Fix-it button that logs into AccessUH to request room maintenance | manual | 1d | 2018-06-19 | 2018-06-19 |  |  |  | 2018-06-06 | 2018-06-06 | 1d | 2018-06-19 | 2018-06-19 |  |  |  |  |  |  |  |  |  | Diane (Housing) |  |
| 210 | 1.7.7.1.2.2.2 | Xcomponent proof of concept using residential data | manual | 1d | 2018-06-19 | 2018-06-19 |  |  |  | 2018-06-04 | 2018-06-04 | 1d | 2018-06-19 | 2018-06-19 |  |  |  |  |  |  |  |  |  | Diane (Housing) |  |
| 211 | 1.7.7.1.2.3 | **Become a Resident** |  | 16.6d | 2018-06-04 A | 2018-06-26 |  | 90% | 1.66d | 2018-06-04 | 2018-06-12 | 7d | 2018-06-04 | 2018-06-26 | 134.4d |  |  |  |  |  |  |  |  | Diane (Housing) |  |
| 212 | 1.7.7.1.2.3.1 | Apply for Housing |  | 2d | 2018-06-06 A | 2018-06-19 |  | 90% | 0.2d | 2018-06-06 | 2018-06-07 | 2d | 2018-06-06 | 2018-06-19 | 139.8d |  | start no earlier than 2018-06-06 |  |  |  |  |  |  | Diane (Housing) |  |
| 213 | 1.7.7.1.2.3.2 | LaundryView Integration |  | 7d | 2018-06-04 A | 2018-06-26 |  | 90% | 0.7d | 2018-06-04 | 2018-06-12 | 7d | 2018-06-04 | 2018-06-26 | 132.4d | 0d | start no earlier than 2018-06-04 |  |  |  |  |  |  | Diane (Housing) |  |
| 214 | 1.7.7.1.2.4 | Marketing evaluation |  | 2d | 2018-06-26 | 2018-06-28 | 213 |  |  | 2018-07-09 | 2018-07-10 | 2d | 2018-06-26 | 2018-06-28 | 132.4d |  | start no earlier than 2018-06-18 |  |  |  |  |  |  | Diane (Housing) |  |
| 215 | 1.7.7.1.2.5 | Module configuration |  | 5d | 2018-06-19 A | 2018-06-29 A | 214 | 100% |  | 2018-06-04 | 2018-06-29 | 5d | 2018-06-19 | 2018-06-29 |  |  | finish no earlier than 2018-06-29 | Ali Dorton | 40h | 40h | 40 | 40 |  | Diane (Housing) |  |
| 216 | 1.7.7.1.2.6 | **Testing** |  | 20d? | 2018-07-02 | 2018-07-27 |  |  |  | 2018-06-25 | 2018-07-20 | 20d? | 2018-07-02 | 2018-07-27 | 111d |  |  |  |  |  |  |  | 0.53 | Diane (Housing) |  |
| 217 | 1.7.7.1.2.6.1 | Dev Testing |  | 5d | 2018-07-02 | 2018-07-06 | 215 |  |  | 2018-06-25 | 2018-06-29 | 5d | 2018-07-02 | 2018-07-06 | 111d | 0d | start no earlier than 2018-06-25 |  |  |  |  |  |  | Diane (Housing) |  |
| 218 | 1.7.7.1.2.6.2 | BO Testing |  | 10d | 2018-07-09 | 2018-07-20 | 217 |  |  | 2018-06-25 | 2018-07-13 | 15d | 2018-07-09 | 2018-07-20 | 111d | 0d | start no earlier than 2018-06-25 |  |  |  |  |  | 0.67 | Diane (Housing) |  |
| 219 | 1.7.7.1.2.6.3 | **Functional Testing** |  | 5d? | 2018-07-23 | 2018-07-27 |  |  |  | 2018-06-25 | 2018-07-06 | 10d? | 2018-07-23 | 2018-07-27 | 111d |  |  |  |  |  |  |  | 0.5 | Diane (Housing) |  |
| 220 | 1.7.7.1.2.6.3.1 | iOS |  | 5d? | 2018-07-23 | 2018-07-27 | 218 |  |  | 2018-06-25 | 2018-07-06 | 10d? | 2018-07-23 | 2018-07-27 | 111d |  | finish no earlier than 2018-07-27 |  |  |  |  |  | 0.5 | Diane (Housing) |  |
| 221 | 1.7.7.1.2.6.3.2 | Android |  | 5d? | 2018-07-23 | 2018-07-27 | 218 |  |  | 2018-06-25 | 2018-07-06 | 10d? | 2018-07-23 | 2018-07-27 | 111d |  | finish no earlier than 2018-07-27 |  |  |  |  |  | 0.5 | Diane (Housing) |  |
| 222 | 1.7.7.1.2.6.4 | Usability Testing |  | 5d | 2018-07-23 | 2018-07-27 | 218 |  |  | 2018-07-02 | 2018-07-13 | 10d | 2018-07-23 | 2018-07-27 | 111d |  | finish no earlier than 2018-07-27 |  |  |  |  |  | 0.5 | Diane (Housing) |  |
| 223 | 1.7.7.1.2.6.5 | Bug Fixing |  | 5d? | 2018-07-23 | 2018-07-27 | 218 |  |  | 2018-07-09 | 2018-07-20 | 10d? | 2018-07-23 | 2018-07-27 | 111d |  | finish no earlier than 2018-07-27 |  |  |  |  |  | 0.5 | Diane (Housing) |  |
| 224 | 1.7.7.1.2.7 | Marketing sign-off |  | 5d | 2018-07-23 | 2018-07-27 |  |  |  | 2018-07-16 | 2018-07-27 | 10d | 2018-07-23 | 2018-07-27 | 111d |  | finish no earlier than 2018-07-27 |  |  |  |  |  | 0.5 | Diane (Housing) |  |

| ID | WBS | Task | Duration | Start | Finish | Complete | Remaining | Baseline start | Baseline finish | Baseline duration | Baseline 1 start | Baseline 1 finish | Total slack | Constraint | Resources | Work | Actual work | Cost | Actual cost | Audience | Text12 |
| --- | --- | --- | --- | --- | --- | --- | --- | --- | --- | --- | --- | --- | --- | --- | --- | --- | --- | --- | --- | --- | --- |
| 225 | 1.7.7.1.3 | **Parking** | 85d? | 2018-04-02 A | 2018-07-27 | 16% | 71.82d? | 2018-04-02 | 2018-07-27 | 85d? | 2018-04-02 | 2018-07-27 | 111d |  |  | 160h | 160h | 160 | 160 | Student | Robert (Parking) |
| 226 | 1.7.7.1.3.1 | Parking Stakeholder Meeting | 20d | 2018-04-02 A | 2018-06-08 A | 100% |  | 2018-04-02 | 2018-06-29 | 20d | 2018-04-02 | 2018-06-08 |  | finish no earlier than 2018-06-29 | Eric Holeman | 160h | 160h | 160 | 160 |  | Robert (Parking) |
| 227 | 1.7.7.1.3.2 | B-Cycle parking bike share [Before Fall] | 2d | 2018-06-28 | 2018-06-29 |  |  | 2018-06-28 | 2018-06-29 | 2d | 2018-06-28 | 2018-06-29 | 131d | finish no earlier than 2018-06-29 |  |  |  |  |  |  | Robert (Parking) |
| 228 | 1.7.7.1.3.3 | Park Mobile | 2d | 2018-06-28 | 2018-06-29 |  |  | 2018-06-28 | 2018-06-29 | 2d | 2018-06-28 | 2018-06-29 | 131d | finish no earlier than 2018-06-29 |  |  |  |  |  |  | Robert (Parking) |
| 229 | 1.7.7.1.3.4 | Pre-purchase parking | 2d | 2018-06-28 | 2018-06-29 |  |  | 2018-06-28 | 2018-06-29 | 2d | 2018-06-28 | 2018-06-29 | 131d | finish no earlier than 2018-06-29 |  |  |  |  |  |  | Robert (Parking) |
| 230 | 1.7.7.1.3.5 | T2 | 2d | 2018-06-28 | 2018-06-29 |  |  | 2018-06-28 | 2018-06-29 | 2d | 2018-06-28 | 2018-06-29 | 131d | finish no earlier than 2018-06-29 |  |  |  |  |  |  | Robert (Parking) |
| 231 | 1.7.7.1.3.6 | Parking citations | 2d | 2018-06-28 | 2018-06-29 |  |  | 2018-06-28 | 2018-06-29 | 2d | 2018-06-28 | 2018-06-29 | 131d | finish no earlier than 2018-06-29 |  |  |  |  |  |  | Robert (Parking) |
| 232 | 1.7.7.1.3.7 | Rent a car | 2d | 2018-06-28 | 2018-06-29 |  |  | 2018-06-28 | 2018-06-29 | 2d | 2018-06-28 | 2018-06-29 | 131d | finish no earlier than 2018-06-29 |  |  |  |  |  |  | Robert (Parking) |
| 233 | 1.7.7.1.3.8 | Order Tow | 2d | 2018-06-28 | 2018-06-29 |  |  | 2018-06-28 | 2018-06-29 | 2d | 2018-06-28 | 2018-06-29 | 131d | finish no earlier than 2018-06-29 |  |  |  |  |  |  | Robert (Parking) |
| 234 | 1.7.7.1.3.9 | **Testing** | 35d? | 2018-06-11 | 2018-07-27 |  |  | 2018-06-11 | 2018-07-27 | 35d? | 2018-06-11 | 2018-07-27 | 111d |  |  |  |  |  |  |  | Robert (Parking) |
| 235 | 1.7.7.1.3.9.1 | Dev Testing | 15d? | 2018-06-11 | 2018-06-29 |  |  | 2018-06-11 | 2018-06-29 | 15d? | 2018-06-11 | 2018-06-29 | 131d | finish no earlier than 2018-06-29 |  |  |  |  |  |  | Robert (Parking) |
| 236 | 1.7.7.1.3.9.2 | UI/UX testing (infomal user testing) | 15d | 2018-06-18 | 2018-07-06 |  |  | 2018-06-18 | 2018-07-06 | 15d | 2018-06-18 | 2018-07-06 | 126d | finish no earlier than 2018-07-06 |  |  |  |  |  |  | Robert (Parking) |
| 237 | 1.7.7.1.3.9.3 | BO Testing | 15d? | 2018-06-25 | 2018-07-13 |  |  | 2018-06-25 | 2018-07-13 | 15d? | 2018-06-25 | 2018-07-13 | 121d | finish no earlier than 2018-07-13 |  |  |  |  |  |  | Robert (Parking) |
| 238 | 1.7.7.1.3.9.4 | **Functional Testing** | 10d? | 2018-06-25 | 2018-07-06 |  |  | 2018-06-25 | 2018-07-06 | 10d? | 2018-06-25 | 2018-07-06 | 126d |  |  |  |  |  |  |  | Robert (Parking) |
| 239 | 1.7.7.1.3.9.4.1 | iOS | 10d? | 2018-06-25 | 2018-07-06 |  |  | 2018-06-25 | 2018-07-06 | 10d? | 2018-06-25 | 2018-07-06 | 126d | finish no earlier than 2018-07-06 |  |  |  |  |  |  | Robert (Parking) |
| 240 | 1.7.7.1.3.9.4.2 | Android | 10d? | 2018-06-25 | 2018-07-06 |  |  | 2018-06-25 | 2018-07-06 | 10d? | 2018-06-25 | 2018-07-06 | 126d | finish no earlier than 2018-07-06 |  |  |  |  |  |  | Robert (Parking) |
| 241 | 1.7.7.1.3.9.5 | Usability Testing | 10d? | 2018-07-02 | 2018-07-13 |  |  | 2018-07-02 | 2018-07-13 | 10d? | 2018-07-02 | 2018-07-13 | 121d | finish no earlier than 2018-07-13 |  |  |  |  |  |  | Robert (Parking) |
| 242 | 1.7.7.1.3.9.6 | Bug Fixing | 10d? | 2018-07-09 | 2018-07-20 |  |  | 2018-07-09 | 2018-07-20 | 10d? | 2018-07-09 | 2018-07-20 | 116d | finish no earlier than 2018-07-20 |  |  |  |  |  |  | Robert (Parking) |
| 243 | 1.7.7.1.3.9.7 | Marketing sign-off | 10d | 2018-07-16 | 2018-07-27 |  |  | 2018-07-16 | 2018-07-27 | 10d | 2018-07-16 | 2018-07-27 | 111d | finish no earlier than 2018-07-27 |  |  |  |  |  |  | Robert (Parking) |
| 244 | 1.7.7.1.4 | **Dining** | 114d? | 2018-02-20 A | 2018-07-27 | 1% | 113.23d? | 2018-02-20 | 2018-07-27 | 114d? | 2018-02-20 | 2018-07-27 | 111d |  |  |  |  |  |  | UH | Robert (Dining) |
| 245 | 1.7.7.1.4.1 | Dining Stakeholder Meeting | 2d | 2018-02-20 A | 2018-06-19 | 50% | 1d | 2018-02-20 | 2018-02-21 | 2d | 2018-02-20 | 2018-06-19 | 139d |  |  |  |  |  |  |  | Robert (Dining) |
| 246 | 1.7.7.1.4.2 | Boost App [ordering] | 2d | 2018-06-19 | 2018-06-20 |  |  | 2018-04-16 | 2018-04-17 | 2d | 2018-06-19 | 2018-06-20 | 138d | start no earlier than 2018-06-18 |  |  |  |  |  |  | Robert (Dining) |
| 247 | 1.7.7.1.4.3 | Pickup | 2d | 2018-06-19 | 2018-06-20 |  |  | 2018-04-16 | 2018-04-17 | 2d | 2018-06-19 | 2018-06-20 | 138d | start no earlier than 2018-06-18 |  |  |  |  |  |  | Robert (Dining) |
| 248 | 1.7.7.1.4.4 | Pre-payment | 2d | 2018-06-19 | 2018-06-20 |  |  | 2018-04-16 | 2018-04-17 | 2d | 2018-06-19 | 2018-06-20 | 138d | start no earlier than 2018-06-18 |  |  |  |  |  |  | Robert (Dining) |
| 249 | 1.7.7.1.4.5 | Express pickup (Integrated with meal plans and CougarCash) | 2d | 2018-06-19 | 2018-06-20 |  |  | 2018-04-16 | 2018-04-17 | 2d | 2018-06-19 | 2018-06-20 | 138d | start no earlier than 2018-06-18 |  |  |  |  |  |  | Robert (Dining) |

| ID | WBS | Task | Type | Duration | Start | Finish | Predecessors | Complete | Remaining | Baseline start | Baseline finish | Baseline duration | Baseline 1 start | Baseline 1 finish | Total slack | Free slack | Constraint | Resources | Work | Actual work | Cost | Actual cost | Text12 | Audience | Text13 |
| --- | --- | --- | --- | --- | --- | --- | --- | --- | --- | --- | --- | --- | --- | --- | --- | --- | --- | --- | --- | --- | --- | --- | --- | --- | --- |
| 250 | 1.7.7.1.4.6 | **Dine on Campus** |  | 20d? | 2018-06-04 | 2018-06-29 |  |  |  | 2018-06-04 | 2018-06-29 | 20d? | 2018-06-04 | 2018-06-29 | 131d |  |  |  |  |  |  |  | Robert (Dining) |  |  |
| 251 | 1.7.7.1.4.6.1 | Menus |  | 20d? | 2018-06-04 | 2018-06-29 |  |  |  | 2018-06-04 | 2018-06-29 | 20d? | 2018-06-04 | 2018-06-29 | 131d |  | finish no earlier than 2018-06-29 |  |  |  |  |  | Robert (Dining) |  |  |
| 252 | 1.7.7.1.4.6.2 | Hours of Operation |  | 20d? | 2018-06-04 | 2018-06-29 |  |  |  | 2018-06-04 | 2018-06-29 | 20d? | 2018-06-04 | 2018-06-29 | 131d |  | finish no earlier than 2018-06-29 |  |  |  |  |  | Robert (Dining) |  |  |
| 253 | 1.7.7.1.4.6.3 | Food Trucks - RSS feed |  | 1d | 2018-06-29 | 2018-06-29 |  |  |  | 2018-06-29 | 2018-06-29 | 1d | 2018-06-29 | 2018-06-29 | 131d |  | finish no earlier than 2018-06-29 |  |  |  |  |  | Robert (Dining) |  |  |
| 254 | 1.7.7.1.4.7 | **My Fitness Pal** |  | 2d | 2018-06-28 | 2018-06-29 |  |  |  | 2018-06-28 | 2018-06-29 | 2d | 2018-06-28 | 2018-06-29 | 131d |  |  |  |  |  |  |  | Robert (Dining) |  |  |
| 255 | 1.7.7.1.4.7.1 | Calories, allergen info, etc. |  | 2d | 2018-06-28 | 2018-06-29 |  |  |  | 2018-06-28 | 2018-06-29 | 2d | 2018-06-28 | 2018-06-29 | 131d |  | finish no earlier than 2018-06-29 |  |  |  |  |  | Robert (Dining) |  |  |
| 256 | 1.7.7.1.4.8 | **Testing** |  | 35d? | 2018-06-11 | 2018-07-27 |  |  |  | 2018-02-20 | 2018-07-27 | 114d? | 2018-06-11 | 2018-07-27 | 111d |  |  |  |  |  |  |  | Robert (Dining) |  |  |
| 257 | 1.7.7.1.4.8.1 | Dev Testing |  | 15d? | 2018-06-11 | 2018-06-29 |  |  |  | 2018-06-11 | 2018-06-29 | 15d? | 2018-06-11 | 2018-06-29 | 131d |  | finish no earlier than 2018-06-29 |  |  |  |  |  | Robert (Dining) |  |  |
| 258 | 1.7.7.1.4.8.2 | UI/UX Testing |  | 15d? | 2018-06-19 | 2018-07-09 |  |  |  | 2018-02-20 | 2018-03-12 | 15d? | 2018-06-19 | 2018-07-09 | 125d |  | start no earlier than 2018-06-18 |  |  |  |  |  | Robert (Dining) |  |  |
| 259 | 1.7.7.1.4.8.3 | BO Testing |  | 15d? | 2018-06-19 | 2018-07-09 |  |  |  | 2018-02-20 | 2018-03-12 | 15d? | 2018-06-19 | 2018-07-09 | 125d |  | start no earlier than 2018-06-18 |  |  |  |  |  | Robert (Dining) |  |  |
| 260 | 1.7.7.1.4.8.4 | **Functional Testing** |  | 10d? | 2018-06-25 | 2018-07-06 |  |  |  | 2018-06-25 | 2018-07-06 | 10d? | 2018-06-25 | 2018-07-06 | 126d |  |  |  |  |  |  |  | Robert (Dining) |  |  |
| 261 | 1.7.7.1.4.8.4.1 | iOS |  | 10d? | 2018-06-25 | 2018-07-06 |  |  |  | 2018-06-25 | 2018-07-06 | 10d? | 2018-06-25 | 2018-07-06 | 126d |  | finish no earlier than 2018-07-06 |  |  |  |  |  | Robert (Dining) |  |  |
| 262 | 1.7.7.1.4.8.4.2 | Android |  | 10d? | 2018-06-25 | 2018-07-06 |  |  |  | 2018-06-25 | 2018-07-06 | 10d? | 2018-06-25 | 2018-07-06 | 126d |  | finish no earlier than 2018-07-06 |  |  |  |  |  | Robert (Dining) |  |  |
| 263 | 1.7.7.1.4.8.5 | Usability Testing |  | 10d? | 2018-07-02 | 2018-07-13 |  |  |  | 2018-07-02 | 2018-07-13 | 10d? | 2018-07-02 | 2018-07-13 | 121d |  | finish no earlier than 2018-07-13 |  |  |  |  |  | Robert (Dining) |  |  |
| 264 | 1.7.7.1.4.8.6 | Bug Fixing |  | 10d? | 2018-07-09 | 2018-07-20 |  |  |  | 2018-07-09 | 2018-07-20 | 10d? | 2018-07-09 | 2018-07-20 | 116d |  | finish no earlier than 2018-07-20 |  |  |  |  |  | Robert (Dining) |  |  |
| 265 | 1.7.7.1.4.8.7 | Marketing sign-off |  | 10d? | 2018-07-16 | 2018-07-27 |  |  |  | 2018-07-16 | 2018-07-27 | 10d? | 2018-07-16 | 2018-07-27 | 111d |  | finish no earlier than 2018-07-27 |  |  |  |  |  | Robert (Dining) |  |  |
| 266 | 1.7.7.1.5 | **Library** |  | 40d | 2018-06-04 A | 2018-07-27 |  | 60% | 15.93d | 2018-06-04 | 2018-07-27 | 40d? | 2018-06-04 | 2018-07-27 | 111d |  |  |  | 88h | 88h | 88 | 88 | Deron (Library) | UH | 0.14 |
| 267 | 1.7.7.1.5.1 | Library Stakeholder Meeting |  | 1d | 2018-06-04 A | 2018-06-04 A |  | 100% |  | 2018-06-04 | 2018-06-29 | 20d | 2018-06-04 | 2018-06-04 |  |  | start no earlier than 2018-06-18 | J Fisher; Rob Spragg | 16h | 16h | 16 | 16 | Deron (Library) |  | 0.05 |
| 268 | 1.7.7.1.5.2 | Hours |  | 3d | 2018-06-11 A | 2018-06-13 A | 267 | 100% |  | 2018-06-29 | 2018-06-29 | 1d | 2018-06-11 | 2018-06-13 |  |  | finish no earlier than 2018-06-13 | Deron Frederickson | 8h | 8h | 8 | 8 | Deron (Library) |  |  |
| 269 | 1.7.7.1.5.3 | News | manual | 0.25d | 2018-06-18 A | 2018-06-18 | 268 | 75% | 0.06d | 2018-06-04 | 2018-06-04 | 1d | 2018-06-18 | 2018-06-19 |  |  |  |  |  |  |  |  | Deron (Library) |  |  |
| 270 | 1.7.7.1.5.4 | Calendar | manual | 3d | 2018-06-11 A | 2018-06-13 A | 269 | 100% |  | 2018-06-04 | 2018-06-04 | 1d | 2018-06-11 | 2018-06-13 |  |  |  | Deron Frederickson | 24h | 24h | 24 | 24 | Deron (Library) |  |  |
| 271 | 1.7.7.1.5.5 | Check-out System | manual | 5d | 2018-06-11 A | 2018-06-15 A | 270 | 100% |  | 2018-06-04 | 2018-06-04 | 1d | 2018-06-11 | 2018-06-15 |  |  |  | Deron Frederickson | 40h | 40h | 40 | 40 | Deron (Library) |  |  |
| 272 | 1.7.7.1.5.6 | **Testing** |  | 16d | 2018-06-29 | 2018-07-20 |  |  |  | 2018-06-11 | 2018-07-20 | 30d? | 2018-06-29 | 2018-07-20 | 116d |  |  |  |  |  |  |  | Deron (Library) |  | 0.08 |
| 273 | 1.7.7.1.5.6.1 | Dev Testing |  | 1d | 2018-06-29 | 2018-06-29 | 271 |  |  | 2018-06-11 | 2018-06-29 | 15d? | 2018-06-29 | 2018-06-29 | 128d | 4d | finish no earlier than 2018-06-29 |  |  |  |  |  | Deron (Library) |  | 0.07 |
| 274 | 1.7.7.1.5.6.2 | UI/UX Testing |  | 1d | 2018-07-06 | 2018-07-06 | 273 |  |  | 2018-06-18 | 2018-07-06 | 15d? | 2018-07-06 | 2018-07-06 | 124d | 4d | finish no earlier than 2018-07-06 |  |  |  |  |  | Deron (Library) |  | 0.07 |
| 275 | 1.7.7.1.5.6.3 | BO Testin |  | 1d | 2018-07-13 | 2018-07-13 | 274 |  |  | 2018-06-25 | 2018-07-13 | 15d? | 2018-07-13 | 2018-07-13 | 120d | 0d | finish no earlier than 2018-07-13 |  |  |  |  |  | Deron (Library) |  | 0.07 |

| ID | WBS | Task | Duration | Start | Finish | Predecessors | Complete | Remaining | Baseline start | Baseline finish | Baseline duration | Baseline 1 start | Baseline 1 finish | Total slack | Constraint | Text12 | Text13 | Audience |
| --- | --- | --- | --- | --- | --- | --- | --- | --- | --- | --- | --- | --- | --- | --- | --- | --- | --- | --- |
| 276 | 1.7.7.1.5.6.4 | **Functional Testing** | 1d | 2018-07-16 | 2018-07-16 |  |  |  | 2018-06-25 | 2018-07-06 | 10d? | 2018-07-16 | 2018-07-16 | 120d |  | Deron (Library) | 0.1 |  |
| 277 | 1.7.7.1.5.6.4.1 | iOS | 1d | 2018-07-16 | 2018-07-16 | 275 |  |  | 2018-06-25 | 2018-07-06 | 10d? | 2018-07-16 | 2018-07-16 | 120d | finish no earlier than 2018-07-06 | Deron (Library) | 0.1 |  |
| 278 | 1.7.7.1.5.6.4.2 | Android | 1d | 2018-07-16 | 2018-07-16 | 275 |  |  | 2018-06-25 | 2018-07-06 | 10d? | 2018-07-16 | 2018-07-16 | 120d | finish no earlier than 2018-07-06 | Deron (Library) | 0.1 |  |
| 279 | 1.7.7.1.5.6.5 | Usability Testing | 1d | 2018-07-16 | 2018-07-16 | 275 |  |  | 2018-07-02 | 2018-07-13 | 10d? | 2018-07-16 | 2018-07-16 | 120d | finish no earlier than 2018-07-13 | Deron (Library) | 0.1 |  |
| 280 | 1.7.7.1.5.6.6 | Bug Fixing | 1d | 2018-07-20 | 2018-07-20 | 275 |  |  | 2018-07-09 | 2018-07-20 | 10d? | 2018-07-20 | 2018-07-20 | 116d | finish no earlier than 2018-07-20 | Deron (Library) | 0.1 |  |
| 281 | 1.7.7.1.5.7 | Marketing sign-off | 1d | 2018-07-27 | 2018-07-27 | 275 |  |  | 2018-07-16 | 2018-07-27 | 10d? | 2018-07-27 | 2018-07-27 | 111d | finish no earlier than 2018-07-27 | Deron (Library) | 0.1 |  |
| 282 | 1.7.7.1.6 | **Social** | 15.2d | 2018-06-04 A | 2018-06-25 |  | 16% | 12.77d | 2018-06-04 | 2018-06-08 | 5d | 2018-06-04 | 2018-06-25 | 135.8d |  | Diane (Social) | 1.41 |  |
| 283 | 1.7.7.1.6.1 | Facebook | 5d | 2018-06-04 A | 2018-06-25 |  | 16% | 4.2d | 2018-06-04 | 2018-06-08 | 5d | 2018-06-04 | 2018-06-25 | 135.8d | finish no earlier than 2018-06-08 | Diane (Social) |  |  |
| 284 | 1.7.7.1.6.2 | Twitter | 5d | 2018-06-04 A | 2018-06-25 |  | 16% | 4.2d | 2018-06-04 | 2018-06-08 | 5d | 2018-06-04 | 2018-06-25 | 135.8d | finish no earlier than 2018-06-08 | Diane (Social) |  |  |
| 285 | 1.7.7.1.6.3 | YouTube | 5d | 2018-06-04 A | 2018-06-25 |  | 16% | 4.2d | 2018-06-04 | 2018-06-08 | 5d | 2018-06-04 | 2018-06-25 | 135.8d | finish no earlier than 2018-06-08 | Diane (Social) |  |  |
| 286 | 1.7.7.1.6.4 | Testing | 5d | 2018-06-04 A | 2018-06-25 |  | 16% | 4.2d | 2018-06-04 | 2018-06-08 | 5d | 2018-06-04 | 2018-06-25 | 135.8d | finish no earlier than 2018-06-08 | Diane (Social) |  |  |
| 287 | 1.7.7.1.7 | **UIT Guide** | 40d? | 2018-06-04 A | 2018-07-27 |  | 11% | 35.68d? | 2018-06-04 | 2018-07-27 | 40d? | 2018-06-04 | 2018-07-27 | 111d |  | Mark (UIT Guide) |  | Student |
| 288 | 1.7.7.1.7.1 | UIT Stakeholder Meeting | 5d | 2018-06-04 A | 2018-06-20 |  | 75% | 1.25d | 2018-06-04 | 2018-06-08 | 5d | 2018-06-04 | 2018-06-20 | 138.75d | finish no earlier than 2018-06-08 | Mark (UIT Guide) |  |  |
| 289 | 1.7.7.1.7.2 | Chat Functionality | 5d? | 2018-06-04 A | 2018-06-20 |  | 75% | 1.25d? | 2018-06-04 | 2018-06-08 | 5d? | 2018-06-04 | 2018-06-20 | 138.75d | finish no earlier than 2018-06-08 | Mark (UIT Guide) |  |  |
| 290 | 1.7.7.1.7.3 | Interactive FAQ | 5d? | 2018-06-04 A | 2018-06-20 |  | 75% | 1.25d? | 2018-06-04 | 2018-06-08 | 5d? | 2018-06-04 | 2018-06-20 | 138.75d | finish no earlier than 2018-06-08 | Mark (UIT Guide) |  |  |
| 291 | 1.7.7.1.7.4 | pull out items within service dashboard | 1d | 2018-06-06 A | 2018-06-19 |  | 75% | 0.25d | 2018-06-06 | 2018-06-06 | 1d | 2018-06-06 | 2018-06-19 | 139.75d | start no earlier than 2018-06-06 | Mark (UIT Guide) |  |  |
| 292 | 1.7.7.1.7.5 | **Testing** | 30d? | 2018-06-11 | 2018-07-20 |  |  |  | 2018-06-11 | 2018-07-20 | 30d? | 2018-06-11 | 2018-07-20 | 116d |  | Mark (UIT Guide) |  |  |
| 293 | 1.7.7.1.7.5.1 | Dev Testing | 15d? | 2018-06-11 | 2018-06-29 |  |  |  | 2018-06-11 | 2018-06-29 | 15d? | 2018-06-11 | 2018-06-29 | 131d | finish no earlier than 2018-06-29 | Mark (UIT Guide) |  |  |
| 294 | 1.7.7.1.7.5.2 | UI/UX Testing | 15d? | 2018-06-18 | 2018-07-06 |  |  |  | 2018-06-18 | 2018-07-06 | 15d? | 2018-06-18 | 2018-07-06 | 126d | finish no earlier than 2018-07-06 | Mark (UIT Guide) |  |  |
| 295 | 1.7.7.1.7.5.3 | BO Testin | 15d? | 2018-06-25 | 2018-07-13 |  |  |  | 2018-06-25 | 2018-07-13 | 15d? | 2018-06-25 | 2018-07-13 | 121d | finish no earlier than 2018-07-13 | Mark (UIT Guide) |  |  |
| 296 | 1.7.7.1.7.5.4 | **Functional Testing** | 10d? | 2018-06-25 | 2018-07-06 |  |  |  | 2018-06-25 | 2018-07-06 | 10d? | 2018-06-25 | 2018-07-06 | 126d |  | Mark (UIT Guide) |  |  |
| 297 | 1.7.7.1.7.5.4.1 | iOS | 10d? | 2018-06-25 | 2018-07-06 |  |  |  | 2018-06-25 | 2018-07-06 | 10d? | 2018-06-25 | 2018-07-06 | 126d | finish no earlier than 2018-07-06 | Mark (UIT Guide) |  |  |
| 298 | 1.7.7.1.7.5.4.2 | Android | 10d? | 2018-06-25 | 2018-07-06 |  |  |  | 2018-06-25 | 2018-07-06 | 10d? | 2018-06-25 | 2018-07-06 | 126d | finish no earlier than 2018-07-06 | Mark (UIT Guide) |  |  |
| 299 | 1.7.7.1.7.5.5 | Usability Testing | 10d? | 2018-07-02 | 2018-07-13 |  |  |  | 2018-07-02 | 2018-07-13 | 10d? | 2018-07-02 | 2018-07-13 | 121d | finish no earlier than 2018-07-13 | Mark (UIT Guide) |  |  |
| 300 | 1.7.7.1.7.5.6 | Bug Fixing | 10d? | 2018-07-09 | 2018-07-20 |  |  |  | 2018-07-09 | 2018-07-20 | 10d? | 2018-07-09 | 2018-07-20 | 116d | finish no earlier than 2018-07-20 | Mark (UIT Guide) |  |  |
| 301 | 1.7.7.1.7.6 | Marketing sign-off | 10d? | 2018-07-16 | 2018-07-27 |  |  |  | 2018-07-16 | 2018-07-27 | 10d? | 2018-07-16 | 2018-07-27 | 111d | finish no earlier than 2018-07-27 | Mark (UIT Guide) |  |  |

| ID | WBS | Task | Type | Duration | Start | Finish | Complete | Remaining | Baseline start | Baseline finish | Baseline duration | Baseline 1 start | Baseline 1 finish | Total slack | Constraint | Resources | Work | Actual work | Cost | Actual cost | Text12 | Audience |
| --- | --- | --- | --- | --- | --- | --- | --- | --- | --- | --- | --- | --- | --- | --- | --- | --- | --- | --- | --- | --- | --- | --- |
| 302 | 1.7.7.1.8 | **News** |  | 80d? | 2018-04-02 A | 2018-07-20 | 32% | 54.4d? | 2018-04-02 | 2018-07-20 | 80d? | 2018-04-02 | 2018-07-20 | 116d |  |  | 160h | 160h | 160 | 160 | Diane (News) |  |
| 303 | 1.7.7.1.8.1 | Daily Cougar |  | 1d | 2018-04-02 A | 2018-04-02 A | 100% |  | 2018-04-02 | 2018-04-02 | 1d | 2018-04-02 | 2018-04-02 |  | finish no earlier than 2018-04-19 | Ali Dorton | 8h | 8h | 8 | 8 | Diane (News) |  |
| 304 | 1.7.7.1.8.2 | RSS feeds |  | 14d | 2018-04-02 A | 2018-04-19 A | 100% |  | 2018-04-02 | 2018-04-19 | 14d | 2018-04-02 | 2018-04-19 |  | finish no earlier than 2018-04-19 | Ali Dorton | 112h | 112h | 112 | 112 | Diane (News) |  |
| 305 | 1.7.7.1.8.3 | Pull in images |  | 5d | 2018-06-04 A | 2018-06-08 A | 100% |  | 2018-06-04 | 2018-06-08 | 5d | 2018-06-04 | 2018-06-08 |  | finish no earlier than 2018-06-08 | Ali Dorton | 40h | 40h | 40 | 40 | Diane (News) |  |
| 306 | 1.7.7.1.8.4 | **Testing** |  | 30d? | 2018-06-11 A | 2018-07-20 | 6% | 28.08d? | 2018-06-11 | 2018-07-20 | 30d? | 2018-06-11 | 2018-07-20 | 116d |  |  |  |  |  |  | Diane (News) |  |
| 307 | 1.7.7.1.8.4.1 | Dev Testing | milestone | 0d | 2018-06-11 A | 2018-06-11 A | 100% |  | 2018-06-11 | 2018-06-11 | 0d | 2018-06-11 | 2018-06-11 |  |  | Ali Dorton |  |  |  |  | Diane (News) |  |
| 308 | 1.7.7.1.8.4.2 | UI/UX Testing |  | 5d? | 2018-06-18 | 2018-06-22 |  |  | 2018-06-18 | 2018-06-22 | 5d? | 2018-06-18 | 2018-06-22 | 136d | finish no earlier than 2018-06-22 |  |  |  |  |  | Diane (News) |  |
| 309 | 1.7.7.1.8.4.3 | BO Testing |  | 5d? | 2018-06-25 | 2018-06-29 |  |  | 2018-06-25 | 2018-06-29 | 5d? | 2018-06-25 | 2018-06-29 | 131d | finish no earlier than 2018-06-29 |  |  |  |  |  | Diane (News) |  |
| 310 | 1.7.7.1.8.4.4 | **Functional Testing** |  | 10d | 2018-06-25 A | 2018-07-06 | 8% | 9.2d | 2018-06-25 | 2018-07-06 | 10d | 2018-06-25 | 2018-07-06 | 126d |  |  |  |  |  |  | Diane (News) |  |
| 311 | 1.7.7.1.8.4.4.1 | iOS |  | 10d | 2018-06-25 A | 2018-07-06 | 8% | 9.2d | 2018-06-25 | 2018-07-06 | 10d | 2018-06-25 | 2018-07-06 | 126d | finish no earlier than 2018-07-06 |  |  |  |  |  | Diane (News) |  |
| 312 | 1.7.7.1.8.4.4.2 | Android |  | 10d | 2018-06-25 A | 2018-07-06 | 8% | 9.2d | 2018-06-25 | 2018-07-06 | 10d | 2018-06-25 | 2018-07-06 | 126d | finish no earlier than 2018-07-06 |  |  |  |  |  | Diane (News) |  |
| 313 | 1.7.7.1.8.4.5 | Usability Testing |  | 10d | 2018-07-02 A | 2018-07-13 | 8% | 9.2d | 2018-07-02 | 2018-07-13 | 10d | 2018-07-02 | 2018-07-13 | 121d | finish no earlier than 2018-07-13 |  |  |  |  |  | Diane (News) |  |
| 314 | 1.7.7.1.8.4.6 | Bug Fixing |  | 10d | 2018-07-09 A | 2018-07-20 | 8% | 9.2d | 2018-07-09 | 2018-07-20 | 10d | 2018-07-09 | 2018-07-20 | 116d | finish no earlier than 2018-07-20 |  |  |  |  |  | Diane (News) |  |
| 315 | 1.7.7.1.8.5 | Marketing sign-off |  | 5d | 2018-07-16 A | 2018-07-20 | 16% | 4.2d | 2018-07-16 | 2018-07-20 | 5d | 2018-07-16 | 2018-07-20 | 116d | finish no earlier than 2018-07-20 |  |  |  |  |  | Diane (News) |  |
| 316 | 1.7.7.1.9 | **Calendar** |  | 80d? | 2018-04-02 A | 2018-07-20 | 84% | 12.62d? | 2018-04-02 | 2018-07-20 | 80d? | 2018-04-02 | 2018-07-20 | 116d |  |  | 368h | 368h | 368 | 368 | Deron (Calendar) | UH |
| 317 | 1.7.7.1.9.1 | Build X componant blocks |  | 2d | 2018-06-06 A | 2018-06-07 A | 100% |  | 2018-06-06 | 2018-06-07 | 2d | 2018-06-06 | 2018-06-07 |  | finish no earlier than 2018-04-19 | Robert Birkline | 16h | 16h | 16 | 16 | Deron (Calendar) |  |
| 318 | 1.7.7.1.9.2 | iCAL Format |  | 14d | 2018-04-02 A | 2018-04-19 A | 100% |  | 2018-04-02 | 2018-04-19 | 14d | 2018-04-02 | 2018-04-19 |  | finish no earlier than 2018-04-19 | Robert Birkline | 112h | 112h | 112 | 112 | Deron (Calendar) |  |
| 319 | 1.7.7.1.9.3 | **Testing** |  | 30d? | 2018-06-11 A | 2018-07-20 | 88% | 3.72d? | 2018-06-11 | 2018-07-20 | 30d? | 2018-06-11 | 2018-07-20 | 116d |  |  | 240h | 240h | 240 | 240 | Deron (Calendar) |  |
| 320 | 1.7.7.1.9.3.1 | Dev Testing | milestone | 0d | 2018-06-11 A | 2018-06-11 A | 100% |  | 2018-06-11 | 2018-06-11 | 0d | 2018-06-11 | 2018-06-11 |  |  | Ali Dorton |  |  |  |  | Deron (Calendar) |  |
| 321 | 1.7.7.1.9.3.2 | UI/UX Testing |  | 5d? | 2018-06-18 A | 2018-06-22 A | 100% |  | 2018-06-18 | 2018-06-22 | 5d? | 2018-06-18 | 2018-06-22 |  | finish no earlier than 2018-06-22 | Bob Marberry | 40h | 40h | 40 | 40 | Deron (Calendar) |  |
| 322 | 1.7.7.1.9.3.3 | BO Testing |  | 5d? | 2018-06-25 A | 2018-06-29 A | 100% |  | 2018-06-25 | 2018-06-29 | 5d? | 2018-06-25 | 2018-06-29 |  | finish no earlier than 2018-06-29 | Deana Kreitz | 40h | 40h | 40 | 40 | Deron (Calendar) |  |
| 323 | 1.7.7.1.9.3.4 | **Functional Testing** |  | 10d | 2018-06-25 A | 2018-07-06 A | 100% |  | 2018-06-25 | 2018-07-06 | 10d | 2018-06-25 | 2018-07-06 |  |  |  | 160h | 160h | 160 | 160 | Deron (Calendar) |  |
| 324 | 1.7.7.1.9.3.4.1 | iOS |  | 10d | 2018-06-25 A | 2018-07-06 A | 100% |  | 2018-06-25 | 2018-07-06 | 10d | 2018-06-25 | 2018-07-06 |  | finish no earlier than 2018-07-06 | Dominic Johnson | 80h | 80h | 80 | 80 | Deron (Calendar) |  |
| 325 | 1.7.7.1.9.3.4.2 | Android |  | 10d | 2018-06-25 A | 2018-07-06 A | 100% |  | 2018-06-25 | 2018-07-06 | 10d | 2018-06-25 | 2018-07-06 |  | finish no earlier than 2018-07-06 | Dominic Johnson | 80h | 80h | 80 | 80 | Deron (Calendar) |  |
| 326 | 1.7.7.1.9.3.5 | Usability Testing |  | 10d | 2018-07-02 A | 2018-07-13 | 94% | 0.6d | 2018-07-02 | 2018-07-13 | 10d | 2018-07-02 | 2018-07-13 | 121d | finish no earlier than 2018-07-13 |  |  |  |  |  | Deron (Calendar) |  |
| 327 | 1.7.7.1.9.3.6 | Bug Fixing |  | 10d | 2018-07-09 A | 2018-07-20 | 44% | 5.6d | 2018-07-09 | 2018-07-20 | 10d | 2018-07-09 | 2018-07-20 | 116d | finish no earlier than 2018-07-20 |  |  |  |  |  | Deron (Calendar) |  |
| 328 | 1.7.7.1.9.4 | Marketing sign-off |  | 5d | 2018-07-16 | 2018-07-20 |  |  | 2018-07-16 | 2018-07-20 | 5d | 2018-07-16 | 2018-07-20 | 116d | finish no earlier than 2018-07-20 |  |  |  |  |  | Deron (Calendar) |  |

| ID | WBS | Task | Duration | Start | Finish | Complete | Remaining | Baseline start | Baseline finish | Baseline duration | Baseline 1 start | Baseline 1 finish | Total slack | Constraint | Resources | Work | Actual work | Cost | Actual cost | Audience | Text12 | Text13 |
| --- | --- | --- | --- | --- | --- | --- | --- | --- | --- | --- | --- | --- | --- | --- | --- | --- | --- | --- | --- | --- | --- | --- |
| 329 | 1.7.7.1.10 | **Directory** | 54d? | 2018-04-02 A | 2018-06-14 A | 100% |  | 2018-04-02 | 2018-07-06 | 70d? | 2018-04-02 | 2018-06-14 |  |  |  | 304h | 304h | 304 | 304 | UH | Robert (Directory) | 0.7 |
| 330 | 1.7.7.1.10.1 | CSV/JSON API feed | 14d | 2018-04-02 A | 2018-04-19 A | 100% |  | 2018-04-02 | 2018-04-19 | 14d | 2018-04-02 | 2018-04-19 |  | finish no earlier than 2018-04-19 | Robert Birkline | 112h | 112h | 112 | 112 |  | Robert (Directory) |  |
| 331 | 1.7.7.1.10.2 | **Testing** | 9d? | 2018-06-04 A | 2018-06-14 A | 100% |  | 2018-06-04 | 2018-06-29 | 20d? | 2018-06-04 | 2018-06-14 |  |  |  | 184h | 184h | 184 | 184 |  | Robert (Directory) | 0.66 |
| 332 | 1.7.7.1.10.2.1 | Dev Testing | 5d | 2018-06-04 A | 2018-06-08 A | 100% |  | 2018-06-04 | 2018-06-08 | 5d | 2018-06-04 | 2018-06-08 |  | finish no earlier than 2018-06-08 | Robert Birkline | 40h | 40h | 40 | 40 |  | Robert (Directory) |  |
| 333 | 1.7.7.1.10.2.2 | UI/UX Testing | 4d? | 2018-06-11 A | 2018-06-14 A | 100% |  | 2018-06-11 | 2018-06-15 | 5d? | 2018-06-11 | 2018-06-14 |  | finish no earlier than 2018-06-14 | Bob Marberry | 32h | 32h | 32 | 32 |  | Robert (Directory) | 0.8 |
| 334 | 1.7.7.1.10.2.3 | BO Testing | 4d? | 2018-06-11 A | 2018-06-14 A | 100% |  | 2018-06-18 | 2018-06-22 | 5d? | 2018-06-11 | 2018-06-14 |  | finish no earlier than 2018-06-14 | Robert Birkline | 32h | 32h | 32 | 32 |  | Robert (Directory) | 0.8 |
| 335 | 1.7.7.1.10.2.4 | **Functional Testing** | 4d | 2018-06-11 A | 2018-06-14 A | 100% |  | 2018-06-11 | 2018-06-15 | 5d | 2018-06-11 | 2018-06-14 |  |  |  | 64h | 64h | 64 | 64 |  | Robert (Directory) | 0.8 |
| 336 | 1.7.7.1.10.2.4.1 | iOS | 4d | 2018-06-11 A | 2018-06-14 A | 100% |  | 2018-06-11 | 2018-06-15 | 5d | 2018-06-11 | 2018-06-14 |  | finish no earlier than 2018-06-14 | Dominic Johnson | 32h | 32h | 32 | 32 |  | Robert (Directory) | 0.8 |
| 337 | 1.7.7.1.10.2.4.2 | Android | 4d | 2018-06-11 A | 2018-06-14 A | 100% |  | 2018-06-11 | 2018-06-15 | 5d | 2018-06-11 | 2018-06-14 |  | finish no earlier than 2018-06-14 | Dominic Johnson | 32h | 32h | 32 | 32 |  | Robert (Directory) | 0.8 |
| 338 | 1.7.7.1.10.2.5 | Usability Testing | 4d | 2018-06-11 A | 2018-06-14 A | 100% |  | 2018-06-18 | 2018-06-22 | 5d | 2018-06-11 | 2018-06-14 |  | finish no earlier than 2018-06-14 | Dominic Johnson | 8h | 8h | 8 | 8 |  | Robert (Directory) | 0.2 |
| 339 | 1.7.7.1.10.2.6 | Bug Fixing | 4d | 2018-06-11 A | 2018-06-14 A | 100% |  | 2018-06-25 | 2018-06-29 | 5d | 2018-06-11 | 2018-06-14 |  | finish no earlier than 2018-06-14 | Ali Dorton | 8h | 8h | 8 | 8 |  | Robert (Directory) | 0.2 |
| 340 | 1.7.7.1.10.3 | Marketing sign-off | 4d | 2018-06-11 A | 2018-06-14 A | 100% |  | 2018-07-02 | 2018-07-06 | 5d | 2018-06-11 | 2018-06-14 |  | finish no earlier than 2018-06-14 | Deana Kreitz | 8h | 8h | 8 | 8 |  | Robert (Directory) | 0.2 |
| 341 | 1.7.7.1.11 | **Shuttle Routes** | 70d? | 2018-04-02 A | 2018-07-06 | 50% | 35d? | 2018-04-02 | 2018-07-06 | 70d? | 2018-04-02 | 2018-07-06 | 126d |  |  | 224h | 224h | 224 | 224 | UH | Robert (Shuttles) |  |
| 342 | 1.7.7.1.11.1 | Shuttle Routes | 14d | 2018-04-02 A | 2018-04-19 A | 100% |  | 2018-04-02 | 2018-04-19 | 14d | 2018-04-02 | 2018-04-19 |  | finish no earlier than 2018-04-19 | Robert Birkline | 112h | 112h | 112 | 112 |  | Robert (Shuttles) |  |
| 343 | 1.7.7.1.11.2 | DoubleMap Integration | 14d | 2018-04-02 A | 2018-04-19 A | 100% |  | 2018-04-02 | 2018-04-19 | 14d | 2018-04-02 | 2018-04-19 |  | finish no earlier than 2018-04-19 | Robert Birkline | 112h | 112h | 112 | 112 |  | Robert (Shuttles) |  |
| 344 | 1.7.7.1.11.3 | **Testing** | 20d? | 2018-06-04 A | 2018-06-29 | 14% | 17.14d? | 2018-06-04 | 2018-06-29 | 20d? | 2018-06-04 | 2018-06-29 | 131d |  |  |  |  |  |  |  | Robert (Shuttles) |  |
| 345 | 1.7.7.1.11.3.1 | Dev Testing | 5d | 2018-06-04 A | 2018-06-22 | 20% | 4d | 2018-06-04 | 2018-06-08 | 5d | 2018-06-04 | 2018-06-22 | 136d | finish no earlier than 2018-06-08 |  |  |  |  |  |  | Robert (Shuttles) |  |
| 346 | 1.7.7.1.11.3.2 | UI/UX Testing | 5d? | 2018-06-11 | 2018-06-15 |  |  | 2018-06-11 | 2018-06-15 | 5d? | 2018-06-11 | 2018-06-15 | 141d | finish no earlier than 2018-06-15 |  |  |  |  |  |  | Robert (Shuttles) |  |
| 347 | 1.7.7.1.11.3.3 | BO Testing | 5d? | 2018-06-18 | 2018-06-22 |  |  | 2018-06-18 | 2018-06-22 | 5d? | 2018-06-18 | 2018-06-22 | 136d | finish no earlier than 2018-06-22 |  |  |  |  |  |  | Robert (Shuttles) |  |
| 348 | 1.7.7.1.11.3.4 | **Functional Testing** | 10d | 2018-06-11 A | 2018-06-22 | 20% | 8d | 2018-06-11 | 2018-06-15 | 5d | 2018-06-11 | 2018-06-22 | 136d |  |  |  |  |  |  |  | Robert (Shuttles) |  |
| 349 | 1.7.7.1.11.3.4.1 | iOS | 5d | 2018-06-11 A | 2018-06-22 | 20% | 4d | 2018-06-11 | 2018-06-15 | 5d | 2018-06-11 | 2018-06-22 | 136d | finish no earlier than 2018-06-15 |  |  |  |  |  |  | Robert (Shuttles) |  |
| 350 | 1.7.7.1.11.3.4.2 | Android | 5d | 2018-06-11 A | 2018-06-22 | 20% | 4d | 2018-06-11 | 2018-06-15 | 5d | 2018-06-11 | 2018-06-22 | 136d | finish no earlier than 2018-06-15 |  |  |  |  |  |  | Robert (Shuttles) |  |
| 351 | 1.7.7.1.11.3.5 | Usability Testing | 5d | 2018-06-18 A | 2018-06-22 | 20% | 4d | 2018-06-18 | 2018-06-22 | 5d | 2018-06-18 | 2018-06-22 | 136d | finish no earlier than 2018-06-22 |  |  |  |  |  |  | Robert (Shuttles) |  |
| 352 | 1.7.7.1.11.3.6 | Bug Fixing | 5d | 2018-06-25 A | 2018-06-29 | 20% | 4d | 2018-06-25 | 2018-06-29 | 5d | 2018-06-25 | 2018-06-29 | 131d | finish no earlier than 2018-06-29 |  |  |  |  |  |  | Robert (Shuttles) |  |
| 353 | 1.7.7.1.11.4 | Marketing sign-off | 5d | 2018-07-02 A | 2018-07-06 | 20% | 4d | 2018-07-02 | 2018-07-06 | 5d | 2018-07-02 | 2018-07-06 | 126d | finish no earlier than 2018-07-06 |  |  |  |  |  |  | Robert (Shuttles) |  |

| ID | WBS | Task | Duration | Start | Finish | Complete | Remaining | Baseline start | Baseline finish | Baseline duration | Baseline 1 start | Baseline 1 finish | Total slack | Constraint | Resources | Work | Actual work | Cost | Actual cost | Audience | Text12 | Text13 |
| --- | --- | --- | --- | --- | --- | --- | --- | --- | --- | --- | --- | --- | --- | --- | --- | --- | --- | --- | --- | --- | --- | --- |
| 354 | 1.7.7.1.12 | **Student Media** | 70d? | 2018-04-02 A | 2018-07-06 | 59% | 29.02d? | 2018-04-02 | 2018-07-06 | 70d? | 2018-04-02 | 2018-07-06 | 126d |  |  | 336h | 336h | 336 | 336 | Student | Robert / Lawrence (Student Media) |  |
| 355 | 1.7.7.1.12.1 | The Cougar | 14d | 2018-04-02 A | 2018-04-19 A | 100% |  | 2018-04-02 | 2018-04-19 | 14d | 2018-04-02 | 2018-04-19 |  | finish no earlier than 2018-04-19 | Robert Birkline | 112h | 112h | 112 | 112 |  | Robert / Lawrence (Student Media) |  |
| 356 | 1.7.7.1.12.2 | CougarTV | 14d | 2018-04-02 A | 2018-04-19 A | 100% |  | 2018-04-02 | 2018-04-19 | 14d | 2018-04-02 | 2018-04-19 |  | finish no earlier than 2018-04-19 | Robert Birkline | 112h | 112h | 112 | 112 |  | Robert / Lawrence (Student Media) |  |
| 357 | 1.7.7.1.12.3 | Coog Radio | 14d | 2018-04-02 A | 2018-04-19 A | 100% |  | 2018-04-02 | 2018-04-19 | 14d | 2018-04-02 | 2018-04-19 |  | finish no earlier than 2018-04-19 | Robert Birkline | 112h | 112h | 112 | 112 |  | Robert / Lawrence (Student Media) |  |
| 358 | 1.7.7.1.12.4 | **Testing** | 20d? | 2018-06-04 A | 2018-06-29 | 14% | 17.14d? | 2018-06-04 | 2018-06-29 | 20d? | 2018-06-04 | 2018-06-29 | 131d |  |  |  |  |  |  |  | Robert / Lawrence (Student Media) |  |
| 359 | 1.7.7.1.12.4.1 | Dev Testing | 5d | 2018-06-04 A | 2018-06-22 | 20% | 4d | 2018-06-04 | 2018-06-08 | 5d | 2018-06-04 | 2018-06-22 | 136d | finish no earlier than 2018-06-08 |  |  |  |  |  |  | Robert / Lawrence (Student Media) |  |
| 360 | 1.7.7.1.12.4.2 | UI/UX Testing | 5d? | 2018-06-11 | 2018-06-15 |  |  | 2018-06-11 | 2018-06-15 | 5d? | 2018-06-11 | 2018-06-15 | 141d | finish no earlier than 2018-06-15 |  |  |  |  |  |  | Robert / Lawrence (Student Media) |  |
| 361 | 1.7.7.1.12.4.3 | BO Testing | 5d? | 2018-06-18 | 2018-06-22 |  |  | 2018-06-18 | 2018-06-22 | 5d? | 2018-06-18 | 2018-06-22 | 136d | finish no earlier than 2018-06-22 |  |  |  |  |  |  | Robert / Lawrence (Student Media) |  |
| 362 | 1.7.7.1.12.4.4 | **Functional Testing** | 10d | 2018-06-11 A | 2018-06-22 | 20% | 8d | 2018-06-11 | 2018-06-15 | 5d | 2018-06-11 | 2018-06-22 | 136d |  |  |  |  |  |  |  | Robert / Lawrence (Student Media) |  |
| 363 | 1.7.7.1.12.4.4.1 | iOS | 5d | 2018-06-11 A | 2018-06-22 | 20% | 4d | 2018-06-11 | 2018-06-15 | 5d | 2018-06-11 | 2018-06-22 | 136d | finish no earlier than 2018-06-15 |  |  |  |  |  |  | Robert / Lawrence (Student Media) |  |
| 364 | 1.7.7.1.12.4.4.2 | Android | 5d | 2018-06-11 A | 2018-06-22 | 20% | 4d | 2018-06-11 | 2018-06-15 | 5d | 2018-06-11 | 2018-06-22 | 136d | finish no earlier than 2018-06-15 |  |  |  |  |  |  | Robert / Lawrence (Student Media) |  |
| 365 | 1.7.7.1.12.4.5 | Usability Testing | 5d | 2018-06-18 A | 2018-06-22 | 20% | 4d | 2018-06-18 | 2018-06-22 | 5d | 2018-06-18 | 2018-06-22 | 136d | finish no earlier than 2018-06-22 |  |  |  |  |  |  | Robert / Lawrence (Student Media) |  |
| 366 | 1.7.7.1.12.4.6 | Bug Fixing | 5d | 2018-06-25 A | 2018-06-29 | 20% | 4d | 2018-06-25 | 2018-06-29 | 5d | 2018-06-25 | 2018-06-29 | 131d | finish no earlier than 2018-06-29 |  |  |  |  |  |  | Robert / Lawrence (Student Media) |  |
| 367 | 1.7.7.1.12.5 | Marketing sign-off | 5d | 2018-07-02 A | 2018-07-06 | 20% | 4d | 2018-07-02 | 2018-07-06 | 5d | 2018-07-02 | 2018-07-06 | 126d | finish no earlier than 2018-07-06 |  |  |  |  |  |  | Robert / Lawrence (Student Media) |  |
| 368 | 1.7.7.1.13 | **Maps** | 15d | 2018-06-04 A | 2018-06-22 | 77% | 3.41d | 2018-06-04 | 2018-07-27 | 40d | 2018-06-04 | 2018-06-22 | 136d |  |  | 150h | 150h | 150 | 150 | UH | Robert (Maps) | 0.42 |
| 369 | 1.7.7.1.13.1 | Way-finder | 8d | 2018-06-04 A | 2018-06-13 A | 100% |  | 2018-06-04 | 2018-06-21 | 14d | 2018-06-04 | 2018-06-13 |  | finish no earlier than 2018-04-19 | fix bugs | 64h | 64h | 64 | 64 |  | Robert (Maps) | 0.57 |
| 370 | 1.7.7.1.13.2 | **Testing** | 10d | 2018-06-11 A | 2018-06-22 | 68% | 3.23d | 2018-06-04 | 2018-07-20 | 35d | 2018-06-11 | 2018-06-22 | 136d |  |  | 78h | 78h | 78 | 78 |  | Robert (Maps) | 0.39 |
| 371 | 1.7.7.1.13.2.1 | Dev Testing | 1d | 2018-06-11 A | 2018-06-11 A | 100% |  | 2018-06-11 | 2018-06-29 | 5d | 2018-06-11 | 2018-06-11 |  | finish no earlier than 2018-06-29 | Dominic Johnson | 8h | 8h | 8 | 8 |  | Robert (Maps) | 0.2 |
| 372 | 1.7.7.1.13.2.2 | UI/UX Testing | 5d | 2018-06-11 A | 2018-06-15 A | 100% |  | 2018-07-02 | 2018-07-06 | 5d | 2018-06-11 | 2018-06-15 |  | finish no earlier than 2018-07-06 | Bob Marberry | 40h | 40h | 40 | 40 |  | Robert (Maps) |  |
| 373 | 1.7.7.1.13.2.3 | BO Testing | 5d | 2018-06-11 A | 2018-06-15 A | 100% |  | 2018-07-09 | 2018-07-13 | 5d | 2018-06-11 | 2018-06-15 |  | finish no earlier than 2018-06-15 | Diane Trippel | 30h | 30h | 30 | 30 |  | Robert (Maps) | 0.75 |
| 374 | 1.7.7.1.13.2.4 | **Functional Testing** | 5d | 2018-06-18 A | 2018-06-22 | 50% | 2.5d | 2018-06-25 | 2018-07-06 | 10d | 2018-06-18 | 2018-06-22 | 136d |  |  |  |  |  |  |  | Robert (Maps) | 0.2 |
| 375 | 1.7.7.1.13.2.4.1 | iOS | 5d | 2018-06-18 A | 2018-06-22 | 50% | 2.5d | 2018-06-25 | 2018-07-06 | 5d | 2018-06-18 | 2018-06-22 | 136d | finish no earlier than 2018-06-22 |  |  |  |  |  |  | Robert (Maps) | 0.2 |
| 376 | 1.7.7.1.13.2.4.2 | Android | 5d | 2018-06-18 A | 2018-06-22 | 50% | 2.5d | 2018-06-25 | 2018-07-06 | 5d | 2018-06-18 | 2018-06-22 | 136d | finish no earlier than 2018-06-22 |  |  |  |  |  |  | Robert (Maps) | 0.2 |
| 377 | 1.7.7.1.13.2.5 | Usability Testing | 5d | 2018-06-18 A | 2018-06-22 | 50% | 2.5d | 2018-07-02 | 2018-07-13 | 5d | 2018-06-18 | 2018-06-22 | 136d | finish no earlier than 2018-06-22 |  |  |  |  |  |  | Robert (Maps) | 0.2 |
| 378 | 1.7.7.1.13.2.6 | Bug Fixing | 5d | 2018-06-18 A | 2018-06-22 | 50% | 2.5d | 2018-06-04 | 2018-07-20 | 5d | 2018-06-18 | 2018-06-22 | 136d | finish no earlier than 2018-06-22 |  |  |  |  |  |  | Robert (Maps) | 0.2 |
| 379 | 1.7.7.1.13.3 | Marketing sign-off | 5d | 2018-06-18 A | 2018-06-22 A | 100% |  | 2018-06-14 | 2018-06-15 | 5d | 2018-06-18 | 2018-06-22 |  | finish no earlier than 2018-06-22 | Deana Kreitz | 8h | 8h | 8 | 8 |  | Robert (Maps) | 0.2 |

| ID | WBS | Task | Type | Duration | Start | Finish | Predecessors | Complete | Remaining | Baseline start | Baseline finish | Baseline duration | Baseline 1 start | Baseline 1 finish | Total slack | Free slack | Constraint | Resources | Work | Actual work | Cost | Actual cost | Audience | Text12 | Text13 |
| --- | --- | --- | --- | --- | --- | --- | --- | --- | --- | --- | --- | --- | --- | --- | --- | --- | --- | --- | --- | --- | --- | --- | --- | --- | --- |
| 380 | 1.7.7.1.14 | **Alerts** |  | 28.1d | 2018-06-14 A | 2018-07-24 |  | 29% | 20.01d | 2018-06-04 | 2018-07-20 | 35d? | 2018-06-25 | 2018-07-27 | 114.9d |  |  |  | 8h | 7.76h | 8 | 7.76 | UH | Deron (Alerts) | 0.41 |
| 381 | 1.7.7.1.14.1 | **Emergency Notifications** |  | 2d | 2018-07-09 | 2018-07-10 |  |  |  | 2018-06-04 | 2018-06-08 | 5d | 2018-07-09 | 2018-07-10 | 0d |  |  |  |  |  |  |  |  | Deron (Alerts) | 0.4 |
| 382 | 1.7.7.1.14.1.1 | how does Marketing want it to work? | manual | 2d | 2018-07-09 | 2018-07-10 | 213, 271 |  |  | 2018-06-04 | 2018-06-08 | 5d | 2018-07-09 | 2018-07-10 |  |  |  |  |  |  |  |  |  | Deron (Alerts) | 0.4 |
| 383 | 1.7.7.1.14.2 | Configure API |  | 1d | 2018-06-14 A | 2018-06-14 |  | 97% | 0.03d | 2018-06-11 | 2018-06-11 | 1d | 2018-07-11 | 2018-07-11 | 8.9d | 0d | start no earlier than 2018-06-14 | Robert Birkline | 8h | 7.76h | 8 | 7.76 |  | Deron (Alerts) |  |
| 384 | 1.7.7.1.14.3 | **Testing** |  | 26d | 2018-06-15 A | 2018-07-20 |  | 26% | 19.31d | 2018-06-11 | 2018-07-20 | 30d? | 2018-06-25 | 2018-07-26 | 0d |  |  |  |  |  |  |  |  | Deron (Alerts) | 0.4 |
| 385 | 1.7.7.1.14.3.1 | Dev Testing |  | 2d | 2018-06-15 | 2018-06-18 | 383 |  |  | 2018-06-11 | 2018-06-15 | 5d | 2018-07-12 | 2018-07-13 | 8.9d | 2d | finish no earlier than 2018-06-15 |  |  |  |  |  |  | Deron (Alerts) | 0.4 |
| 386 | 1.7.7.1.14.3.2 | UI/UX Testing |  | 2d | 2018-06-21 | 2018-06-22 | 385 |  |  | 2018-06-18 | 2018-06-22 | 5d? | 2018-07-16 | 2018-07-17 | 6.9d | 3d | finish no earlier than 2018-06-22 |  |  |  |  |  |  | Deron (Alerts) | 0.4 |
| 387 | 1.7.7.1.14.3.3 | BO Testing |  | 2d | 2018-06-28 | 2018-06-29 | 386 |  |  | 2018-06-25 | 2018-06-29 | 5d? | 2018-07-18 | 2018-07-19 | 3.9d | 0d | finish no earlier than 2018-06-29 |  |  |  |  |  |  | Deron (Alerts) | 0.4 |
| 388 | 1.7.7.1.14.3.4 | **Functional Testing** |  | 11.1d | 2018-06-25 A | 2018-07-10 |  | 45% | 6.11d | 2018-06-25 | 2018-07-06 | 10d | 2018-06-25 | 2018-07-24 | 2.8d |  |  |  |  |  |  |  |  | Deron (Alerts) | 0.4 |
| 389 | 1.7.7.1.14.3.4.1 | iOS |  | 2d | 2018-06-25 A | 2018-07-06 | 387 | 45% | 1.1d | 2018-06-25 | 2018-07-06 | 5d | 2018-06-25 | 2018-07-23 | 0d |  | finish no earlier than 2018-07-06 |  |  |  |  |  |  | Deron (Alerts) | 0.4 |
| 390 | 1.7.7.1.14.3.4.2 | Android |  | 2d | 2018-06-25 A | 2018-07-10 | 389 | 45% | 1.1d | 2018-06-25 | 2018-07-06 | 5d | 2018-06-25 | 2018-07-24 | 2.8d | 0d | finish no earlier than 2018-07-06 |  |  |  |  |  |  | Deron (Alerts) | 0.4 |
| 391 | 1.7.7.1.14.3.5 | Usability Testing |  | 2d | 2018-07-02 A | 2018-07-13 | 390 | 45% | 1.1d | 2018-07-02 | 2018-07-13 | 5d | 2018-07-02 | 2018-07-25 | 3.9d | 0d | finish no earlier than 2018-07-13 |  |  |  |  |  |  | Deron (Alerts) | 0.4 |
| 392 | 1.7.7.1.14.3.6 | Bug Fixing |  | 2d | 2018-07-09 A | 2018-07-20 | 391 | 45% | 1.1d | 2018-07-09 | 2018-07-20 | 5d | 2018-07-09 | 2018-07-26 | 0d |  | finish no earlier than 2018-07-20 |  |  |  |  |  |  | Deron (Alerts) | 0.4 |
| 393 | 1.7.7.1.14.4 | Marketing sign-off |  | 2d | 2018-07-16 A | 2018-07-24 | 392 | 45% | 1.1d | 2018-07-16 | 2018-07-20 | 5d | 2018-07-16 | 2018-07-27 | 114.9d |  | finish no earlier than 2018-07-20 |  |  |  |  |  |  | Deron (Alerts) | 0.4 |
| 394 | 1.7.7.1.15 | **UH Tours** |  | 30d? | 2018-06-18 A | 2018-07-27 |  | 11% | 26.67d? | 2018-06-18 | 2018-07-27 | 30d? | 2018-06-18 | 2018-07-27 | 111d |  |  |  |  |  |  |  | UH | Robert (UH Tours) |  |
| 395 | 1.7.7.1.15.1 | migrate art assets to map |  | 14d | 2018-06-19 | 2018-07-06 |  |  |  | 2018-06-18 | 2018-07-05 | 14d | 2018-06-19 | 2018-07-06 | 126d |  | start no earlier than 2018-06-18 |  |  |  |  |  |  | Robert (UH Tours) |  |
| 396 | 1.7.7.1.15.2 | **Testing** |  | 25d? | 2018-06-18 A | 2018-07-20 |  | 14% | 21.43d? | 2018-06-18 | 2018-07-20 | 25d? | 2018-06-18 | 2018-07-20 | 116d |  |  |  |  |  |  |  |  | Robert (UH Tours) |  |
| 397 | 1.7.7.1.15.2.1 | Dev Testing |  | 5d | 2018-06-18 A | 2018-06-22 |  | 20% | 4d | 2018-06-18 | 2018-06-22 | 5d | 2018-06-18 | 2018-06-22 | 136d |  | finish no earlier than 2018-06-22 |  |  |  |  |  |  | Robert (UH Tours) |  |
| 398 | 1.7.7.1.15.2.2 | UI/UX Testing |  | 5d? | 2018-06-25 | 2018-06-29 |  |  |  | 2018-06-25 | 2018-06-29 | 5d? | 2018-06-25 | 2018-06-29 | 131d |  | start no earlier than 2018-06-25 |  |  |  |  |  |  | Robert (UH Tours) |  |
| 399 | 1.7.7.1.15.2.3 | BO Testing |  | 5d? | 2018-07-02 | 2018-07-06 |  |  |  | 2018-07-02 | 2018-07-06 | 5d? | 2018-07-02 | 2018-07-06 | 126d |  | start no earlier than 2018-07-02 |  |  |  |  |  |  | Robert (UH Tours) |  |
| 400 | 1.7.7.1.15.2.4 | **Functional Testing** |  | 5d | 2018-07-02 A | 2018-07-06 |  | 20% | 4d | 2018-07-02 | 2018-07-06 | 5d | 2018-07-02 | 2018-07-06 | 126d |  |  |  |  |  |  |  |  | Robert (UH Tours) |  |
| 401 | 1.7.7.1.15.2.4.1 | iOS |  | 5d | 2018-07-02 A | 2018-07-06 |  | 20% | 4d | 2018-07-02 | 2018-07-06 | 5d | 2018-07-02 | 2018-07-06 | 126d |  | finish no earlier than 2018-07-06 |  |  |  |  |  |  | Robert (UH Tours) |  |
| 402 | 1.7.7.1.15.2.4.2 | Android |  | 5d | 2018-07-02 A | 2018-07-06 |  | 20% | 4d | 2018-07-02 | 2018-07-06 | 5d | 2018-07-02 | 2018-07-06 | 126d |  | finish no earlier than 2018-07-06 |  |  |  |  |  |  | Robert (UH Tours) |  |
| 403 | 1.7.7.1.15.2.5 | Usability Testing |  | 5d | 2018-07-09 A | 2018-07-13 |  | 20% | 4d | 2018-07-09 | 2018-07-13 | 5d | 2018-07-09 | 2018-07-13 | 121d |  | finish no earlier than 2018-07-13 |  |  |  |  |  |  | Robert (UH Tours) |  |
| 404 | 1.7.7.1.15.2.6 | Bug Fixing |  | 5d | 2018-07-16 A | 2018-07-20 |  | 20% | 4d | 2018-07-16 | 2018-07-20 | 5d | 2018-07-16 | 2018-07-20 | 116d |  | finish no earlier than 2018-07-20 |  |  |  |  |  |  | Robert (UH Tours) |  |
| 405 | 1.7.7.1.15.3 | Marketing sign-off |  | 5d | 2018-07-23 A | 2018-07-27 |  | 20% | 4d | 2018-07-23 | 2018-07-27 | 5d | 2018-07-23 | 2018-07-27 | 111d |  | finish no earlier than 2018-07-27 |  |  |  |  |  |  | Robert (UH Tours) |  |

| ID | WBS | Task | Type | Duration | Start | Finish | Complete | Remaining | Baseline start | Baseline finish | Baseline duration | Baseline 1 start | Baseline 1 finish | Total slack | Constraint | Resources | Work | Actual work | Cost | Actual cost | Audience | Text12 | Text13 |
| --- | --- | --- | --- | --- | --- | --- | --- | --- | --- | --- | --- | --- | --- | --- | --- | --- | --- | --- | --- | --- | --- | --- | --- |
| 406 | 1.7.7.1.16 | **Sugar Land** |  | 10d? | 2018-06-04 A | 2018-06-15 A | 100% |  | 2018-06-04 | 2018-07-27 | 40d? | 2018-06-04 | 2018-06-15 |  |  |  | 200h | 200h | 200 | 200 | Students>Sugarland | Robert (Sugar Land) | 0.25 |
| 407 | 1.7.7.1.16.1 | Add Geo-location | manual | 5d | 2018-06-04 A | 2018-06-08 A | 100% |  | 2018-06-18 | 2018-06-18 | 1d | 2018-06-04 | 2018-06-08 |  |  | Robert Birkline | 40h | 40h | 40 | 40 |  | Robert (Sugar Land) |  |
| 408 | 1.7.7.1.16.2 | Wayfinding |  | 4d? | 2018-06-08 A | 2018-06-13 A | 100% |  | 2018-06-04 | 2018-06-08 | 5d? | 2018-06-08 | 2018-06-13 |  | finish no earlier than 2018-06-13 | Robert Birkline | 32h | 32h | 32 | 32 |  | Robert (Sugar Land) | 0.8 |
| 409 | 1.7.7.1.16.3 | **Testing** |  | 2d? | 2018-06-14 A | 2018-06-15 A | 100% |  | 2018-06-11 | 2018-07-20 | 30d? | 2018-06-14 | 2018-06-15 |  |  |  | 112h | 112h | 112 | 112 |  | Robert (Sugar Land) | 0.16 |
| 410 | 1.7.7.1.16.3.1 | Dev Testing |  | 2d? | 2018-06-14 A | 2018-06-15 A | 100% |  | 2018-06-11 | 2018-06-29 | 15d? | 2018-06-14 | 2018-06-15 |  | start no earlier than 2018-06-14 | Dominic Johnson | 16h | 16h | 16 | 16 |  | Robert (Sugar Land) | 0.13 |
| 411 | 1.7.7.1.16.3.2 | UI/UX Testing |  | 2d? | 2018-06-14 A | 2018-06-15 A | 100% |  | 2018-06-18 | 2018-07-06 | 15d? | 2018-06-14 | 2018-06-15 |  | finish no earlier than 2018-06-15 | Bob Marberry | 16h | 16h | 16 | 16 |  | Robert (Sugar Land) | 0.13 |
| 412 | 1.7.7.1.16.3.3 | BO Testing |  | 2d? | 2018-06-14 A | 2018-06-15 A | 100% |  | 2018-06-25 | 2018-07-13 | 15d? | 2018-06-14 | 2018-06-15 |  | finish no earlier than 2018-06-15 | Robert Birkline | 16h | 16h | 16 | 16 |  | Robert (Sugar Land) | 0.13 |
| 413 | 1.7.7.1.16.3.4 | **Functional Testing** |  | 2d? | 2018-06-14 A | 2018-06-15 A | 100% |  | 2018-06-25 | 2018-07-06 | 10d? | 2018-06-14 | 2018-06-15 |  |  |  | 32h | 32h | 32 | 32 |  | Robert (Sugar Land) | 0.2 |
| 414 | 1.7.7.1.16.3.4.1 | iOS |  | 2d? | 2018-06-14 A | 2018-06-15 A | 100% |  | 2018-06-25 | 2018-07-06 | 10d? | 2018-06-14 | 2018-06-15 |  | finish no earlier than 2018-06-15 | Dominic Johnson | 16h | 16h | 16 | 16 |  | Robert (Sugar Land) | 0.2 |
| 415 | 1.7.7.1.16.3.4.2 | Android |  | 2d? | 2018-06-14 A | 2018-06-15 A | 100% |  | 2018-06-25 | 2018-07-06 | 10d? | 2018-06-14 | 2018-06-15 |  | finish no earlier than 2018-06-15 | Dominic Johnson | 16h | 16h | 16 | 16 |  | Robert (Sugar Land) | 0.2 |
| 416 | 1.7.7.1.16.3.5 | Usability Testing |  | 2d? | 2018-06-14 A | 2018-06-15 A | 100% |  | 2018-07-02 | 2018-07-13 | 10d? | 2018-06-14 | 2018-06-15 |  | finish no earlier than 2018-06-15 | Dominic Johnson | 16h | 16h | 16 | 16 |  | Robert (Sugar Land) | 0.2 |
| 417 | 1.7.7.1.16.3.6 | Bug Fixing |  | 2d? | 2018-06-14 A | 2018-06-15 A | 100% |  | 2018-07-09 | 2018-07-20 | 10d? | 2018-06-14 | 2018-06-15 |  | finish no earlier than 2018-06-15 | Robert Birkline | 16h | 16h | 16 | 16 |  | Robert (Sugar Land) | 0.2 |
| 418 | 1.7.7.1.16.4 | Marketing sign-off |  | 2d? | 2018-06-14 A | 2018-06-15 A | 100% |  | 2018-07-16 | 2018-07-27 | 10d? | 2018-06-14 | 2018-06-15 |  | finish no earlier than 2018-06-15 | Deana Kreitz | 16h | 16h | 16 | 16 |  | Robert (Sugar Land) | 0.2 |
| 419 | 1.7.7.1.17 | **Weeks of Welcome** |  | 40d? | 2018-06-04 A | 2018-07-27 | 4% | 38.3d? | 2018-06-04 | 2018-07-27 | 40d? | 2018-06-04 | 2018-07-27 | 111d |  |  |  |  |  |  | Students | Robert (WOW) |  |
| 420 | 1.7.7.1.17.1 | Content |  | 20d | 2018-06-04 A | 2018-07-12 | 10% | 18d | 2018-06-04 | 2018-06-29 | 20d | 2018-06-04 | 2018-07-12 | 122d | finish no earlier than 2018-06-29 |  |  |  |  |  |  | Robert (WOW) |  |
| 421 | 1.7.7.1.17.2 | Pilot iBeacons using Aruba |  | 30d | 2018-06-13 A | 2018-07-25 | 10% | 27d | 2018-06-18 | 2018-07-27 | 30d | 2018-06-13 | 2018-07-25 | 113d | start no earlier than 2018-06-13 |  |  |  |  |  |  | Robert (WOW) |  |
| 422 | 1.7.7.1.17.3 | QR codes |  | 20d | 2018-06-04 A | 2018-07-12 | 10% | 18d | 2018-06-04 | 2018-06-29 | 20d | 2018-06-04 | 2018-07-12 | 122d | finish no earlier than 2018-06-29 |  |  |  |  |  |  | Robert (WOW) |  |
| 423 | 1.7.7.1.17.4 | **Testing** |  | 24d? | 2018-06-19 | 2018-07-20 |  |  | 2018-06-11 | 2018-07-20 | 30d? | 2018-06-19 | 2018-07-20 | 116d |  |  |  |  |  |  |  | Robert (WOW) |  |
| 424 | 1.7.7.1.17.4.1 | Dev Testing |  | 15d? | 2018-06-19 | 2018-07-09 |  |  | 2018-06-11 | 2018-06-29 | 15d? | 2018-06-19 | 2018-07-09 | 125d | start no earlier than 2018-06-18 |  |  |  |  |  |  | Robert (WOW) |  |
| 425 | 1.7.7.1.17.4.2 | UI/UX Testing |  | 15d? | 2018-06-19 | 2018-07-09 |  |  | 2018-06-18 | 2018-07-06 | 15d? | 2018-06-19 | 2018-07-09 | 125d | start no earlier than 2018-06-18 |  |  |  |  |  |  | Robert (WOW) |  |
| 426 | 1.7.7.1.17.4.3 | BO Testing |  | 15d? | 2018-06-25 | 2018-07-13 |  |  | 2018-06-25 | 2018-07-13 | 15d? | 2018-06-25 | 2018-07-13 | 121d | start no earlier than 2018-06-25 |  |  |  |  |  |  | Robert (WOW) |  |
| 427 | 1.7.7.1.17.4.4 | **Functional Testing** |  | 10d? | 2018-06-25 | 2018-07-06 |  |  | 2018-06-25 | 2018-07-06 | 10d? | 2018-06-25 | 2018-07-06 | 126d |  |  |  |  |  |  |  | Robert (WOW) |  |
| 428 | 1.7.7.1.17.4.4.1 | iOS |  | 10d? | 2018-06-25 | 2018-07-06 |  |  | 2018-06-25 | 2018-07-06 | 10d? | 2018-06-25 | 2018-07-06 | 126d | start no earlier than 2018-06-25 |  |  |  |  |  |  | Robert (WOW) |  |
| 429 | 1.7.7.1.17.4.4.2 | Android |  | 10d? | 2018-06-25 | 2018-07-06 |  |  | 2018-06-25 | 2018-07-06 | 10d? | 2018-06-25 | 2018-07-06 | 126d | start no earlier than 2018-06-25 |  |  |  |  |  |  | Robert (WOW) |  |
| 430 | 1.7.7.1.17.4.5 | Usability Testing |  | 10d? | 2018-07-02 | 2018-07-13 |  |  | 2018-07-02 | 2018-07-13 | 10d? | 2018-07-02 | 2018-07-13 | 121d | start no earlier than 2018-07-02 |  |  |  |  |  |  | Robert (WOW) |  |
| 431 | 1.7.7.1.17.4.6 | Bug Fixing |  | 10d? | 2018-07-09 | 2018-07-20 |  |  | 2018-07-09 | 2018-07-20 | 10d? | 2018-07-09 | 2018-07-20 | 116d | start no earlier than 2018-07-09 |  |  |  |  |  |  | Robert (WOW) |  |
| 432 | 1.7.7.1.17.5 | Marketing sign-off |  | 10d? | 2018-07-16 | 2018-07-27 |  |  | 2018-07-16 | 2018-07-27 | 10d? | 2018-07-16 | 2018-07-27 | 111d | start no earlier than 2018-07-16 |  |  |  |  |  |  | Robert (WOW) |  |

| ID | WBS | Task | Type | Duration | Start | Finish | Complete | Remaining | Baseline start | Baseline finish | Baseline duration | Baseline 1 start | Baseline 1 finish | Total slack | Constraint | Resources | Work | Actual work | Cost | Actual cost | Audience | Text12 | Text13 |
| --- | --- | --- | --- | --- | --- | --- | --- | --- | --- | --- | --- | --- | --- | --- | --- | --- | --- | --- | --- | --- | --- | --- | --- |
| 433 | 1.7.7.1.18 | **OEM** |  | 29d? | 2018-06-19 | 2018-07-27 |  |  | 2018-06-11 | 2018-07-27 | 35d? | 2018-06-19 | 2018-07-27 | 111d |  |  |  |  |  |  | UH | Robert (OEM) |  |
| 434 | 1.7.7.1.18.1 | Be Prepared |  | 5d? | 2018-06-19 | 2018-06-25 |  |  | 2018-06-18 | 2018-06-22 | 5d? | 2018-06-19 | 2018-06-25 | 135d | start no earlier than 2018-06-18 |  |  |  |  |  |  | Robert (OEM) |  |
| 435 | 1.7.7.1.18.2 | **Testing** |  | 24d? | 2018-06-19 | 2018-07-20 |  |  | 2018-06-11 | 2018-07-20 | 30d? | 2018-06-19 | 2018-07-20 | 116d |  |  |  |  |  |  |  | Robert (OEM) |  |
| 436 | 1.7.7.1.18.2.1 | Dev Testing |  | 15d? | 2018-06-19 | 2018-07-09 |  |  | 2018-06-11 | 2018-06-29 | 15d? | 2018-06-19 | 2018-07-09 | 125d | start no earlier than 2018-06-18 |  |  |  |  |  |  | Robert (OEM) |  |
| 437 | 1.7.7.1.18.2.2 | UI/UX Testing |  | 15d? | 2018-06-19 | 2018-07-09 |  |  | 2018-06-18 | 2018-07-06 | 15d? | 2018-06-19 | 2018-07-09 | 125d | start no earlier than 2018-06-18 |  |  |  |  |  |  | Robert (OEM) |  |
| 438 | 1.7.7.1.18.2.3 | BO Testing |  | 15d? | 2018-06-25 | 2018-07-13 |  |  | 2018-06-25 | 2018-07-13 | 15d? | 2018-06-25 | 2018-07-13 | 121d | start no earlier than 2018-06-25 |  |  |  |  |  |  | Robert (OEM) |  |
| 439 | 1.7.7.1.18.2.4 | **Functional Testing** |  | 10d? | 2018-06-25 | 2018-07-06 |  |  | 2018-06-25 | 2018-07-06 | 10d? | 2018-06-25 | 2018-07-06 | 126d |  |  |  |  |  |  |  | Robert (OEM) |  |
| 440 | 1.7.7.1.18.2.4.1 | iOS |  | 10d? | 2018-06-25 | 2018-07-06 |  |  | 2018-06-25 | 2018-07-06 | 10d? | 2018-06-25 | 2018-07-06 | 126d | start no earlier than 2018-06-25 |  |  |  |  |  |  | Robert (OEM) |  |
| 441 | 1.7.7.1.18.2.4.2 | Android |  | 10d? | 2018-06-25 | 2018-07-06 |  |  | 2018-06-25 | 2018-07-06 | 10d? | 2018-06-25 | 2018-07-06 | 126d | start no earlier than 2018-06-25 |  |  |  |  |  |  | Robert (OEM) |  |
| 442 | 1.7.7.1.18.2.5 | Usability Testing |  | 10d? | 2018-07-02 | 2018-07-13 |  |  | 2018-07-02 | 2018-07-13 | 10d? | 2018-07-02 | 2018-07-13 | 121d | start no earlier than 2018-07-02 |  |  |  |  |  |  | Robert (OEM) |  |
| 443 | 1.7.7.1.18.2.6 | Bug Fixing |  | 10d? | 2018-07-09 | 2018-07-20 |  |  | 2018-07-09 | 2018-07-20 | 10d? | 2018-07-09 | 2018-07-20 | 116d | start no earlier than 2018-07-09 |  |  |  |  |  |  | Robert (OEM) |  |
| 444 | 1.7.7.1.18.3 | Marketing sign-off |  | 10d? | 2018-07-16 | 2018-07-27 |  |  | 2018-07-16 | 2018-07-27 | 10d? | 2018-07-16 | 2018-07-27 | 111d | start no earlier than 2018-07-16 |  |  |  |  |  |  | Robert (OEM) |  |
| 445 | 1.7.7.1.19 | Provost |  | 21d? | 2018-06-04 A | 2018-07-03 | 50% | 10.5d? | 2018-06-04 | 2018-07-02 | 21d? | 2018-06-04 | 2018-07-03 | 129.5d |  |  |  |  |  |  |  | Robert (OEM) |  |
| 446 | 1.7.7.1.20 | **CFI** |  | 8d? | 2018-06-04 A | 2018-06-13 A | 100% |  | 2018-06-11 | 2018-07-27 | 35d? | 2018-06-04 | 2018-06-13 |  |  |  | 256h | 256h | 256 | 256 | Students | Robert (CFI) | 0.28 |
| 447 | 1.7.7.1.20.1 | update map (create CFI filter) | manual | 5d | 2018-06-04 A | 2018-06-08 A | 100% |  | 2018-06-28 | 2018-06-28 | 1d | 2018-06-04 | 2018-06-08 |  |  | Robert Birkline | 40h | 40h | 40 | 40 |  | Robert (CFI) |  |
| 448 | 1.7.7.1.20.2 | add content | manual | 3d | 2018-06-11 A | 2018-06-13 A | 100% |  | 2018-06-18 | 2018-07-13 | 20d | 2018-06-11 | 2018-06-13 |  |  | Dan Olivaris | 24h | 24h | 24 | 24 |  | Robert (CFI) | 0.15 |
| 449 | 1.7.7.1.20.3 | **Testing** |  | 3d? | 2018-06-11 A | 2018-06-13 A | 100% |  | 2018-06-11 | 2018-07-20 | 30d? | 2018-06-11 | 2018-06-13 |  |  |  | 168h | 168h | 168 | 168 |  | Robert (CFI) | 0.25 |
| 450 | 1.7.7.1.20.3.1 | Dev Testing |  | 3d? | 2018-06-11 A | 2018-06-13 A | 100% |  | 2018-06-11 | 2018-06-29 | 15d? | 2018-06-11 | 2018-06-13 |  | finish no earlier than 2018-06-13 | Dominic Johnson | 24h | 24h | 24 | 24 |  | Robert (CFI) | 0.2 |
| 451 | 1.7.7.1.20.3.2 | UI/UX Testing |  | 3d? | 2018-06-11 A | 2018-06-13 A | 100% |  | 2018-06-18 | 2018-07-06 | 15d? | 2018-06-11 | 2018-06-13 |  | finish no earlier than 2018-06-13 | Bob Marberry | 24h | 24h | 24 | 24 |  | Robert (CFI) | 0.2 |
| 452 | 1.7.7.1.20.3.3 | BO Testing |  | 3d? | 2018-06-11 A | 2018-06-13 A | 100% |  | 2018-06-25 | 2018-07-13 | 15d? | 2018-06-11 | 2018-06-13 |  | finish no earlier than 2018-06-13 | Dan Olivaris | 24h | 24h | 24 | 24 |  | Robert (CFI) | 0.2 |
| 453 | 1.7.7.1.20.3.4 | **Functional Testing** |  | 3d? | 2018-06-11 A | 2018-06-13 A | 100% |  | 2018-06-25 | 2018-07-06 | 10d? | 2018-06-11 | 2018-06-13 |  |  |  | 48h | 48h | 48 | 48 |  | Robert (CFI) | 0.3 |
| 454 | 1.7.7.1.20.3.4.1 | iOS |  | 3d? | 2018-06-11 A | 2018-06-13 A | 100% |  | 2018-06-25 | 2018-07-06 | 10d? | 2018-06-11 | 2018-06-13 |  | finish no earlier than 2018-06-13 | Dominic Johnson | 24h | 24h | 24 | 24 |  | Robert (CFI) | 0.3 |
| 455 | 1.7.7.1.20.3.4.2 | Android |  | 3d? | 2018-06-11 A | 2018-06-13 A | 100% |  | 2018-06-25 | 2018-07-06 | 10d? | 2018-06-11 | 2018-06-13 |  | finish no earlier than 2018-06-13 | Dominic Johnson | 24h | 24h | 24 | 24 |  | Robert (CFI) | 0.3 |
| 456 | 1.7.7.1.20.3.5 | Usability Testing |  | 3d? | 2018-06-11 A | 2018-06-13 A | 100% |  | 2018-07-02 | 2018-07-13 | 10d? | 2018-06-11 | 2018-06-13 |  | finish no earlier than 2018-06-13 | Dominic Johnson | 24h | 24h | 24 | 24 |  | Robert (CFI) | 0.3 |
| 457 | 1.7.7.1.20.3.6 | Bug Fixing |  | 3d? | 2018-06-11 A | 2018-06-13 A | 100% |  | 2018-07-09 | 2018-07-20 | 10d? | 2018-06-11 | 2018-06-13 |  | finish no earlier than 2018-06-13 | Ali Dorton | 24h | 24h | 24 | 24 |  | Robert (CFI) | 0.3 |
| 458 | 1.7.7.1.20.4 | Marketing sign-off |  | 3d? | 2018-06-11 A | 2018-06-13 A | 100% |  | 2018-07-16 | 2018-07-27 | 10d? | 2018-06-11 | 2018-06-13 |  | finish no earlier than 2018-06-13 | Deana Kreitz | 24h | 24h | 24 | 24 |  | Robert (CFI) | 0.3 |

| ID | WBS | Task | Duration | Start | Finish | Complete | Remaining | Baseline start | Baseline finish | Baseline duration | Baseline 1 start | Baseline 1 finish | Total slack | Constraint | Work | Actual work | Cost | Actual cost | Audience | Text12 |
| --- | --- | --- | --- | --- | --- | --- | --- | --- | --- | --- | --- | --- | --- | --- | --- | --- | --- | --- | --- | --- |
| 459 | 1.7.7.1.21 | **Feedback** | 40d? | 2018-06-04 | 2018-07-27 |  |  | 2018-06-04 | 2018-07-27 | 40d? | 2018-06-04 | 2018-07-27 | 111d |  |  |  |  |  | Students |  |
| 460 | 1.7.7.1.21.1 | Web hook | 20d? | 2018-06-04 | 2018-06-29 |  |  | 2018-06-04 | 2018-06-29 | 20d? | 2018-06-04 | 2018-06-29 | 131d | finish no earlier than 2018-06-29 |  |  |  |  |  |  |
| 461 | 1.7.7.1.21.2 | **Testing** | 30d? | 2018-06-11 | 2018-07-20 |  |  | 2018-06-11 | 2018-07-20 | 30d? | 2018-06-11 | 2018-07-20 | 116d |  |  |  |  |  |  |  |
| 462 | 1.7.7.1.21.2.1 | Dev Testing | 15d? | 2018-06-11 | 2018-06-29 |  |  | 2018-06-11 | 2018-06-29 | 15d? | 2018-06-11 | 2018-06-29 | 131d | finish no earlier than 2018-06-29 |  |  |  |  |  |  |
| 463 | 1.7.7.1.21.2.2 | UI/UX Testing | 15d? | 2018-06-18 | 2018-07-06 |  |  | 2018-06-18 | 2018-07-06 | 15d? | 2018-06-18 | 2018-07-06 | 126d | finish no earlier than 2018-07-06 |  |  |  |  |  |  |
| 464 | 1.7.7.1.21.2.3 | BO Testing | 15d? | 2018-06-25 | 2018-07-13 |  |  | 2018-06-25 | 2018-07-13 | 15d? | 2018-06-25 | 2018-07-13 | 121d | finish no earlier than 2018-07-13 |  |  |  |  |  |  |
| 465 | 1.7.7.1.21.2.4 | **Functional Testing** | 10d? | 2018-06-25 | 2018-07-06 |  |  | 2018-06-25 | 2018-07-06 | 10d? | 2018-06-25 | 2018-07-06 | 126d |  |  |  |  |  |  |  |
| 466 | 1.7.7.1.21.2.4.1 | iOS | 10d? | 2018-06-25 | 2018-07-06 |  |  | 2018-06-25 | 2018-07-06 | 10d? | 2018-06-25 | 2018-07-06 | 126d | finish no earlier than 2018-07-06 |  |  |  |  |  |  |
| 467 | 1.7.7.1.21.2.4.2 | Android | 10d? | 2018-06-25 | 2018-07-06 |  |  | 2018-06-25 | 2018-07-06 | 10d? | 2018-06-25 | 2018-07-06 | 126d | finish no earlier than 2018-07-06 |  |  |  |  |  |  |
| 468 | 1.7.7.1.21.2.5 | Usability Testing | 10d? | 2018-07-02 | 2018-07-13 |  |  | 2018-07-02 | 2018-07-13 | 10d? | 2018-07-02 | 2018-07-13 | 121d | finish no earlier than 2018-07-13 |  |  |  |  |  |  |
| 469 | 1.7.7.1.21.2.6 | Bug Fixing | 10d? | 2018-07-09 | 2018-07-20 |  |  | 2018-07-09 | 2018-07-20 | 10d? | 2018-07-09 | 2018-07-20 | 116d | finish no earlier than 2018-07-20 |  |  |  |  |  |  |
| 470 | 1.7.7.1.21.3 | Marketing sign-off | 10d? | 2018-07-16 | 2018-07-27 |  |  | 2018-07-16 | 2018-07-27 | 10d? | 2018-07-16 | 2018-07-27 | 111d | finish no earlier than 2018-07-27 |  |  |  |  |  |  |
| 471 | 1.7.7.1.22 | **EAB Guide** | 100d? | 2018-03-12 A | 2018-07-27 | 34% | 65.87d? | 2018-06-04 | 2018-07-27 | 40d? | 2018-03-12 | 2018-07-27 | 111d |  | 704h | 448h | 704 | 448 | Students | Robert (EAB Guide) |
| 472 | 1.7.7.1.22.1 | sent email requesting schema | 20d? | 2018-06-04 A | 2018-06-29 A | 100% |  | 2018-06-04 | 2018-06-29 | 20d? | 2018-06-04 | 2018-06-29 |  | finish no earlier than 2018-06-29 |  |  |  |  |  | Robert (EAB Guide) |
| 473 | 1.7.7.1.22.2 | **Testing** | 30d? | 2018-06-11 | 2018-07-20 |  |  | 2018-06-11 | 2018-07-20 | 30d? | 2018-06-11 | 2018-07-20 | 116d |  |  |  |  |  |  | Robert (EAB Guide) |
| 474 | 1.7.7.1.22.2.1 | Dev Testing | 15d? | 2018-06-11 | 2018-06-29 |  |  | 2018-06-11 | 2018-06-29 | 15d? | 2018-06-11 | 2018-06-29 | 131d | finish no earlier than 2018-06-29 |  |  |  |  |  |  |
| 475 | 1.7.7.1.22.2.2 | UI/UX Testing | 15d? | 2018-06-18 | 2018-07-06 |  |  | 2018-06-18 | 2018-07-06 | 15d? | 2018-06-18 | 2018-07-06 | 126d | finish no earlier than 2018-07-06 |  |  |  |  |  |  |
| 476 | 1.7.7.1.22.2.3 | BO Testing | 15d? | 2018-06-25 | 2018-07-13 |  |  | 2018-06-25 | 2018-07-13 | 15d? | 2018-06-25 | 2018-07-13 | 121d | finish no earlier than 2018-07-13 |  |  |  |  |  |  |
| 477 | 1.7.7.1.22.2.4 | **Functional Testing** | 10d? | 2018-06-25 | 2018-07-06 |  |  | 2018-06-25 | 2018-07-06 | 10d? | 2018-06-25 | 2018-07-06 | 126d |  |  |  |  |  |  |  |
| 478 | 1.7.7.1.22.2.4.1 | Mobile Web | 10d? | 2018-06-25 | 2018-07-06 |  |  | 2018-06-25 | 2018-07-06 | 10d? | 2018-06-25 | 2018-07-06 | 126d | finish no earlier than 2018-07-06 |  |  |  |  |  |  |
| 479 | 1.7.7.1.22.2.4.2 | iOS | 10d? | 2018-06-25 | 2018-07-06 |  |  | 2018-06-25 | 2018-07-06 | 10d? | 2018-06-25 | 2018-07-06 | 126d | finish no earlier than 2018-07-06 |  |  |  |  |  |  |
| 480 | 1.7.7.1.22.2.4.3 | Android | 10d? | 2018-06-25 | 2018-07-06 |  |  | 2018-06-25 | 2018-07-06 | 10d? | 2018-06-25 | 2018-07-06 | 126d | finish no earlier than 2018-07-06 |  |  |  |  |  |  |
| 481 | 1.7.7.1.22.2.5 | Usability Testing | 10d? | 2018-07-02 | 2018-07-13 |  |  | 2018-07-02 | 2018-07-13 | 10d? | 2018-07-02 | 2018-07-13 | 121d | finish no earlier than 2018-07-13 |  |  |  |  |  |  |
| 482 | 1.7.7.1.22.2.6 | Bug Fixing | 10d? | 2018-07-09 | 2018-07-20 |  |  | 2018-07-09 | 2018-07-20 | 10d? | 2018-07-09 | 2018-07-20 | 116d | finish no earlier than 2018-07-20 |  |  |  |  |  |  |
| 483 | 1.7.7.1.22.3 | Marketing sign-off | 30d? | 2018-06-18 A | 2018-07-27 | 50% | 15d? | 2018-07-16 | 2018-07-27 | 10d? | 2018-06-18 | 2018-07-27 | 111d | start no earlier than 2018-06-18 |  |  |  |  |  | Robert (EAB Guide) |

| ID | WBS | Task | Duration | Start | Finish | Complete | Remaining | Baseline start | Baseline finish | Baseline duration | Baseline 1 start | Baseline 1 finish | Total slack | Constraint | Resources | Work | Actual work | Cost | Actual cost | Text12 |
| --- | --- | --- | --- | --- | --- | --- | --- | --- | --- | --- | --- | --- | --- | --- | --- | --- | --- | --- | --- | --- |
| 484 | 1.7.7.1.22.4 | **Authentication/Security** | 68d? | 2018-03-12 A | 2018-06-13 | 99% | 0d? | 2018-02-20 | 2018-03-23 | 24d? | 2018-03-12 | 2018-06-13 | 0d |  | Ali Dorton | 704h | 448h | 704 | 448 | Robert (EAB Guide) |
| 485 | 1.7.7.1.22.4.1 | Determine authentication type (done) | 10d | 2018-03-12 A | 2018-03-23 A | 100% |  | 2018-03-12 | 2018-03-23 | 10d | 2018-03-12 | 2018-03-23 |  | finish no earlier than 2018-03-23 | Ali Dorton | 80h | 80h | 80 | 80 | Robert (EAB Guide) |
| 486 | 1.7.7.1.22.4.2 | Set up Shibboleth | 1d? | 2018-06-13 A | 2018-06-13 A | 100% |  | 2018-02-20 | 2018-02-20 | 1d? | 2018-06-13 | 2018-06-13 |  | start no earlier than 2018-06-18 |  |  |  |  |  | Robert (EAB Guide) |
| 487 | 1.7.7.1.22.4.3 | Apply to either modules or persona | 10d | 2018-03-12 A | 2018-03-23 A | 100% |  | 2018-03-12 | 2018-03-23 | 10d | 2018-03-12 | 2018-03-23 |  | finish no earlier than 2018-03-23 | Ali Dorton | 80h | 80h | 80 | 80 | Robert (EAB Guide) |
| 488 | 1.7.7.1.22.4.4 | Authentication/Security Testing | 1d? | 2018-06-13 A | 2018-06-13 A | 100% |  | 2018-02-20 | 2018-02-20 | 1d? | 2018-06-13 | 2018-06-13 |  | start no earlier than 2018-06-13 |  |  |  |  |  | Robert (EAB Guide) |
| 489 | 1.7.8 | **Personas** | 40d? | 2018-06-04 A | 2018-07-27 | 5% | 38.15d? | 2018-06-04 | 2018-07-27 | 40d? | 2018-06-04 | 2018-07-27 | 111d |  |  |  |  |  |  | Edu (Personas) |
| 490 | 1.7.8.1 | University of Houston | 5d | 2018-06-04 A | 2018-06-22 | 30% | 3.5d | 2018-06-04 | 2018-06-22 | 5d | 2018-06-04 | 2018-06-22 | 136d | finish no earlier than 2018-06-22 |  |  |  |  |  | Edu (Personas) |
| 491 | 1.7.8.2 | Student | 5d | 2018-06-04 A | 2018-06-22 | 30% | 3.5d | 2018-06-04 | 2018-06-22 | 5d | 2018-06-04 | 2018-06-22 | 136d | finish no earlier than 2018-06-22 |  |  |  |  |  | Edu (Personas) |
| 492 | 1.7.8.3 | **Testing** | 25d? | 2018-06-18 | 2018-07-20 |  |  | 2018-06-18 | 2018-07-20 | 25d? | 2018-06-18 | 2018-07-20 | 116d |  |  |  |  |  |  | Edu (Personas) |
| 493 | 1.7.8.3.1 | Dev Testing | 5d? | 2018-06-18 | 2018-06-22 |  |  | 2018-06-18 | 2018-06-22 | 5d? | 2018-06-18 | 2018-06-22 | 136d | finish no earlier than 2018-06-22 |  |  |  |  |  | Edu (Personas) |
| 494 | 1.7.8.3.2 | UI/UX Testing | 5d? | 2018-06-25 | 2018-06-29 |  |  | 2018-06-25 | 2018-06-29 | 5d? | 2018-06-25 | 2018-06-29 | 131d | finish no earlier than 2018-06-29 |  |  |  |  |  | Edu (Personas) |
| 495 | 1.7.8.3.3 | BO Testing | 5d? | 2018-07-02 | 2018-07-06 |  |  | 2018-07-02 | 2018-07-06 | 5d? | 2018-07-02 | 2018-07-06 | 126d | finish no earlier than 2018-07-06 |  |  |  |  |  | Edu (Personas) |
| 496 | 1.7.8.3.4 | **Functional Testing** | 5d? | 2018-06-25 | 2018-06-29 |  |  | 2018-06-25 | 2018-06-29 | 5d? | 2018-06-25 | 2018-06-29 | 131d |  |  |  |  |  |  | Edu (Personas) |
| 497 | 1.7.8.3.4.1 | iOS | 5d? | 2018-06-25 | 2018-06-29 |  |  | 2018-06-25 | 2018-06-29 | 5d? | 2018-06-25 | 2018-06-29 | 131d | finish no earlier than 2018-06-29 |  |  |  |  |  | Edu (Personas) |
| 498 | 1.7.8.3.4.2 | Android | 5d? | 2018-06-25 | 2018-06-29 |  |  | 2018-06-25 | 2018-06-29 | 5d? | 2018-06-25 | 2018-06-29 | 131d | finish no earlier than 2018-06-29 |  |  |  |  |  | Edu (Personas) |
| 499 | 1.7.8.3.5 | Usability Testing | 10d? | 2018-07-02 | 2018-07-13 |  |  | 2018-07-02 | 2018-07-13 | 10d? | 2018-07-02 | 2018-07-13 | 121d | finish no earlier than 2018-07-13 |  |  |  |  |  | Edu (Personas) |
| 500 | 1.7.8.3.6 | Bug Fixing | 10d? | 2018-07-09 | 2018-07-20 |  |  | 2018-07-09 | 2018-07-20 | 10d? | 2018-07-09 | 2018-07-20 | 116d | finish no earlier than 2018-07-20 |  |  |  |  |  | Edu (Personas) |
| 501 | 1.7.8.4 | Marketing sign-off | 10d? | 2018-07-16 | 2018-07-27 |  |  | 2018-07-16 | 2018-07-27 | 10d? | 2018-07-16 | 2018-07-27 | 111d | finish no earlier than 2018-07-27 |  |  |  |  |  | Edu (Personas) |
| 502 | 1.7.9 | **Locations** | 40d? | 2018-06-04 | 2018-07-27 |  |  | 2018-06-04 | 2018-07-27 | 40d? | 2018-06-04 | 2018-07-27 | 111d |  |  |  |  |  |  | Diane (Locations) |
| 503 | 1.7.9.1 | Central | 15d? | 2018-06-04 | 2018-06-22 |  |  | 2018-06-04 | 2018-06-22 | 15d? | 2018-06-04 | 2018-06-22 | 136d | finish no earlier than 2018-06-22 |  |  |  |  |  | Diane (Locations) |
| 504 | 1.7.9.2 | Sugar Land | 15d? | 2018-06-04 | 2018-06-22 |  |  | 2018-06-04 | 2018-06-22 | 15d? | 2018-06-04 | 2018-06-22 | 136d | finish no earlier than 2018-06-22 |  |  |  |  |  | Diane (Locations) |
| 505 | 1.7.9.3 | **Testing** | 25d? | 2018-06-18 | 2018-07-20 |  |  | 2018-06-18 | 2018-07-20 | 25d? | 2018-06-18 | 2018-07-20 | 116d |  |  |  |  |  |  | Diane (Locations) |
| 506 | 1.7.9.3.1 | Dev Testing | 5d? | 2018-06-18 | 2018-06-22 |  |  | 2018-06-18 | 2018-06-22 | 5d? | 2018-06-18 | 2018-06-22 | 136d | finish no earlier than 2018-06-22 |  |  |  |  |  | Diane (Locations) |
| 507 | 1.7.9.3.2 | UI/UX Testing | 5d? | 2018-06-25 | 2018-06-29 |  |  | 2018-06-25 | 2018-06-29 | 5d? | 2018-06-25 | 2018-06-29 | 131d | finish no earlier than 2018-06-29 |  |  |  |  |  | Diane (Locations) |
| 508 | 1.7.9.3.3 | BO Testing | 5d? | 2018-07-02 | 2018-07-06 |  |  | 2018-07-02 | 2018-07-06 | 5d? | 2018-07-02 | 2018-07-06 | 126d | finish no earlier than 2018-07-06 |  |  |  |  |  | Diane (Locations) |

Notes:
- 490: Still in scope for Aug Implementation?
- 491: Still in scope for Aug Implementation?

| ID | WBS | Task | Type | Duration | Start | Finish | Predecessors | Complete | Remaining | Baseline start | Baseline finish | Baseline duration | Baseline 1 start | Baseline 1 finish | Total slack | Free slack | Constraint | Resources | Work | Actual work | Cost | Actual cost | Text12 |
| --- | --- | --- | --- | --- | --- | --- | --- | --- | --- | --- | --- | --- | --- | --- | --- | --- | --- | --- | --- | --- | --- | --- | --- |
| 509 | 1.7.9.3.4 | **Functional Testing** |  | 5d? | 2018-06-25 | 2018-06-29 |  |  |  | 2018-06-25 | 2018-06-29 | 5d? | 2018-06-25 | 2018-06-29 | 131d |  |  |  |  |  |  |  | Diane (Locations) |
| 510 | 1.7.9.3.4.1 | iOS |  | 5d? | 2018-06-25 | 2018-06-29 |  |  |  | 2018-06-25 | 2018-06-29 | 5d? | 2018-06-25 | 2018-06-29 | 131d |  | finish no earlier than 2018-06-29 |  |  |  |  |  | Diane (Locations) |
| 511 | 1.7.9.3.4.2 | Android |  | 5d? | 2018-06-25 | 2018-06-29 |  |  |  | 2018-06-25 | 2018-06-29 | 5d? | 2018-06-25 | 2018-06-29 | 131d |  | finish no earlier than 2018-06-29 |  |  |  |  |  | Diane (Locations) |
| 512 | 1.7.9.3.5 | Usability Testing |  | 10d? | 2018-07-02 | 2018-07-13 |  |  |  | 2018-07-02 | 2018-07-13 | 10d? | 2018-07-02 | 2018-07-13 | 121d |  | finish no earlier than 2018-07-13 |  |  |  |  |  | Diane (Locations) |
| 513 | 1.7.9.3.6 | Bug Fixing |  | 10d? | 2018-07-09 | 2018-07-20 |  |  |  | 2018-07-09 | 2018-07-20 | 10d? | 2018-07-09 | 2018-07-20 | 116d |  | finish no earlier than 2018-07-20 |  |  |  |  |  | Diane (Locations) |
| 514 | 1.7.9.4 | Marketing sign-off |  | 10d? | 2018-07-16 | 2018-07-27 |  |  |  | 2018-07-16 | 2018-07-27 | 10d? | 2018-07-16 | 2018-07-27 | 111d |  | finish no earlier than 2018-07-27 |  |  |  |  |  | Diane (Locations) |
| 515 | 1.7.10 | **Roles and Security** |  | 5d? | 2018-05-21 A | 2018-05-25 A |  | 100% |  | 2018-05-21 | 2018-05-25 | 5d? | 2018-05-21 | 2018-05-25 |  |  |  |  | 120h | 120h | 120 | 120 |  |
| 516 | 1.7.10.1 | Create |  | 5d? | 2018-05-21 A | 2018-05-25 A |  | 100% |  | 2018-05-21 | 2018-05-25 | 5d? | 2018-05-21 | 2018-05-25 |  |  | finish no earlier than 2018-05-25 | Ali Dorton | 40h | 40h | 40 | 40 |  |
| 517 | 1.7.10.2 | Communicate |  | 5d? | 2018-05-21 A | 2018-05-25 A |  | 100% |  | 2018-05-21 | 2018-05-25 | 5d? | 2018-05-21 | 2018-05-25 |  |  | finish no earlier than 2018-05-25 | Ali Dorton | 40h | 40h | 40 | 40 |  |
| 518 | 1.7.10.3 | Analyze |  | 5d? | 2018-05-21 A | 2018-05-25 A |  | 100% |  | 2018-05-21 | 2018-05-25 | 5d? | 2018-05-21 | 2018-05-25 |  |  | finish no earlier than 2018-05-25 | Ali Dorton | 40h | 40h | 40 | 40 |  |
| 519 | 1.7.11 | **Prepare App for Stores in Modo** |  | 2d? | 2018-07-30 | 2018-07-31 | 185, 191 |  |  | 2018-07-30 | 2018-07-31 | 2d? | 2018-07-30 | 2018-07-31 | 109d |  |  |  |  |  |  |  |  |
| 520 | 1.7.11.1 | TestFlight |  | 2d? | 2018-07-30 | 2018-07-31 |  |  |  | 2018-07-30 | 2018-07-31 | 2d? | 2018-07-30 | 2018-07-31 | 109d |  | finish no earlier than 2018-07-31 |  |  |  |  |  |  |
| 521 | 1.7.12 | **App Submission** |  | 3d | 2018-08-01 A | 2018-08-03 |  | 11% | 2.67d | 2018-08-01 | 2018-08-03 | 3d | 2018-08-01 | 2018-08-03 | 106d |  |  |  |  |  |  |  |  |
| 522 | 1.7.12.1 | Submission checklists |  | 3d | 2018-08-01 A | 2018-08-03 |  | 33% | 2d | 2018-08-01 | 2018-08-03 | 3d | 2018-08-01 | 2018-08-03 | 106d |  | finish no earlier than 2018-08-03 |  |  |  |  |  |  |
| 523 | 1.7.12.2 | Publish mobile website |  | 3d | 2018-08-01 A | 2018-08-03 |  | 33% | 2d | 2018-08-01 | 2018-08-03 | 3d | 2018-08-01 | 2018-08-03 | 106d |  | finish no earlier than 2018-08-03 |  |  |  |  |  |  |
| 524 | 1.7.12.3 | Submit iOS app to app store |  | 3d | 2018-08-01 | 2018-08-03 |  |  |  | 2018-08-01 | 2018-08-03 | 3d | 2018-08-01 | 2018-08-03 | 106d |  | finish no earlier than 2018-08-03 |  |  |  |  |  |  |
| 525 | 1.7.12.4 | Wait for app store approval |  | 3d | 2018-08-01 | 2018-08-03 |  |  |  | 2018-08-01 | 2018-08-03 | 3d | 2018-08-01 | 2018-08-03 | 106d |  | finish no earlier than 2018-08-03 |  |  |  |  |  |  |
| 526 | 1.7.12.5 | iOS app release in app store |  | 3d | 2018-08-01 | 2018-08-03 |  |  |  | 2018-08-01 | 2018-08-03 | 3d | 2018-08-01 | 2018-08-03 | 106d |  | finish no earlier than 2018-08-03 |  |  |  |  |  |  |
| 527 | 1.7.12.6 | Submit android app |  | 3d | 2018-08-01 | 2018-08-03 |  |  |  | 2018-08-01 | 2018-08-03 | 3d | 2018-08-01 | 2018-08-03 | 106d |  | finish no earlier than 2018-08-03 |  |  |  |  |  |  |
| 528 | 1.7.12.7 | MS: Go-Live (Modo Applications) | milestone, manual | 0d | 2018-08-01 | 2018-08-01 |  |  |  |  |  |  | 2018-08-01 | 2018-08-01 |  |  |  |  |  |  |  |  |  |
| 529 | 1.7.12.8 | MS: Go-Live (Grey Heller) | milestone, manual | 0d | 2018-08-01 | 2018-08-01 |  |  |  |  |  |  | 2018-08-01 | 2018-08-01 |  |  |  |  |  |  |  |  |  |
| 530 | 1.7.13 | **Business Owner Training** |  | 15d? | 2018-06-19 | 2018-07-09 |  |  |  | 2018-06-18 | 2018-07-06 | 15d? | 2018-06-19 | 2018-07-09 | 125d |  |  |  |  |  |  |  |  |
| 531 | 1.7.13.1 | Marketing Training |  | 5d | 2018-07-03 | 2018-07-09 | 532 |  |  | 2018-07-02 | 2018-07-06 | 5d | 2018-07-03 | 2018-07-09 | 125d |  |  |  |  |  |  |  |  |
| 532 | 1.7.13.2 | Auxiliary Services Training |  | 10d? | 2018-06-19 | 2018-07-02 |  |  |  | 2018-06-18 | 2018-06-29 | 10d? | 2018-06-19 | 2018-07-02 | 125d | 0d | start no earlier than 2018-06-18 |  |  |  |  |  |  |
| 533 | 1.7.13.3 | Housing Training |  | 10d? | 2018-06-19 | 2018-07-02 |  |  |  | 2018-06-18 | 2018-06-29 | 10d? | 2018-06-19 | 2018-07-02 | 130d |  | start no earlier than 2018-06-18 |  |  |  |  |  |  |
| 534 | 1.7.13.4 | Enrollment Services Training |  | 10d? | 2018-06-19 | 2018-07-02 |  |  |  | 2018-06-18 | 2018-06-29 | 10d? | 2018-06-19 | 2018-07-02 | 130d |  | start no earlier than 2018-06-18 |  |  |  |  |  |  |

| ID | WBS | Task | Type | Duration | Start | Finish | Complete | Remaining | Baseline start | Baseline finish | Baseline duration | Baseline 1 start | Baseline 1 finish | Total slack | Constraint | Work | Actual work | Cost | Actual cost | Text13 |
| --- | --- | --- | --- | --- | --- | --- | --- | --- | --- | --- | --- | --- | --- | --- | --- | --- | --- | --- | --- | --- |
| 535 | 1.7.14 | **Establish Institutional Policies** |  | 10d? | 2018-05-21 | 2018-06-01 |  |  | 2018-05-21 | 2018-06-01 | 10d? | 2018-05-21 | 2018-06-01 | 151d |  |  |  |  |  |  |
| 536 | 1.7.14.1 | **App Policies** |  | 10d? | 2018-05-21 | 2018-06-01 |  |  | 2018-05-21 | 2018-06-01 | 10d? | 2018-05-21 | 2018-06-01 | 151d |  |  |  |  |  |  |
| 537 | 1.7.14.1.1 | Permissions Policy |  | 5d? | 2018-05-21 | 2018-05-25 |  |  | 2018-05-21 | 2018-05-25 | 5d? | 2018-05-21 | 2018-05-25 | 156d | finish no earlier than 2018-05-25 |  |  |  |  |  |
| 538 | 1.7.14.1.2 | Publishing & Deployment Policy |  | 4d | 2018-05-29 | 2018-06-01 |  |  | 2018-05-29 | 2018-06-01 | 4d | 2018-05-29 | 2018-06-01 | 151d | finish no earlier than 2018-06-01 |  |  |  |  |  |
| 539 | 1.7.14.1.3 | Admin Policy |  | 4d? | 2018-05-29 | 2018-06-01 |  |  | 2018-05-29 | 2018-06-01 | 4d? | 2018-05-29 | 2018-06-01 | 151d | finish no earlier than 2018-06-01 |  |  |  |  |  |
| 540 | 1.7.14.1.4 | Naming Convention |  | 4d? | 2018-05-29 | 2018-06-01 |  |  | 2018-05-29 | 2018-06-01 | 4d? | 2018-05-29 | 2018-06-01 | 151d | finish no earlier than 2018-06-01 |  |  |  |  |  |
| 541 | 2 | **Deffered Tasks** |  | 218d? | 2018-03-01 A | 2018-12-31 | 2% | 212.78d? | 2018-02-20 | 2018-12-31 | 225d | 2018-03-01 | 2018-12-31 | 0d |  | 2232h | 662.65h | 2,232 | 662.65 | 1.95 |
| 542 | 2.1 | **Indoor maps - DEFERRED** |  | 86d | 2018-09-03 A | 2018-12-31 |  | 85.82d | 2018-09-03 | 2018-12-31 | 86d | 2018-09-03 | 2018-12-31 |  |  |  |  |  |  |  |
| 543 | 2.1.1 | Floor plans | manual | 86d | 2018-09-03 A | 2018-12-31 | 1% | 85d | 2018-09-03 | 2018-12-31 | 86d | 2018-09-03 | 2018-12-31 |  |  |  |  |  |  |  |
| 544 | 2.1.2 | Google Maps | manual | 86d | 2018-09-03 A | 2018-12-31 | 1% | 85d | 2018-09-03 | 2018-12-31 | 86d | 2018-09-03 | 2018-12-31 |  |  |  |  |  |  |  |
| 545 | 2.1.3 | **Testing** |  | 86d | 2018-09-03 | 2018-12-31 |  |  | 2018-09-03 | 2018-12-31 | 86d | 2018-09-03 | 2018-12-31 |  |  |  |  |  |  |  |
| 546 | 2.1.3.1 | Dev Testing | manual | 86d | 2018-09-03 | 2018-12-31 |  |  | 2018-09-03 | 2018-12-31 | 86d | 2018-09-03 | 2018-12-31 |  |  |  |  |  |  |  |
| 547 | 2.1.3.2 | UI/UX Testing | manual | 86d | 2018-09-03 | 2018-12-31 |  |  | 2018-09-03 | 2018-12-31 | 86d | 2018-09-03 | 2018-12-31 |  |  |  |  |  |  |  |
| 548 | 2.1.3.3 | BO Testing | manual | 86d | 2018-09-03 | 2018-12-31 |  |  | 2018-09-03 | 2018-12-31 | 86d | 2018-09-03 | 2018-12-31 |  |  |  |  |  |  |  |
| 549 | 2.1.3.4 | **Functional Testing** |  | 86d | 2018-09-03 | 2018-12-31 |  |  | 2018-09-03 | 2018-12-31 | 86d | 2018-09-03 | 2018-12-31 |  |  |  |  |  |  |  |
| 550 | 2.1.3.4.1 | Mobile Web | manual | 86d | 2018-09-03 | 2018-12-31 |  |  | 2018-09-03 | 2018-12-31 | 86d | 2018-09-03 | 2018-12-31 |  |  |  |  |  |  |  |
| 551 | 2.1.3.4.2 | iOS | manual | 86d | 2018-09-03 | 2018-12-31 |  |  | 2018-09-03 | 2018-12-31 | 86d | 2018-09-03 | 2018-12-31 |  |  |  |  |  |  |  |
| 552 | 2.1.3.4.3 | Android | manual | 86d | 2018-09-03 | 2018-12-31 |  |  | 2018-09-03 | 2018-12-31 | 86d | 2018-09-03 | 2018-12-31 |  |  |  |  |  |  |  |
| 553 | 2.1.3.5 | Usability Testing | manual | 86d | 2018-09-03 | 2018-12-31 |  |  | 2018-09-03 | 2018-12-31 | 86d | 2018-09-03 | 2018-12-31 |  |  |  |  |  |  |  |
| 554 | 2.1.3.6 | Bug Fixing | manual | 86d | 2018-09-03 | 2018-12-31 |  |  | 2018-09-03 | 2018-12-31 | 86d | 2018-09-03 | 2018-12-31 |  |  |  |  |  |  |  |
| 555 | 2.1.4 | Marketing sign-off | manual | 86d | 2018-09-03 | 2018-12-31 |  |  | 2018-09-03 | 2018-12-31 | 86d | 2018-09-03 | 2018-12-31 |  |  |  |  |  |  |  |
| 556 | 2.2 | **TouchNet - DEFERRED** |  | 86d? | 2018-09-03 | 2018-12-31 |  |  | 2018-09-03 | 2018-12-31 | 86d | 2018-09-03 | 2018-12-31 |  |  |  |  |  |  |  |
| 557 | 2.2.1 | Schedule technical meetings |  | 86d? | 2018-09-03 | 2018-12-31 |  |  | 2018-09-03 | 2018-12-31 | 86d? | 2018-09-03 | 2018-12-31 | 0d | start no earlier than 2018-09-03 |  |  |  |  |  |
| 558 | 2.3 | **Grade Center - DEFERRED** |  | 86d? | 2018-09-03 | 2018-12-31 |  |  | 2018-09-03 | 2018-12-31 | 86d | 2018-09-03 | 2018-12-31 |  |  |  |  |  |  |  |
| 559 | 2.3.1 | Stakeholder Meeting |  | 86d? | 2018-09-03 | 2018-12-31 |  |  | 2018-09-03 | 2018-12-31 | 86d? | 2018-09-03 | 2018-12-31 | 0d | finish no earlier than 2018-12-31 |  |  |  |  |  |
| 560 | 2.3.2 | Blackboard Integration |  | 86d? | 2018-09-03 | 2018-12-31 |  |  | 2018-09-03 | 2018-12-31 | 86d? | 2018-09-03 | 2018-12-31 | 0d | start no earlier than 2018-09-03 |  |  |  |  |  |
| 561 | 2.3.3 | PeopleSoft Integration |  | 86d? | 2018-09-03 | 2018-12-31 |  |  | 2018-09-03 | 2018-12-31 | 86d? | 2018-09-03 | 2018-12-31 | 0d | start no earlier than 2018-09-03 |  |  |  |  |  |
| 562 | 2.3.4 | Casa Integration |  | 1d? | 2018-12-31 | 2018-12-31 |  |  | 2018-12-31 | 2018-12-31 | 1d? | 2018-12-31 | 2018-12-31 | 0d | finish no earlier than 2018-12-31 |  |  |  |  |  |

| ID | WBS | Task | Duration | Start | Finish | Baseline start | Baseline finish | Baseline duration | Baseline 1 start | Baseline 1 finish | Total slack | Constraint | Resources | Work | Cost | Project Plan Phase |
| --- | --- | --- | --- | --- | --- | --- | --- | --- | --- | --- | --- | --- | --- | --- | --- | --- |
| 563 | 2.3.5 | **Testing** | 86d? | 2018-09-03 | 2018-12-31 | 2018-09-03 | 2018-12-31 | 86d | 2018-09-03 | 2018-12-31 |  |  |  |  |  |  |
| 564 | 2.3.5.1 | Dev Testing | 86d? | 2018-09-03 | 2018-12-31 | 2018-09-03 | 2018-12-31 | 86d? | 2018-09-03 | 2018-12-31 | 0d | start no earlier than 2018-09-03 |  |  |  |  |
| 565 | 2.3.5.2 | UI/UX Testing | 86d? | 2018-09-03 | 2018-12-31 | 2018-09-03 | 2018-12-31 | 86d? | 2018-09-03 | 2018-12-31 | 0d | start no earlier than 2018-09-03 |  |  |  |  |
| 566 | 2.3.5.3 | BO Testing | 86d? | 2018-09-03 | 2018-12-31 | 2018-09-03 | 2018-12-31 | 86d? | 2018-09-03 | 2018-12-31 | 0d | start no earlier than 2018-09-03 |  |  |  |  |
| 567 | 2.3.5.4 | **Functional Testing** | 86d? | 2018-09-03 | 2018-12-31 | 2018-09-03 | 2018-12-31 | 86d | 2018-09-03 | 2018-12-31 |  |  |  |  |  |  |
| 568 | 2.3.5.4.1 | Mobile Web | 86d? | 2018-09-03 | 2018-12-31 | 2018-09-03 | 2018-12-31 | 86d? | 2018-09-03 | 2018-12-31 | 0d | start no earlier than 2018-09-03 |  |  |  |  |
| 569 | 2.3.5.4.2 | iOS | 86d? | 2018-09-03 | 2018-12-31 | 2018-09-03 | 2018-12-31 | 86d? | 2018-09-03 | 2018-12-31 | 0d | start no earlier than 2018-09-03 |  |  |  |  |
| 570 | 2.3.5.4.3 | Android | 86d? | 2018-09-03 | 2018-12-31 | 2018-09-03 | 2018-12-31 | 86d? | 2018-09-03 | 2018-12-31 | 0d | start no earlier than 2018-09-03 |  |  |  |  |
| 571 | 2.3.5.5 | Usability Testing | 86d? | 2018-09-03 | 2018-12-31 | 2018-09-03 | 2018-12-31 | 86d? | 2018-09-03 | 2018-12-31 | 0d | start no earlier than 2018-09-03 |  |  |  |  |
| 572 | 2.3.5.6 | Bug Fixing | 86d? | 2018-09-03 | 2018-12-31 | 2018-09-03 | 2018-12-31 | 86d? | 2018-09-03 | 2018-12-31 | 0d | start no earlier than 2018-09-03 |  |  |  |  |
| 573 | 2.3.6 | Marketing sign-off | 86d? | 2018-09-03 | 2018-12-31 | 2018-09-03 | 2018-12-31 | 86d? | 2018-09-03 | 2018-12-31 | 0d | start no earlier than 2018-09-03 |  |  |  |  |
| 574 | 2.4 | **Institutional** | 54d | 2018-06-19 | 2018-08-31 | 2018-02-20 | 2018-08-31 | 139d | 2018-06-19 | 2018-08-31 | 86d |  |  | 528h | 528 |  |
| 575 | 2.4.1 | **MAPP creation** | 54d | 2018-06-19 | 2018-08-31 | 2018-06-06 | 2018-08-31 | 63d | 2018-06-19 | 2018-08-31 | 86d |  |  | 432h | 432 |  |
| 576 | 2.4.1.1 | Draft | 14d | 2018-06-19 | 2018-07-06 | 2018-06-06 | 2018-06-25 | 14d | 2018-06-19 | 2018-07-06 | 126d | start no earlier than 2018-06-18 | Diane Trippel | 112h | 112 |  |
| 577 | 2.4.1.2 | Final | 40d | 2018-07-09 | 2018-08-31 | 2018-07-09 | 2018-08-31 | 40d | 2018-07-09 | 2018-08-31 | 86d | start no earlier than 2018-07-09 | Marketing | 320h | 320 |  |
| 578 | 2.4.2 | Privacy Policy | 6d | 2018-06-19 | 2018-06-26 | 2018-02-20 | 2018-02-27 | 6d | 2018-06-19 | 2018-06-26 | 134d | start no earlier than 2018-06-18 | Diane Trippel; Deana Kreitz | 96h | 96 |  |
| 579 | 2.5 | **Grey Heller Future Phase** | 1d? | 2018-09-03 | 2018-09-03 | 2018-09-03 | 2018-09-03 | 1d? | 2018-09-03 | 2018-09-03 | 0d |  |  | 192h | 192 |  |
| 580 | 2.5.1 | **Admissions (Deferred)** | 1d? | 2018-09-03 | 2018-09-03 | 2018-09-03 | 2018-09-03 | 1d | 2018-09-03 | 2018-09-03 |  |  | Charita Hampton | 112h | 112 | ADMISSIONS |
| 581 | 2.5.1.1 | Admissions: Application Fee Payment | 1d | 2018-09-03 | 2018-09-03 | 2018-09-03 | 2018-09-03 | 1d | 2018-09-03 | 2018-09-03 | 85d |  | Charita Hampton | 8h | 8 | ADMISSIONS |
| 582 | 2.5.1.2 | Admissions: Apply for UH Scholarships | 1d? | 2018-09-03 | 2018-09-03 | 2018-09-03 | 2018-09-03 | 1d? | 2018-09-03 | 2018-09-03 | 85d |  | Charita Hampton | 8h | 8 | ADMISSIONS |
| 583 | 2.5.1.3 | Admissions: Application Status | 1d? | 2018-09-03 | 2018-09-03 | 2018-09-03 | 2018-09-03 | 1d? | 2018-09-03 | 2018-09-03 | 85d |  | Charita Hampton | 8h | 8 | ADMISSIONS |
| 584 | 2.5.1.4 | Admissions: New Student Conference | 1d? | 2018-09-03 | 2018-09-03 | 2018-09-03 | 2018-09-03 | 1d? | 2018-09-03 | 2018-09-03 | 85d |  | Charita Hampton | 8h | 8 | ADMISSIONS |
| 585 | 2.5.1.5 | **Testing** | 1d? | 2018-09-03 | 2018-09-03 | 2018-09-03 | 2018-09-03 | 1d? | 2018-09-03 | 2018-09-03 | 85d |  | Charita Hampton | 56h | 56 |  |
| 586 | 2.5.1.5.1 | Set up test accounts | 1d? | 2018-09-03 | 2018-09-03 | 2018-09-03 | 2018-09-03 | 1d? | 2018-09-03 | 2018-09-03 | 85d |  | Charita Hampton | 8h | 8 |  |
| 587 | 2.5.1.5.2 | Identify testers | 1d? | 2018-09-03 | 2018-09-03 | 2018-09-03 | 2018-09-03 | 1d? | 2018-09-03 | 2018-09-03 | 85d |  | Charita Hampton | 8h | 8 |  |
| 588 | 2.5.1.5.3 | Perform Dev Test | 1d? | 2018-09-03 | 2018-09-03 | 2018-09-03 | 2018-09-03 | 1d? | 2018-09-03 | 2018-09-03 | 85d |  | Rachel Honora | 8h | 8 |  |
| 589 | 2.5.1.5.4 | Perform UI/UX Test | 1d? | 2018-09-03 | 2018-09-03 | 2018-09-03 | 2018-09-03 | 1d? | 2018-09-03 | 2018-09-03 | 85d |  | Mardel Maxwell/Rolana Starr | 8h | 8 |  |
| 590 | 2.5.1.5.5 | Perform Functional Test | 1d? | 2018-09-03 | 2018-09-03 | 2018-09-03 | 2018-09-03 | 1d? | 2018-09-03 | 2018-09-03 | 85d |  | Deanna Kreitz/Rainer Schuhsler | 8h | 8 |  |
| 591 | 2.5.1.5.6 | Perform Usability Test | 1d | 2018-09-03 | 2018-09-03 | 2018-09-03 | 2018-09-03 | 1d | 2018-09-03 | 2018-09-03 | 85d | finish no earlier than 2018-06-01 | Dominic Johnson | 8h | 8 |  |
| 592 | 2.5.1.6 | Migrations | 1d? | 2018-09-03 | 2018-09-03 | 2018-09-03 | 2018-09-03 | 1d? | 2018-09-03 | 2018-09-03 | 85d |  | Charita Hampton | 8h | 8 |  |
| 593 | 2.5.1.7 | Move to Production | 1d? | 2018-09-03 | 2018-09-03 | 2018-09-03 | 2018-09-03 | 1d? | 2018-09-03 | 2018-09-03 | 85d |  | Charita Hampton | 8h | 8 |  |

Notes:
- 576: Is this different from Map?

| ID | WBS | Task | Type | Duration | Start | Finish | Complete | Remaining | Baseline start | Baseline finish | Baseline duration | Baseline 1 start | Baseline 1 finish | Total slack | Constraint | Resources | Work | Actual work | Cost | Actual cost | Project Plan Phase | Text11 | Text13 |
| --- | --- | --- | --- | --- | --- | --- | --- | --- | --- | --- | --- | --- | --- | --- | --- | --- | --- | --- | --- | --- | --- | --- | --- |
| 594 | 2.5.2 | **Faculty (Deferred)** |  | 1d? | 2018-09-03 | 2018-09-03 |  |  | 2018-09-03 | 2018-09-03 | 1d? | 2018-09-03 | 2018-09-03 | 85d |  | Charita Hampton | 80h |  | 80 |  | FACULTY |  |  |
| 595 | 2.5.2.1 | Faculty: Class Roster |  | 1d? | 2018-09-03 | 2018-09-03 |  |  | 2018-09-03 | 2018-09-03 | 1d? | 2018-09-03 | 2018-09-03 | 85d | start no earlier than 2018-09-03 | Charita Hampton | 8h |  | 8 |  | FACULTY |  |  |
| 596 | 2.5.2.2 | Faculty: Grade Roster |  | 1d? | 2018-09-03 | 2018-09-03 |  |  | 2018-09-03 | 2018-09-03 | 1d? | 2018-09-03 | 2018-09-03 | 85d | start no earlier than 2018-09-03 | Charita Hampton | 8h |  | 8 |  | FACULTY |  |  |
| 597 | 2.5.2.3 | Faculty: Faculty Center |  | 1d? | 2018-09-03 | 2018-09-03 |  |  | 2018-09-03 | 2018-09-03 | 1d? | 2018-09-03 | 2018-09-03 | 85d | start no earlier than 2018-09-03 | Charita Hampton | 8h |  | 8 |  | FACULTY |  |  |
| 598 | 2.5.2.4 | Faculty: Faculty Worklist |  | 1d? | 2018-09-03 | 2018-09-03 |  |  | 2018-09-03 | 2018-09-03 | 1d? | 2018-09-03 | 2018-09-03 | 85d | start no earlier than 2018-09-03 | Charita Hampton | 8h |  | 8 |  | FACULTY |  |  |
| 599 | 2.5.2.5 | **Testing** |  | 1d? | 2018-09-03 | 2018-09-03 |  |  | 2018-09-03 | 2018-09-03 | 1d? | 2018-09-03 | 2018-09-03 | 85d |  | Charita Hampton | 24h |  | 24 |  |  |  |  |
| 600 | 2.5.2.5.1 | Set up test accounts |  | 1d? | 2018-09-03 | 2018-09-03 |  |  | 2018-09-03 | 2018-09-03 | 1d? | 2018-09-03 | 2018-09-03 | 85d | start no earlier than 2018-09-03 | Charita Hampton | 8h |  | 8 |  |  |  |  |
| 601 | 2.5.2.5.2 | Identify testers |  | 1d? | 2018-09-03 | 2018-09-03 |  |  | 2018-09-03 | 2018-09-03 | 1d? | 2018-09-03 | 2018-09-03 | 85d | start no earlier than 2018-09-03 | Charita Hampton | 8h |  | 8 |  |  |  |  |
| 602 | 2.5.2.5.3 | Perform Dev Test |  | 1d? | 2018-09-03 | 2018-09-03 |  |  | 2018-09-03 | 2018-09-03 | 1d? | 2018-09-03 | 2018-09-03 | 85d | start no earlier than 2018-09-03 |  |  |  |  |  |  |  |  |
| 603 | 2.5.2.5.4 | Perform UI/UX Test |  | 1d? | 2018-09-03 | 2018-09-03 |  |  | 2018-09-03 | 2018-09-03 | 1d? | 2018-09-03 | 2018-09-03 | 85d | start no earlier than 2018-09-03 |  |  |  |  |  |  |  |  |
| 604 | 2.5.2.5.5 | Perform Functional Test |  | 1d? | 2018-09-03 | 2018-09-03 |  |  | 2018-09-03 | 2018-09-03 | 1d? | 2018-09-03 | 2018-09-03 | 85d | start no earlier than 2018-09-03 |  |  |  |  |  |  |  |  |
| 605 | 2.5.2.5.6 | Perform Usability Test |  | 1d? | 2018-09-03 | 2018-09-03 |  |  | 2018-09-03 | 2018-09-03 | 1d? | 2018-09-03 | 2018-09-03 | 85d | start no earlier than 2018-09-03 |  |  |  |  |  |  |  |  |
| 606 | 2.5.2.6 | Migrations |  | 1d? | 2018-09-03 | 2018-09-03 |  |  | 2018-09-03 | 2018-09-03 | 1d? | 2018-09-03 | 2018-09-03 | 85d | start no earlier than 2018-09-03 | Charita Hampton | 8h |  | 8 |  |  |  |  |
| 607 | 2.5.2.7 | Move to Production |  | 1d? | 2018-09-03 | 2018-09-03 |  |  | 2018-09-03 | 2018-09-03 | 1d? | 2018-09-03 | 2018-09-03 | 85d | start no earlier than 2018-09-03 | Charita Hampton | 8h |  | 8 |  |  |  |  |
| 608 | 2.6 | **Phase 5 - Advising** |  | 94d? | 2018-03-01 A | 2018-07-10 | 49% | 48.32d? | 2018-02-20 | 2018-07-09 | 100d? | 2018-03-01 | 2018-07-10 | 124d |  |  | 1512h | 662.65h | 1,512 | 662.65 | P5 | GH | 0.92 |
| 609 | 2.6.1 | Admissions: Application Fee Payment | manual | 1d? | 2018-03-01 | 2018-03-01 |  |  |  |  |  | 2018-03-01 | 2018-03-01 |  | start no earlier than 2018-06-18 |  |  |  |  |  |  | GH |  |
| 610 | 2.6.2 | Faculty: Faculty Center | manual | 1d? | 2018-03-01 | 2018-03-01 |  |  |  |  |  | 2018-03-01 | 2018-03-01 |  | start no earlier than 2018-06-18 |  |  |  |  |  |  | GH |  |
| 611 | 2.6.3 | Admissions: Apply for UH Scholarships | manual | 1d? | 2018-03-01 | 2018-03-01 |  |  |  |  |  | 2018-03-01 | 2018-03-01 |  | start no earlier than 2018-06-18 |  |  |  |  |  |  | GH |  |
| 612 | 2.6.4 | Faculty: Grade Roster | manual | 1d? | 2018-03-01 | 2018-03-01 |  |  |  |  |  | 2018-03-01 | 2018-03-01 |  | start no earlier than 2018-06-18 |  |  |  |  |  |  | GH |  |
| 613 | 2.6.5 | Faculty: Class Froster | manual | 1d? | 2018-03-01 | 2018-03-01 |  |  |  |  |  | 2018-03-01 | 2018-03-01 |  | start no earlier than 2018-06-18 |  |  |  |  |  |  | GH |  |
| 614 | 2.6.6 | Faculty: Faculty Worklist | manual | 1d? | 2018-03-01 | 2018-03-01 |  |  |  |  |  | 2018-03-01 | 2018-03-01 |  | start no earlier than 2018-06-18 |  |  |  |  |  |  | GH |  |
| 615 | 2.6.7 | Housing: Housing Information | manual | 1d? | 2018-03-01 | 2018-03-01 |  |  |  |  |  | 2018-03-01 | 2018-03-01 |  | start no earlier than 2018-06-18 |  |  |  |  |  |  | GH |  |
| 616 | 2.6.8 | Admissions: New Student Conference | manual | 1d? | 2018-03-01 | 2018-03-01 |  |  |  |  |  | 2018-03-01 | 2018-03-01 |  | start no earlier than 2018-06-18 |  |  |  |  |  |  | GH |  |
| 617 | 2.6.9 | Admissions: Application Status | manual | 1d? | 2018-03-01 | 2018-03-01 |  |  |  |  |  | 2018-03-01 | 2018-03-01 |  | start no earlier than 2018-06-18 |  |  |  |  |  |  | GH |  |
| 618 | 2.6.10 | Financial Aid: FSA ID Website link | manual | 1d? | 2018-03-01 | 2018-03-01 |  |  |  |  |  | 2018-03-01 | 2018-03-01 |  | start no earlier than 2018-06-18 |  |  |  |  |  |  | GH |  |
| 619 | 2.6.11 | Personal Info: Housing | manual | 1d? | 2018-03-01 | 2018-03-01 |  |  |  |  |  | 2018-03-01 | 2018-03-01 |  | start no earlier than 2018-06-18 |  |  |  |  |  |  | GH |  |
| 620 | 2.6.12 | Financial Aid: FAFSA on the web link | manual | 1d? | 2018-03-01 | 2018-03-01 |  |  |  |  |  | 2018-03-01 | 2018-03-01 |  | start no earlier than 2018-06-18 |  |  |  |  |  |  | GH |  |
| 621 | 2.6.13 | Personal Info: Demographic Information | manual | 1d? | 2018-03-01 | 2018-03-01 |  |  |  |  |  | 2018-03-01 | 2018-03-01 |  | start no earlier than 2018-06-18 |  |  |  |  |  |  | GH |  |
| 622 | 2.6.14 | Financial Aid: Student Loans link |  | 1d? | 2018-06-19 | 2018-06-19 |  |  | 2018-02-20 | 2018-02-20 | 1d? | 2018-06-19 | 2018-06-19 | 139d | start no earlier than 2018-06-18 | Charita Hampton | 8h |  | 8 |  | P5 | GH |  |
| 623 | 2.6.15 | JumpForward: JumpForward Website | manual | 1d? | 2018-03-01 | 2018-03-01 |  |  |  |  |  | 2018-03-01 | 2018-03-01 |  | start no earlier than 2018-06-18 |  |  |  |  |  |  | GH |  |
| 624 | 2.6.16 | Financial Aid: NSLDS Student Access link |  | 1d? | 2018-06-19 | 2018-06-19 |  |  | 2018-05-18 | 2018-05-18 | 1d? | 2018-06-19 | 2018-06-19 | 139d | start no earlier than 2018-06-18 | Charita Hampton | 8h |  | 8 |  | P5 | GH |  |

| ID | WBS | Task | Type | Duration | Start | Finish | Predecessors | Complete | Remaining | Baseline start | Baseline finish | Baseline duration | Baseline 1 start | Baseline 1 finish | Total slack | Free slack | Constraint | Resources | Work | Actual work | Cost | Actual cost | Text11 | Text13 |
| --- | --- | --- | --- | --- | --- | --- | --- | --- | --- | --- | --- | --- | --- | --- | --- | --- | --- | --- | --- | --- | --- | --- | --- | --- |
| 625 | 2.6.17 | **Testing** |  | 94d? | 2018-03-01 A | 2018-07-10 |  | 58% | 39.08d? | 2018-03-01 | 2018-07-09 | 93d? | 2018-03-01 | 2018-07-10 | 124d |  |  | Charita Hampton | 1464h | 662.65h | 1,464 | 662.65 | GH | 1.01 |
| 626 | 2.6.17.1 | Set up test accounts |  | 8d? | 2018-03-01 A | 2018-03-12 A |  | 100% |  | 2018-03-01 | 2018-03-12 | 8d? | 2018-03-01 | 2018-03-12 |  |  | finish no earlier than 2018-03-12 | Charita Hampton | 64h | 64h | 64 | 64 | GH |  |
| 627 | 2.6.17.2 | Identify testers |  | 44d? | 2018-03-01 A | 2018-05-01 A |  | 100% |  | 2018-03-01 | 2018-05-01 | 44d? | 2018-03-01 | 2018-05-01 |  |  | finish no earlier than 2018-05-01 | Charita Hampton | 352h | 352h | 352 | 352 | GH |  |
| 628 | 2.6.17.3 | Perform Dev Test |  | 5d? | 2018-05-21 | 2018-05-25 |  |  |  | 2018-05-21 | 2018-05-25 | 5d? | 2018-05-21 | 2018-05-25 | 125d | 0d | finish no earlier than 2018-05-25 | Nhi Nguyen | 40h |  | 40 |  | GH |  |
| 629 | 2.6.17.4 | Perform UI/UX Test |  | 15d? | 2018-05-28 | 2018-06-15 | 628 |  |  | 2018-05-28 | 2018-06-15 | 15d? | 2018-05-28 | 2018-06-15 | 125d | 1d | finish no earlier than 2018-06-15 | Deanna Kreitz/Rainer Schuhsler | 120h |  | 120 |  | GH |  |
| 630 | 2.6.17.5 | Perform Functional Test |  | 11d? | 2018-06-19 | 2018-07-03 | 629 |  |  | 2018-06-18 | 2018-07-02 | 11d? | 2018-06-19 | 2018-07-03 | 124d | 0d | start no earlier than 2018-06-18 | Teri Longacre/Melissa Pierson | 88h |  | 88 |  | GH |  |
| 631 | 2.6.17.6 | Perform Usability Test |  | 5d? | 2018-07-04 | 2018-07-10 | 630 |  |  | 2018-07-03 | 2018-07-09 | 5d? | 2018-07-04 | 2018-07-10 | 124d |  | finish no earlier than 2018-07-09 | Dominic Johnson | 40h |  | 40 |  | GH |  |
| 632 | 2.6.17.7 | Functional retest before moving to prod (links) | manual | 1d | 2018-07-02 | 2018-07-02 |  |  |  | 2018-07-02 | 2018-07-02 | 1d | 2018-07-02 | 2018-07-02 |  |  |  | Deana Kreitz | 8h |  | 8 |  | GH |  |
| 633 | 2.6.18 | **Migrations** |  | 2d? | 2018-07-03 | 2018-07-05 |  |  |  | 2018-06-11 | 2018-07-02 | 16d? | 2018-07-03 | 2018-07-05 | 0d |  |  | Charita Hampton | 32h |  | 32 |  | GH | 0.22 |
| 634 | 2.6.18.1 | Move to TEST | manual | 1d | 2018-07-03 | 2018-07-03 | 632 |  |  | 2018-06-11 | 2018-06-11 | 1d | 2018-07-03 | 2018-07-03 |  |  |  | Charita Hampton | 8h |  | 8 |  | GH |  |
| 635 | 2.6.18.2 | Move to Production |  | 1d? | 2018-07-04 | 2018-07-04 | 634 |  |  | 2018-07-02 | 2018-07-02 | 1d? | 2018-07-04 | 2018-07-04 | 128d | 0d | start no earlier than 2018-07-02 | Charita Hampton | 8h |  | 8 |  | GH |  |
| 636 | 2.6.18.3 | MS: Phase 5 Completed | milestone, manual | 0d | 2018-07-05 | 2018-07-05 | 635 |  |  |  |  |  | 2018-07-05 | 2018-07-05 |  |  |  |  |  |  |  |  | GH |  |
| 637 | 3 | MS: Go-Live | milestone, manual | 1d? | 2018-08-03 | 2018-08-03 |  |  |  |  |  |  | 2018-08-03 | 2018-08-03 |  |  |  |  |  |  |  |  |  |  |
| 638 | 4 | Integration Data Development / Testing Complete | manual | 1d | 2018-07-16 | 2018-07-16 |  |  |  |  |  |  | 2018-07-16 | 2018-07-16 |  |  |  |  |  |  |  |  |  |  |
| 639 | 5 | Data Integration Development / Testing Complete | milestone, manual | 1d? | 2018-07-16 | 2018-07-16 |  |  |  |  |  |  | 2018-07-16 | 2018-07-16 |  |  |  |  |  |  |  |  |  |  |
